# Subproyecto A3 : "Entrega de las Defensas Ribereñas del Río Lacramarca - Paquete 11 - R07"

How a schedule from Primavera P6 changed from version to version. A marks actual dates.

## Version 1 (data date 2023-05-01, saved 2023-05-03, file A3-1.xer)

| ID | WBS | Task | Duration | Start | Finish | Predecessors | Total float |
| --- | --- | --- | --- | --- | --- | --- | --- |
|  | A | **HITOS** |  | 2023-05-01 | 2023-11-16 |  |  |
| H1 |  | INICIO DE PLAZO CONTRACTUAL - ACCESO AL SITIO (16 días calendario despues del KOM) | 0d | 2023-05-01 | 2023-05-01 |  | 0d |
| H2 |  | INICIO DE EXCAVACION | 0d | 2023-05-06 | 2023-05-06 | H1 FS+5d | 0d |
| H3 |  | INICIO DE RELLENO DE DIQUE | 0d | 2023-05-22 | 2023-05-22 | 1.5.3.99 FS+3d | 178d |
| H4 |  | FIN DE PLAZO DE CONTRACTUAL - CULMINACION DE OBRAS | 0d | 2023-11-16 | 2023-11-16 | 1.4.2, 1.5.1.5, 1.5.2.5, 1.5.4.5, 2.1.5.2, 2.1.6.2, 2.2.5.2, 2.3.3.1, 2.4.1.2.6, 2.4.2.2.7, 2.5.8, 3.6, 4.4.3, 4.4.6, 5.2, 2.4.1.1.3, 2.1.6.8, 4.4.7, 2.4.2.2.6, 1.2.11, 1.4.4, 3.2, 3.1, 6.1, 6.2, 1.5.3.59, 1.5.5.149 | 0d |
|  | 1 | **DEFENSAS RIBEREÑAS** |  | 2023-05-01 | 2023-11-15 |  |  |
|  | 1 | **OBRAS PRELIMINARES** |  | 2023-05-01 | 2023-10-18 |  |  |
| 1.1.2 |  | INSTALACIONES PROVISIONALES PARA LA OBRA | 13d | 2023-05-01 | 2023-05-13 | H1 | 29d |
| 1.1.3 |  | MANTENIMIENTO DE TRÁNSITO Y SEGURIDAD VIAL | 159d | 2023-05-13 | 2023-10-18 | 1.2.1 FS-1d | 28d |
| 1.1.1 |  | CARTEL DE IDENTIFICACIÓN OBRA 4.80 x 3.60 m. | 5d | 2023-05-14 | 2023-05-18 | 1.2.1, H1 | 181d |
|  | 2 | **TRABAJOS PRELIMINARES** |  | 2023-05-01 | 2023-11-15 |  |  |
| 1.2.1 |  | MOVILIZACION DE EQUIPOS | 13d | 2023-05-01 | 2023-05-13 | H1 | 28d |
| 1.2.2 |  | TOPOGRAFÍA Y GEOREFERENCIACIÓN | 170d | 2023-05-01 | 2023-10-17 | 1.1.2 SS | 29d |
| 1.2.11 |  | DESMOVILIZACION DE EQUIPOS | 45d | 2023-10-02 | 2023-11-15 | 3.5, 3.3, 3.4 | 0d |
|  | 3 | **MEJORAMIENTO DE VÍAS EXISTENTES** |  | 2023-05-08 | 2023-06-01 |  |  |
|  | 1 | **MOVIMIENTO DE TIERRAS** |  | 2023-05-08 | 2023-06-01 |  |  |
| 1.3.1.1 |  | ROCE Y LIMPIEZA DE MALEZA | 4d | 2023-05-08 | 2023-05-11 | 1.2.2 SS+7d | 167d |
| 1.3.1.2 |  | MEJORAMIENTO DE VIAS EXISTENTES | 22d | 2023-05-11 | 2023-06-01 | 1.3.1.1 SS+3d | 167d |
|  | 2 | **REPOSICIÓN DE ESTRUCTURAS** |  | 2023-05-15 | 2023-05-23 |  |  |
| 1.3.2.1 |  | DEMOLICIÓN DE ESTRUCTURAS EXISTENTES | 3d | 2023-05-15 | 2023-05-17 | 1.3.1.2 SS+4d | 168d |
| 1.3.2.2 |  | REPOSICIÓN DE PASE DE AGUA TUBO HDPE Ø=18" | 3d | 2023-05-18 | 2023-05-20 | 1.3.2.1 | 168d |
| 1.3.2.3 |  | REPOSICIÓN DE PASE DE AGUA TUBO HDPE Ø=36" | 3d | 2023-05-18 | 2023-05-20 | 1.3.2.2 SS | 168d |
| 1.3.2.4 |  | SUMINISTRO Y MONTAJE DE PANELES DE C°A° 1.6mx1.0mx0.20m EN PASE DE AGUA | 3d | 2023-05-21 | 2023-05-23 | 1.3.2.3 | 168d |
| 1.3.2.5 |  | SUMINISTRO Y MONTAJE DE PANELES DE C°A° 2.20mx1.0mx0.20m EN PASE DE AGUA | 3d | 2023-05-21 | 2023-05-23 | 1.3.2.4 SS | 168d |
|  | 3 | **CABEZAL DE ENTRADA Y SALIDA** |  | 2023-05-24 | 2023-05-31 |  |  |
| 1.3.3.2 |  | ENCOFRADO Y DESENCOFRADO RECTO | 5d | 2023-05-24 | 2023-05-28 | 1.3.2.5 | 168d |
| 1.3.3.1 |  | CONCRETOS | 3d | 2023-05-29 | 2023-05-31 | 1.3.3.2 | 168d |
|  | 4 | **DESCOLMATACIÓN DE CAUCE y OBRAS AUXILIARES** |  | 2023-05-01 | 2023-10-23 |  |  |
| 1.4.1 |  | DESBROCE Y LIMPIEZA EN ZONA NO BOSCOSA | 43d | 2023-05-01 | 2023-06-12 | 1.2.1 SS | 146d |
| 1.4.2 |  | DESCOLMATACIÓN DE CAUCE NATURAL DEL RÍO LACRAMARCA | 43d | 2023-05-04 | 2023-06-15 | 1.4.1 SS+3d | 146d |
| 1.4.3 |  | CONFORMACIÓN DE DESVIO EN CAUCE DE RÍO | 40d | 2023-05-06 | 2023-06-14 | 1.4.2 SS+2d | 146d |
| 1.4.4 |  | RELLENO NO ESTRUCTURAL CON MATERIAL PROPIO | 33d | 2023-09-21 | 2023-10-23 | 1.4.3 SS+15d, 1.5.1.5, 1.5.2.5 | 23d |
|  | 5 | **DIQUES DE TIERRA COMPACTADA CON ENROCADO** |  | 2023-05-06 | 2023-11-15 |  |  |
|  | 1 | **DIQUE DE TIERRA COMPACTADA A3-D-01** |  | 2023-06-13 | 2023-08-06 |  |  |
| 1.5.1.1 |  | EXCAVACIÓN EN TERRENO NATURAL CON EQUIPO | 7d | 2023-06-13 | 2023-06-19 | H2, 1.5.2.1, 1.5.2.2, 1.5.3.89 | 65d |
| 1.5.1.2 |  | EXCAVACIÓN DE UÑA CON EQUIPO | 4d | 2023-06-20 | 2023-06-23 | 1.5.1.1 | 65d |
| 1.5.1.3 |  | PERFILADO Y COMPACTACIÓN EN ZONA DE CORTE | 5d | 2023-06-24 | 2023-06-28 | 1.5.1.2 | 65d |
| 1.5.1.9 |  | PREPARACIÓN DE FUNDACIÓN DE CUERPO DE DIQUE | 3d | 2023-06-29 | 2023-07-01 | 1.5.1.3 | 65d |
| 1.5.1.4 |  | CONFORMACIÓN DE CUERPO DE DIQUE CON MATERIAL PROPIO | 5d | 2023-07-02 | 2023-07-06 | 1.5.1.9 | 65d |
| 1.5.1.6 |  | GEOTEXTIL NO TEJIDO 400 G/M2, INC. COLOCACIÓN | 12d | 2023-07-07 | 2023-07-18 | 1.5.1.4 | 65d |
| 1.5.1.7 |  | COLOCACION Y ACOMODO DE ROCA EN UÑA DE DIQUE | 10d | 2023-07-11 | 2023-07-20 | 1.5.1.6 SS+4d | 65d |
| 1.5.1.8 |  | COLOCACION Y ACOMODO DE ROCA EN TALUD DE DIQUE | 14d | 2023-07-18 | 2023-07-31 | 1.5.1.7 SS+7d | 65d |
| 1.5.1.5 |  | CONFORMACIÓN DE CORONA DE DIQUE CON MATERIAL PROPIO | 6d | 2023-08-01 | 2023-08-06 | 1.5.1.8 | 68d |
|  | 2 | **DIQUE DE TIERRA COMPACTADA A3-D-02** |  | 2023-05-06 | 2023-09-20 |  |  |
| 1.5.2.1 |  | EXCAVACIÓN EN TERRENO NATURAL CON EQUIPO | 26d | 2023-05-06 | 2023-05-31 | H2 | 0d |
| 1.5.2.2 |  | EXCAVACIÓN DE UÑA CON EQUIPO | 12d | 2023-05-27 | 2023-06-07 | 1.5.2.1 FS-5d | 0d |
| 1.5.2.3 |  | PERFILADO Y COMPACTACIÓN EN ZONA DE CORTE | 11d | 2023-06-08 | 2023-06-18 | 1.5.2.2 | 0d |
| 1.5.2.9 |  | PREPARACIÓN DE FUNDACIÓN DE CUERPO DE DIQUE | 6d | 2023-06-19 | 2023-06-24 | 1.5.2.3 | 0d |
| 1.5.2.4 |  | CONFORMACIÓN DE CUERPO DE DIQUE CON MATERIAL PROPIO | 9d | 2023-06-22 | 2023-06-30 | 1.5.2.9 FS-3d | 0d |
| 1.5.2.6 |  | GEOTEXTIL NO TEJIDO 400 G/M2, INC. COLOCACIÓN | 45d | 2023-06-29 | 2023-08-12 | 1.5.2.4 FS-2d | 0d |
| 1.5.2.7 |  | COLOCACION Y ACOMODO DE ROCA EN UÑA DE DIQUE | 57d | 2023-07-02 | 2023-08-27 | 1.5.2.6 SS+3d | 0d |
| 1.5.2.8 |  | COLOCACION Y ACOMODO DE ROCA EN TALUD DE DIQUE | 48d | 2023-07-17 | 2023-09-02 | 1.5.2.7 SS+15d | 0d |
| 1.5.2.5 |  | CONFORMACIÓN DE CORONA DE DIQUE CON MATERIAL PROPIO | 18d | 2023-09-03 | 2023-09-20 | 1.5.2.8 | 23d |
|  | 3 | **DIQUE DE TIERRA COMPACTADA A3-I-01** |  | 2023-05-06 | 2023-09-01 |  |  |
|  | 1 | **DIQUE DE TIERRA COMPACTADA A3-I-01- 1 ETAPA** |  | 2023-05-06 | 2023-06-16 |  |  |
| 1.5.3.19 |  | EXCAVACIÓN EN TERRENO NATURAL CON EQUIPO | 7d | 2023-05-06 | 2023-05-12 | H2 | 0d |
| 1.5.3.29 |  | EXCAVACIÓN DE UÑA CON EQUIPO | 2d | 2023-05-13 | 2023-05-14 | 1.5.3.19 | 0d |
| 1.5.3.39 |  | PERFILADO Y COMPACTACIÓN EN ZONA DE CORTE | 2d | 2023-05-15 | 2023-05-16 | 1.5.3.29 | 0d |
| 1.5.3.99 |  | PREPARACIÓN DE FUNDACIÓN DE CUERPO DE DIQUE | 2d | 2023-05-17 | 2023-05-18 | 1.5.3.39 | 0d |
| 1.5.3.49 |  | CONFORMACIÓN DE CUERPO DE DIQUE CON MATERIAL PROPIO | 4d | 2023-05-19 | 2023-05-22 | 1.5.3.99 | 0d |
| 1.5.3.69 |  | GEOTEXTIL NO TEJIDO 400 G/M2, INC. COLOCACIÓN | 3d | 2023-05-23 | 2023-05-25 | 1.5.3.49 | 0d |
| 1.5.3.79 |  | COLOCACION Y ACOMODO DE ROCA EN UÑA DE DIQUE | 7d | 2023-05-26 | 2023-06-01 | 1.5.3.69 | 0d |
| 1.5.3.89 |  | COLOCACION Y ACOMODO DE ROCA EN TALUD DE DIQUE | 11d | 2023-06-02 | 2023-06-12 | 1.5.3.79, 1.5.3.79 FF | 65d |
| 1.5.3.59 |  | CONFORMACIÓN DE CORONA DE DIQUE CON MATERIAL PROPIO | 4d | 2023-06-13 | 2023-06-16 | 1.5.3.89 | 152d |
|  | 2 | **DIQUE DE TIERRA COMPACTADA A3-I-01- 2 ETAPA** |  | 2023-07-27 | 2023-09-01 |  |  |
| 1.5.3.100 |  | LIBERACIÓN DE PREDIOS A3-I-01 | 0d | 2023-07-27 | 2023-07-27 | H1 FS+87d | 0d |
| 1.5.3.109 |  | EXCAVACIÓN EN TERRENO NATURAL CON EQUIPO | 5d | 2023-07-27 | 2023-07-31 | 1.5.3.100 | 0d |
| 1.5.3.119 |  | EXCAVACIÓN DE UÑA CON EQUIPO | 3d | 2023-08-01 | 2023-08-03 | 1.5.3.109 | 0d |
| 1.5.3.129 |  | PERFILADO Y COMPACTACIÓN EN ZONA DE CORTE | 2d | 2023-08-04 | 2023-08-05 | 1.5.3.119 | 0d |
| 1.5.3.189 |  | PREPARACIÓN DE FUNDACIÓN DE CUERPO DE DIQUE | 2d | 2023-08-06 | 2023-08-07 | 1.5.3.129 | 0d |

| ID | WBS | Task | Duration | Start | Finish | Predecessors | Total float |
| --- | --- | --- | --- | --- | --- | --- | --- |
| 1.5.3.139 |  | CONFORMACIÓN DE CUERPO DE DIQUE CON MATERIAL PROPIO | 3d | 2023-08-08 | 2023-08-10 | 1.5.3.189 | 0d |
| 1.5.3.159 |  | GEOTEXTIL NO TEJIDO 400 G/M2, INC. COLOCACIÓN | 5d | 2023-08-11 | 2023-08-15 | 1.5.3.139 | 0d |
| 1.5.3.169 |  | COLOCACION Y ACOMODO DE ROCA EN UÑA DE DIQUE | 5d | 2023-08-16 | 2023-08-20 | 1.5.3.159 | 0d |
| 1.5.3.179 |  | COLOCACION Y ACOMODO DE ROCA EN TALUD DE DIQUE | 10d | 2023-08-21 | 2023-08-30 | 1.5.3.169, 1.5.3.169 FF | 0d |
| 1.5.3.149 |  | CONFORMACIÓN DE CORONA DE DIQUE CON MATERIAL PROPIO | 2d | 2023-08-31 | 2023-09-01 | 1.5.3.179 | 75d |
|  | 4 | **DIQUE DE TIERRA COMPACTADA A3-I-02** |  | 2023-05-06 | 2023-08-02 |  |  |
| 1.5.4.1 |  | EXCAVACIÓN EN TERRENO NATURAL CON EQUIPO | 27d | 2023-05-06 | 2023-06-01 | H2 | 12d |
| 1.5.4.2 |  | EXCAVACIÓN DE UÑA CON EQUIPO | 8d | 2023-06-02 | 2023-06-09 | 1.5.4.1 | 12d |
| 1.5.4.3 |  | PERFILADO Y COMPACTACIÓN EN ZONA DE CORTE | 7d | 2023-06-10 | 2023-06-16 | 1.5.4.2 | 12d |
| 1.5.4.9 |  | PREPARACIÓN DE FUNDACIÓN DE CUERPO DE DIQUE | 3d | 2023-06-17 | 2023-06-19 | 1.5.4.3 | 12d |
| 1.5.4.4 |  | CONFORMACIÓN DE CUERPO DE DIQUE CON MATERIAL PROPIO | 4d | 2023-06-20 | 2023-06-23 | 1.5.4.9 | 12d |
| 1.5.4.6 |  | GEOTEXTIL NO TEJIDO 400 G/M2, INC. COLOCACIÓN | 11d | 2023-06-24 | 2023-07-04 | 1.5.4.4 | 12d |
| 1.5.4.7 |  | COLOCACION Y ACOMODO DE ROCA EN UÑA DE DIQUE | 23d | 2023-06-27 | 2023-07-19 | 1.5.4.6 SS+3d | 12d |
| 1.5.4.8 |  | COLOCACION Y ACOMODO DE ROCA EN TALUD DE DIQUE | 16d | 2023-07-12 | 2023-07-27 | 1.5.4.7 SS+15d | 12d |
| 1.5.4.5 |  | CONFORMACIÓN DE CORONA DE DIQUE CON MATERIAL PROPIO | 6d | 2023-07-28 | 2023-08-02 | 1.5.4.8 | 105d |
|  | 5 | **DIQUE DE TIERRA COMPACTADA A3-I-03** |  | 2023-05-06 | 2023-11-15 |  |  |
|  | 1 | **DIQUE DE TIERRA COMPACTADA A3-I-03- 1 ETAPA** |  | 2023-05-06 | 2023-09-06 |  |  |
| 1.5.5.19 |  | EXCAVACIÓN EN TERRENO NATURAL CON EQUIPO | 22d | 2023-05-06 | 2023-05-27 | H2 | 70d |
| 1.5.5.29 |  | EXCAVACIÓN DE UÑA CON EQUIPO | 12d | 2023-05-28 | 2023-06-08 | 1.5.5.19 | 70d |
| 1.5.5.39 |  | PERFILADO Y COMPACTACIÓN EN ZONA DE CORTE | 11d | 2023-06-09 | 2023-06-19 | 1.5.5.29 | 70d |
| 1.5.5.99 |  | PREPARACIÓN DE FUNDACIÓN DE CUERPO DE DIQUE | 5d | 2023-06-20 | 2023-06-24 | 1.5.5.39 | 70d |
| 1.5.5.49 |  | CONFORMACIÓN DE CUERPO DE DIQUE CON MATERIAL PROPIO | 9d | 2023-06-23 | 2023-07-01 | 1.5.5.99 FS-2d | 70d |
| 1.5.5.69 |  | GEOTEXTIL NO TEJIDO 400 G/M2, INC. COLOCACIÓN | 33d | 2023-07-02 | 2023-08-03 | 1.5.5.49 | 70d |
| 1.5.5.79 |  | COLOCACION Y ACOMODO DE ROCA EN UÑA DE DIQUE | 29d | 2023-07-05 | 2023-08-02 | 1.5.5.69 SS+3d | 70d |
| 1.5.5.89 |  | COLOCACION Y ACOMODO DE ROCA EN TALUD DE DIQUE | 36d | 2023-07-20 | 2023-08-24 | 1.5.5.79 SS+15d | 70d |
| 1.5.5.59 |  | CONFORMACIÓN DE CORONA DE DIQUE CON MATERIAL PROPIO | 13d | 2023-08-25 | 2023-09-06 | 1.5.5.89 | 70d |
|  | 2 | **DIQUE DE TIERRA COMPACTADA A3-I-03- 2 ETAPA** |  | 2023-10-13 | 2023-11-15 |  |  |
| 1.5.5.108 |  | LIBERACION DE PREDIOS A3-I-03 | 0d | 2023-10-13 | 2023-10-13 | H2 FS+160d | 0d |
| 1.5.5.109 |  | EXCAVACIÓN EN TERRENO NATURAL CON EQUIPO | 3d | 2023-10-13 | 2023-10-15 | 1.5.5.108 | 0d |
| 1.5.5.119 |  | EXCAVACIÓN DE UÑA CON EQUIPO | 3d | 2023-10-16 | 2023-10-18 | 1.5.5.109 | 0d |
| 1.5.5.129 |  | PERFILADO Y COMPACTACIÓN EN ZONA DE CORTE | 2d | 2023-10-19 | 2023-10-20 | 1.5.5.119 | 0d |
| 1.5.5.139 |  | CONFORMACIÓN DE CUERPO DE DIQUE CON MATERIAL PROPIO | 2d | 2023-10-21 | 2023-10-22 | 1.5.5.189 FS-2d | 0d |
| 1.5.5.189 |  | PREPARACIÓN DE FUNDACIÓN DE CUERPO DE DIQUE | 2d | 2023-10-21 | 2023-10-22 | 1.5.5.129 | 0d |
| 1.5.5.159 |  | GEOTEXTIL NO TEJIDO 400 G/M2, INC. COLOCACIÓN | 4d | 2023-10-23 | 2023-10-26 | 1.5.5.139 | 0d |
| 1.5.5.169 |  | COLOCACION Y ACOMODO DE ROCA EN UÑA DE DIQUE | 4d | 2023-10-26 | 2023-10-29 | 1.5.5.159 SS+3d | 0d |
| 1.5.5.179 |  | COLOCACION Y ACOMODO DE ROCA EN TALUD DE DIQUE | 4d | 2023-11-10 | 2023-11-13 | 1.5.5.169 SS+15d | 0d |
| 1.5.5.149 |  | CONFORMACIÓN DE CORONA DE DIQUE CON MATERIAL PROPIO | 2d | 2023-11-14 | 2023-11-15 | 1.5.5.179 | 0d |
|  | 6 | **RAMPAS** |  | 2023-08-25 | 2023-09-02 |  |  |
| 1.6.1 |  | EXCAVACIÓN EN TERRENO NATURAL CON EQUIPO | 3d | 2023-08-25 | 2023-08-27 | 1.5.5.89 | 74d |
| 1.6.2 |  | CONFORMACIÓN DE CUERPO DE RAMPA CON MATERIAL PROPIO | 3d | 2023-08-28 | 2023-08-30 | 1.6.1 | 74d |
| 1.6.3 |  | CONFORMACIÓN DE CORONACIÓN DE RAMPA | 3d | 2023-08-31 | 2023-09-02 | 1.6.2 | 74d |
|  | 2 | **OBRAS DE ARTE** |  | 2023-05-01 | 2023-11-15 |  |  |
|  | 1 | **CAPTACIÓN A3-CP-23-95** |  | 2023-07-17 | 2023-11-15 |  |  |
|  | 1 | **MOVIMIENTO DE TIERRAS** |  | 2023-07-17 | 2023-08-25 |  |  |
| 2.1.1.1 |  | EXCAVACIÓN ESTRUCTURAL PARA OBRAS DE ARTE | 8d | 2023-07-17 | 2023-07-24 | 1.5.2.8 SS | 0d |
| 2.1.1.2 |  | RELLENO ESTRUCTURAL PARA OBRAS DE ARTE, CON MATERIAL PROPIO | 5d | 2023-08-21 | 2023-08-25 | 2.1.2.2 | 82d |
|  | 2 | **OBRAS DE CONCRETO** |  | 2023-07-25 | 2023-08-20 |  |  |
| 2.1.2.3 |  | CONCRETO CICLÓPEO f'c=280 kg/cm2 + 30% P.G. | 3d | 2023-07-25 | 2023-07-27 | 2.1.1.1 | 0d |
| 2.1.2.1 |  | CONCRETO f'c=100 kg/cm2 | 3d | 2023-07-28 | 2023-07-30 | 2.1.2.3 | 0d |
| 2.1.2.5 |  | ACERO DE REFUERZO fy=4200 kg/cm2 | 11d | 2023-07-31 | 2023-08-10 | 2.1.2.1 | 0d |
| 2.1.2.4 |  | ENCOFRADO Y DESENCOFRADO RECTO | 7d | 2023-08-09 | 2023-08-15 | 2.1.2.5 FS-2d | 0d |
| 2.1.2.2 |  | CONCRETO f'c=280 kg/cm2 | 5d | 2023-08-16 | 2023-08-20 | 2.1.2.4 | 0d |
|  | 3 | **ESTRUCTURAS METALICAS** |  | 2023-08-21 | 2023-09-04 |  |  |
| 2.1.3.1 |  | COMPUERTA METALICA PLANA DESLIZANTE DE 1.0x1.0m | 3d | 2023-08-21 | 2023-08-23 | 2.1.2.2 | 72d |
| 2.1.3.2 |  | REJILLA DE 1.00x1.00m CON VARILLA DE 1/2" CADA 6,25cm | 3d | 2023-08-24 | 2023-08-26 | 2.1.3.1 | 72d |
| 2.1.3.3 |  | BARANDA DE FIERRO GALVANIZADO 1 1/2" | 3d | 2023-08-27 | 2023-08-29 | 2.1.3.2 | 72d |
| 2.1.3.4 |  | ESCALERA TIPO GATO | 3d | 2023-08-30 | 2023-09-01 | 2.1.3.3 | 72d |
| 2.1.3.5 |  | TAPA METALICA CIRCULAR DN600 MM | 3d | 2023-09-02 | 2023-09-04 | 2.1.3.4 | 72d |
|  | 4 | **TUBERIAS** |  | 2023-08-21 | 2023-10-16 |  |  |
| 2.1.4.1 |  | EXCAVACIÓN ESTRUCTURAL PARA OBRAS DE ARTE (Buzones) | 5d | 2023-08-21 | 2023-08-25 | 2.1.2.2 | 0d |
| 2.1.4.6 |  | CONCRETO f'c=100 kg/cm2 (Buzones) | 3d | 2023-08-26 | 2023-08-28 | 2.1.4.1 | 30d |
| 2.1.4.10 |  | ACERO DE REFUERZO fy=4200 kg/cm2 (Buzones) | 5d | 2023-08-29 | 2023-09-02 | 2.1.4.6 | 30d |
| 2.1.4.9 |  | ENCOFRADO Y DESENCOFRADO CURVO | 5d | 2023-09-01 | 2023-09-05 | 2.1.4.10 FS-2d | 30d |
| 2.1.4.8 |  | ENCOFRADO Y DESENCOFRADO RECTO | 4d | 2023-09-06 | 2023-09-09 | 2.1.4.9 | 30d |
| 2.1.4.7 |  | CONCRETO f'c=280 kg/cm2 (Buzones) | 3d | 2023-09-10 | 2023-09-12 | 2.1.4.8 | 30d |
| 2.1.4.2 |  | EXCAVACIÓN DE ZANJA | 13d | 2023-09-13 | 2023-09-25 | 2.1.4.7, 2.1.2.2 | 30d |
| 2.1.4.3 |  | RELLENO ESTRUCTURAL PARA OBRAS DE ARTE CON MATERIAL PROPIO (Buzones) | 3d | 2023-09-13 | 2023-09-15 | 2.1.4.7 | 61d |
| 2.1.4.4 |  | CAMA DE ARENA | 6d | 2023-09-26 | 2023-10-01 | 2.1.4.2 | 30d |
| 2.1.4.11 |  | SUMINISTRO E INSTALACIÓN DE TUBERÍA GRP DN600 mm SN2500 | 7d | 2023-10-02 | 2023-10-08 | 2.1.4.4 | 30d |
| 2.1.4.5 |  | RELLENO COMÚN PARA ZANJAS | 8d | 2023-10-09 | 2023-10-16 | 2.1.4.11 | 30d |

| ID | WBS | Task | Duration | Start | Finish | Predecessors | Total float |
| --- | --- | --- | --- | --- | --- | --- | --- |
|  | 5 | **CANAL** |  | 2023-08-26 | 2023-10-29 |  |  |
| 2.1.5.1 |  | EXCAVACIÓN ESTRUCTURAL PARA OBRAS DE ARTE | 8d | 2023-08-26 | 2023-09-02 | 2.1.1.1 FS+5d, 2.1.4.1 | 0d |
| 2.1.5.3 |  | COLOCACIÓN DE CONCRETO f'c=100 kg/cm2 | 4d | 2023-09-03 | 2023-09-06 | 2.1.5.1 | 0d |
| 2.1.5.6 |  | ACERO DE REFUERZO fy=4200 kg/cm2 | 13d | 2023-09-07 | 2023-09-19 | 2.1.5.3 | 0d |
| 2.1.5.5 |  | ENCOFRADO Y DESENCOFRADO RECTO | 30d | 2023-09-12 | 2023-10-11 | 2.1.5.6 SS+5d | 0d |
| 2.1.5.7 |  | JUNTA WATER STOP SIN BULBO 150 mm | 4d | 2023-10-12 | 2023-10-15 | 2.1.5.5 | 0d |
| 2.1.5.4 |  | COLOCACIÓN DE CONCRETO f'c=280 kg/cm2 | 5d | 2023-10-16 | 2023-10-20 | 2.1.5.7 | 0d |
| 2.1.5.2 |  | RELLENO ESTRUCTURAL PARA CANALES, CON MATERIAL PROPIO | 9d | 2023-10-21 | 2023-10-29 | 2.1.5.4 | 17d |
|  | 6 | **OBRAS DE DESCARGA** |  | 2023-10-21 | 2023-11-15 |  |  |
| 2.1.6.1 |  | EXCAVACIÓN ESTRUCTURAL PARA OBRAS DE ARTE | 3d | 2023-10-21 | 2023-10-23 | 2.1.5.4 | 0d |
| 2.1.6.3 |  | CONCRETO f'c=100 kg/cm2 | 3d | 2023-10-24 | 2023-10-26 | 2.1.6.1 | 0d |
| 2.1.6.6 |  | ACERO DE REFUERZO fy=4200 kg/cm2 | 3d | 2023-10-27 | 2023-10-29 | 2.1.6.3 | 0d |
| 2.1.6.5 |  | ENCOFRADO Y DESENCOFRADO RECTO | 5d | 2023-10-30 | 2023-11-03 | 2.1.6.6 | 0d |
| 2.1.6.7 |  | JUNTA WATER STOP SIN BULBO 150 mm | 4d | 2023-11-01 | 2023-11-04 | 2.1.6.5 SS+2d | 0d |
| 2.1.6.4 |  | CONCRETO f'c=280 kg/cm2 | 3d | 2023-11-05 | 2023-11-07 | 2.1.6.7 | 0d |
| 2.1.6.2 |  | RELLENO ESTRUCTURAL PARA OBRAS DE ARTE CON MATERIAL PROPIO | 3d | 2023-11-08 | 2023-11-10 | 2.1.6.4 | 0d |
| 2.1.6.8 |  | COMPUERTA METALICA PLANA DESLIZANTE | 5d | 2023-11-11 | 2023-11-15 | 2.1.6.2 | 0d |
|  | 2 | **CAPTACIÓN A3-CP-21-05** |  | 2023-08-31 | 2023-11-15 |  |  |
|  | 1 | **MOVIMIENTO DE TIERRAS** |  | 2023-08-31 | 2023-10-09 |  |  |
| 2.2.1.1 |  | EXCAVACIÓN ESTRUCTURAL PARA OBRAS DE ARTE | 6d | 2023-08-31 | 2023-09-05 | 1.5.3.179 | 0d |
| 2.2.1.2 |  | RELLENO ESTRUCTURAL PARA OBRAS DE ARTE, CON MATERIAL PROPIO | 5d | 2023-10-05 | 2023-10-09 | 2.2.2.2 | 37d |
|  | 2 | **OBRAS DE CONCRETO** |  | 2023-09-06 | 2023-10-04 |  |  |
| 2.2.2.3 |  | CONCRETO CICLÓPEO f'c=280 kg/cm2 + 30% P.G. | 3d | 2023-09-06 | 2023-09-08 | 2.2.1.1 | 24d |
| 2.2.2.1 |  | CONCRETO f'c=100 kg/cm2 | 3d | 2023-09-09 | 2023-09-11 | 2.2.2.3 | 24d |
| 2.2.2.5 |  | ACERO DE REFUERZO fy=4200 kg/cm2 | 11d | 2023-09-12 | 2023-09-22 | 2.2.2.1 | 24d |
| 2.2.2.4 |  | ENCOFRADO Y DESENCOFRADO RECTO | 12d | 2023-09-16 | 2023-09-27 | 2.2.2.5 SS+4d | 24d |
| 2.2.2.2 |  | CONCRETO f'c=280 kg/cm2 | 7d | 2023-09-28 | 2023-10-04 | 2.2.2.4 | 24d |
|  | 3 | **ESTRUCTURAS METALICAS** |  | 2023-10-05 | 2023-10-22 |  |  |
| 2.2.3.1 |  | COMPUERTA METALICA PLANA DESLIZANTE DE 1.0x1.0m | 3d | 2023-10-05 | 2023-10-07 | 2.2.2.2 | 24d |
| 2.2.3.2 |  | REJILLA DE 1.00x1.00m CON VARILLA DE 1/2 CADA 6,25cm | 3d | 2023-10-08 | 2023-10-10 | 2.2.3.1 | 24d |
| 2.2.3.3 |  | BARANDA DE FIERRO GALVANIZADO 1 1/2" | 6d | 2023-10-11 | 2023-10-16 | 2.2.3.2 | 24d |
| 2.2.3.4 |  | ESCALERA TIPO GATO | 3d | 2023-10-17 | 2023-10-19 | 2.2.3.3 | 24d |
| 2.2.3.5 |  | TAPA METALICA CIRCULAR DN600 MM | 3d | 2023-10-20 | 2023-10-22 | 2.2.3.4 | 24d |
|  | 4 | **TUBERIAS** |  | 2023-09-06 | 2023-10-09 |  |  |
| 2.2.4.1 |  | EXCAVACIÓN ESTRUCTURAL PARA OBRAS DE ARTE (Buzones) | 3d | 2023-09-06 | 2023-09-08 | 2.2.1.1 | 0d |
| 2.2.4.7 |  | CONCRETO f'c=100 kg/cm2 (Buzones) | 3d | 2023-09-09 | 2023-09-11 | 2.2.4.1 | 0d |
| 2.2.4.11 |  | ACERO DE REFUERZO fy=4200 kg/cm2 | 3d | 2023-09-12 | 2023-09-14 | 2.2.4.7 | 0d |
| 2.2.4.10 |  | ENCOFRADO Y DESENCOFRADO CURVO | 4d | 2023-09-15 | 2023-09-18 | 2.2.4.11 | 0d |
| 2.2.4.9 |  | ENCOFRADO Y DESENCOFRADO RECTO | 3d | 2023-09-19 | 2023-09-21 | 2.2.4.10 | 0d |
| 2.2.4.8 |  | CONCRETO f'c=280 kg/cm2 (Buzones) | 3d | 2023-09-22 | 2023-09-24 | 2.2.4.9 | 0d |
| 2.2.4.2 |  | EXCAVACIÓN DE ZANJA | 3d | 2023-09-25 | 2023-09-27 | 2.2.4.8, 2.2.1.1 | 0d |
| 2.2.4.3 |  | RELLENO ESTRUCTURAL PARA OBRAS DE ARTE CON MATERIAL PROPIO | 3d | 2023-09-25 | 2023-09-27 | 2.2.4.8 | 49d |
| 2.2.4.4 |  | CAMA DE ARENA | 3d | 2023-09-28 | 2023-09-30 | 2.2.4.2 | 0d |
| 2.2.4.12 |  | SUMINISTRO E INSTALACIÓN DE TUBERÍA GRP DN600 mm SN2500 | 3d | 2023-10-01 | 2023-10-03 | 2.2.4.4 | 0d |
| 2.2.4.6 |  | RELLENO COMÚN PARA ZANJAS | 3d | 2023-10-04 | 2023-10-06 | 2.2.4.12 | 37d |
| 2.2.4.5 |  | RELLENO SELECCIONADO PARA ZANJAS CON MATERIAL PROPIO | 3d | 2023-10-07 | 2023-10-09 | 2.2.4.6 | 37d |
|  | 5 | **CANALES** |  | 2023-10-04 | 2023-11-15 |  |  |
| 2.2.5.1 |  | EXCAVACIÓN ESTRUCTURAL PARA OBRAS DE ARTE | 7d | 2023-10-04 | 2023-10-10 | 2.2.4.12 | 0d |
| 2.2.5.3 |  | COLOCACIÓN DE CONCRETO f'c=100 kg/cm2 | 3d | 2023-10-11 | 2023-10-13 | 2.2.5.1 | 0d |
| 2.2.5.6 |  | ACERO DE REFUERZO fy=4200 kg/cm2 | 6d | 2023-10-14 | 2023-10-19 | 2.2.5.3 | 0d |
| 2.2.5.5 |  | ENCOFRADO Y DESENCOFRADO | 16d | 2023-10-18 | 2023-11-02 | 2.2.5.6 SS+4d | 0d |
| 2.2.5.7 |  | JUNTA WATER STOP SIN BULBO 150 mm | 3d | 2023-11-03 | 2023-11-05 | 2.2.5.5 | 0d |
| 2.2.5.4 |  | COLOCACIÓN DE CONCRETO f'c=280 kg/cm2 | 4d | 2023-11-06 | 2023-11-09 | 2.2.5.7 | 0d |
| 2.2.5.2 |  | RELLENO ESTRUCTURAL PARA CANALES, CON MATERIAL PROPIO | 6d | 2023-11-10 | 2023-11-15 | 2.2.5.4 | 0d |
|  | 3 | **RETORNO A3-OA-RE-D-21-55** |  | 2023-08-01 | 2023-09-11 |  |  |
|  | 1 | **MOVIMIENTO DE TIERRAS** |  | 2023-08-01 | 2023-09-06 |  |  |
| 2.3.1.1 |  | EXCAVACIÓN ESTRUCTURAL PARA OBRAS DE ARTE | 3d | 2023-08-01 | 2023-08-03 | 1.5.1.8 | 65d |
| 2.3.1.2 |  | RELLENO ESTRUCTURAL PARA OBRAS DE ARTE, CON MATERIAL PROPIO | 3d | 2023-09-04 | 2023-09-06 | 2.3.2.2 | 65d |
|  | 2 | **OBRAS DE CONCRETO** |  | 2023-08-04 | 2023-09-03 |  |  |
| 2.3.2.3 |  | CONCRETO CICLÓPEO f'c=280 kg/cm2 + 30% P.G. | 4d | 2023-08-04 | 2023-08-07 | 2.3.1.1 | 65d |
| 2.3.2.1 |  | CONCRETO f'c=100 kg/cm2 | 3d | 2023-08-08 | 2023-08-10 | 2.3.2.3 | 65d |
| 2.3.2.5 |  | ACERO DE REFUERZO fy=4200 kg/cm2 | 13d | 2023-08-11 | 2023-08-23 | 2.3.2.1 | 65d |
| 2.3.2.4 |  | ENCOFRADO Y DESENCOFRADO | 6d | 2023-08-21 | 2023-08-26 | 2.3.2.5 FS-3d | 65d |
| 2.3.2.6 |  | JUNTA WATER STOP SIN BULBO 150 mm | 4d | 2023-08-27 | 2023-08-30 | 2.3.2.4 | 65d |
| 2.3.2.2 |  | CONCRETO f'c=280 kg/cm2 | 4d | 2023-08-31 | 2023-09-03 | 2.3.2.6 | 65d |
|  | 3 | **ESTRUCTURAS METALICAS** |  | 2023-09-07 | 2023-09-11 |  |  |
| 2.3.3.1 |  | COMPUERTA METALICA PLANA DESLIZANTE DE 1.0x1.6 m | 3d | 2023-09-07 | 2023-09-09 | 2.3.1.2 | 65d |
| 2.3.3.2 |  | BARANDA DE FIERRO GALVANIZADO 1 1/2" | 2d | 2023-09-10 | 2023-09-11 | 2.3.3.1 | 65d |
|  | 4 | **REPOSICIÓN DE CANALES** |  | 2023-05-01 | 2023-11-03 |  |  |
|  | 1 | **REPOSICIÓN DE CANAL 1** |  | 2023-07-28 | 2023-11-03 |  |  |

| ID | WBS | Task | Duration | Start | Finish | Predecessors | Total float |
| --- | --- | --- | --- | --- | --- | --- | --- |
|  | 1 | **MOVIMIENTO DE TIERRAS** |  | 2023-07-28 | 2023-11-03 |  |  |
| 2.4.1.1.1 |  | DEMOLICIÓN DE ESTRUCTURAS EXISTENTES | 6d | 2023-07-28 | 2023-08-02 | 1.5.4.8 | 12d |
| 2.4.1.1.2 |  | EXCAVACIÓN EN TERRENO NATURAL CON EQUIPO | 7d | 2023-08-03 | 2023-08-09 | 2.4.1.1.1 | 12d |
| 2.4.1.1.3 |  | RELLENO ESTRUCTURAL PARA OBRAS DE ARTE CON MATERIAL PROPIO | 9d | 2023-10-26 | 2023-11-03 | 2.4.1.2.4 FS-3d | 12d |
|  | 2 | **OBRAS DE CONCRETO** |  | 2023-08-10 | 2023-10-31 |  |  |
| 2.4.1.2.3 |  | CONCRETO f'c=100 kg/cm2 | 7d | 2023-08-10 | 2023-08-16 | 2.4.1.1.2 | 12d |
| 2.4.1.2.2 |  | ACERO DE REFUERZO fy=4200 kg/cm2 | 25d | 2023-08-17 | 2023-09-10 | 2.4.1.2.3 | 12d |
| 2.4.1.2.1 |  | ENCOFRADO Y DESENCOFRADO RECTO | 47d | 2023-08-25 | 2023-10-10 | 2.4.1.2.2 SS+8d | 12d |
| 2.4.1.2.5 |  | JUNTA WATER STOP 6" | 8d | 2023-10-11 | 2023-10-18 | 2.4.1.2.1 | 12d |
| 2.4.1.2.4 |  | CONCRETO f'c=280 kg/cm2 | 10d | 2023-10-19 | 2023-10-28 | 2.4.1.2.5 | 12d |
| 2.4.1.2.6 |  | MAMPOSTERIA DE PIEDRA, e=20cm, ACABADO CARA VISTA | 3d | 2023-10-29 | 2023-10-31 | 2.4.1.2.4 | 15d |
|  | 2 | **REPOSICIÓN DE CANAL 3** |  | 2023-05-01 | 2023-06-26 |  |  |
|  | 1 | **MOVIMIENTO DE TIERRAS** |  | 2023-05-01 | 2023-06-16 |  |  |
| 2.4.2.1.1 |  | DEMOLICIÓN DE ESTRUCTURAS EXISTENTES | 7d | 2023-05-01 | 2023-05-07 |  | 142d |
| 2.4.2.1.2 |  | EXCAVACIÓN EN TERRENO NATURAL CON EQUIPO | 3d | 2023-05-08 | 2023-05-10 | 2.4.2.1.1 | 142d |
| 2.4.2.1.3 |  | RELLENO ESTRUCTURAL PARA OBRAS DE ARTE CON MATERIAL PROPIO | 3d | 2023-06-14 | 2023-06-16 | 2.4.2.2.5 | 152d |
|  | 2 | **OBRAS DE CONCRETO** |  | 2023-05-11 | 2023-06-26 |  |  |
| 2.4.2.2.4 |  | CONCRETO f'c=100 kg/cm2 | 4d | 2023-05-11 | 2023-05-14 | 2.4.2.1.2 | 142d |
| 2.4.2.2.3 |  | MALLA ELECTROSOLDADA DE DN6mm EN CUADRICULA 15x15 cm | 9d | 2023-05-15 | 2023-05-23 | 2.4.2.2.4 | 142d |
| 2.4.2.2.1 |  | ENCOFRADO Y DESENCOFRADO PARA REVESTIMIENTO DE CANALES (CERCHAS) | 4d | 2023-05-23 | 2023-05-26 | 2.4.2.2.3 FS-1d | 142d |
| 2.4.2.2.2 |  | ENCOFRADO Y DESENCOFRADO RECTO | 13d | 2023-05-27 | 2023-06-08 | 2.4.2.2.1 | 142d |
| 2.4.2.2.5 |  | CONCRETO f'c=280 kg/cm2 | 5d | 2023-06-09 | 2023-06-13 | 2.4.2.2.2 | 142d |
| 2.4.2.2.6 |  | SELLO DE JUNTA CONSTRUCCIÓN CON MATERIAL ELASTOMÉRICO | 13d | 2023-06-14 | 2023-06-26 | 2.4.2.2.5 | 142d |
| 2.4.2.2.7 |  | MAMPOSTERIA DE PIEDRA, e=20cm, ACABADO CARA VISTA | 3d | 2023-06-14 | 2023-06-16 | 2.4.2.2.5 | 152d |
|  | 5 | **REPOSICIÓN SIFON INOPERATIVO** |  | 2023-05-01 | 2023-06-12 |  |  |
| 2.5.1 |  | DEMOLICIÓN DE ESTRUCTURAS EXISTENTES | 3d | 2023-05-01 | 2023-05-03 |  | 105d |
| 2.5.2 |  | EXCAVACIÓN ESTRUCTURAL PARA OBRAS DE ARTE | 7d | 2023-05-04 | 2023-05-10 | 2.5.1 | 105d |
| 2.5.3 |  | COLOCACIÓN CAMA DE ARENA | 4d | 2023-05-11 | 2023-05-14 | 2.5.2 | 105d |
| 2.5.11 |  | CODOS HDPE DE 14" DN 355mm | 7d | 2023-05-15 | 2023-05-21 | 2.5.6 SS | 105d |
| 2.5.6 |  | TUBERÍAS DE 14" HDPE SDR21 DN 355mm | 7d | 2023-05-15 | 2023-05-21 | 2.5.3 | 105d |
| 2.5.5 |  | RELLENO COMÚN | 7d | 2023-05-22 | 2023-05-28 | 2.5.6, 2.5.11 | 105d |
| 2.5.4 |  | RELLENO ESTRUCTURAL PARA OBRAS DE ARTE CON MATERIAL PROPIO | 3d | 2023-05-29 | 2023-05-31 | 2.5.5 | 105d |
| 2.5.7 |  | CONCRETO f'c=100 kg/cm2 | 3d | 2023-06-01 | 2023-06-03 | 2.5.4 | 156d |
| 2.5.10 |  | ACERO DE REFUERZO fy=4200 kg/cm2 | 3d | 2023-06-04 | 2023-06-06 | 2.5.7 | 156d |
| 2.5.9 |  | ENCOFRADO Y DESENCOFRADO RECTO | 3d | 2023-06-07 | 2023-06-09 | 2.5.10 | 156d |
| 2.5.8 |  | CONCRETO f'c=280 kg/cm2 | 3d | 2023-06-10 | 2023-06-12 | 2.5.9 | 156d |
|  | 3 | **TRANSPORTE DE MATERIAL** |  | 2023-05-06 | 2023-10-22 |  |  |
| 3.5 |  | TRANSPORTE DE MATERIAL EXCEDENTE PARA DISTANCIAS <1KM | 130d | 2023-05-06 | 2023-09-12 | H2 | 19d |
| 3.6 |  | TRANSPORTE DE MATERIAL EXCEDENTE PARA DISTANCIAS >1KM | 130d | 2023-05-06 | 2023-09-12 | 3.5 SS | 49d |
| 3.3 |  | TRANSPORTE DE ROCA PARA DISTANCIAS <1KM | 122d | 2023-06-02 | 2023-10-01 | 1.5.3.79 | 0d |
| 3.4 |  | TRANSPORTE DE ROCA PARA DISTANCIAS >1KM | 122d | 2023-06-02 | 2023-10-01 | 3.3 SS | 0d |
| 3.1 |  | TRANSPORTE DE MATERIAL GRANULAR PARA DISTANCIAS <1KM | 90d | 2023-07-25 | 2023-10-22 | 2.1.2.3 SS | 24d |
| 3.2 |  | TRANSPORTE DE MATERIAL GRANULAR PARA DISTANCIAS >1KM | 90d | 2023-07-25 | 2023-10-22 | 2.1.2.3 SS | 24d |
|  | 4 | **ARQUITECTURA Y PAISAJISMO** |  | 2023-07-28 | 2023-09-21 |  |  |
|  | 1 | **OBRAS PRELIMINARES** |  | 2023-07-28 | 2023-08-05 |  |  |
| 4.1.1 |  | MOVILIZACIÓN Y DEMOVILIZACIÓN DE EQUIPOS Y HERRAMIENTAS (ARQUITECTURA Y PAISAJISMO) | 4d | 2023-07-28 | 2023-07-31 | 2.5.4, 1.5.4.8 | 48d |
| 4.1.2 |  | TRAZO Y REPLANTEO PRELIMINAR | 5d | 2023-08-01 | 2023-08-05 | 4.1.1 | 48d |
|  | 2 | **MOVIMIENTO DE TIERRAS** |  | 2023-08-06 | 2023-08-17 |  |  |
| 4.2.1 |  | EXCAVACIÓN MANUAL PARA INSTALACIÓN DE BORDILLOS Y CIMENTACIONES | 3d | 2023-08-06 | 2023-08-08 | 4.1.2 | 48d |
| 4.2.2 |  | EXCAVACIÓN PARA MEJORAMIENTO DE SUELO CON TIERRA VEGETAL | 6d | 2023-08-07 | 2023-08-12 | 4.2.1 SS+1d | 48d |
| 4.2.3 |  | ELIMINACION DE MATERIAL EXCEDENTE (DME´S) | 5d | 2023-08-13 | 2023-08-17 | 4.2.2 | 90d |
|  | 3 | **PAVIMENTOS, RECUBRIMIENTOS Y BORDILLOS** |  | 2023-08-13 | 2023-08-30 |  |  |
| 4.3.1 |  | PISO DE GRAVILLA | 3d | 2023-08-13 | 2023-08-15 | 4.2.2 | 48d |
| 4.3.2 |  | RECUBRIMIENTO DE PIEDRA DEL LUGAR e=0.05cm | 10d | 2023-08-16 | 2023-08-25 | 4.3.1 | 48d |
| 4.3.3 |  | BORDILLOS DE PIEDRA DEL LUGAR | 5d | 2023-08-26 | 2023-08-30 | 4.3.2 | 48d |
|  | 4 | **MOBILIARIOS, BARANDAS Y ESCALERAS** |  | 2023-08-31 | 2023-09-21 |  |  |
| 4.4.1 |  | ESCALERA DE CONCRETO SOBRE ENROCADO, CIMENTACION Y ANCLAJE | 4d | 2023-08-31 | 2023-09-03 | 4.3.3 | 48d |
| 4.4.2 |  | BARANDA DE MADERA EUCALIPTO CON SOGA, INCLUYE CIMENTACIÓN | 3d | 2023-09-04 | 2023-09-06 | 4.4.1 | 48d |
| 4.4.7 |  | BOLARDOS DE PIEDRA | 3d | 2023-09-07 | 2023-09-09 | 4.4.2 | 55d |
| 4.4.5 |  | POSTES DE ILUMINACIÓN, INCLUYE LUMINARIA Y CIMENTACIÓN | 3d | 2023-09-10 | 2023-09-12 | 4.4.7 | 55d |
| 4.4.4 |  | BANCAS DE CONCRETO, INCLUYE CIMENTACIÓN | 3d | 2023-09-13 | 2023-09-15 | 4.4.5 | 55d |
| 4.4.3 |  | TACHOS DE BASURA, INCLUYE CIMENTACIÓN | 3d | 2023-09-16 | 2023-09-18 | 4.4.4 | 55d |
| 4.4.6 |  | SEÑALETICA INFORMATIVA | 3d | 2023-09-19 | 2023-09-21 | 4.4.3 | 55d |
|  | 5 | **INSTALACIÓN DE ALCORQUES** |  | 2023-08-31 | 2023-09-02 |  |  |
| 4.5.1 |  | ALCORQUES DE PIEDRA DE CANTO RODADO PARA ARBOLES | 3d | 2023-08-31 | 2023-09-02 | 4.3.3 | 74d |
|  | 5 | **PROGRAMA DE CIERRE DE OBRA** |  | 2023-05-09 | 2023-09-28 |  |  |
| 5.1 |  | ACONDICIONAMIENTO DE DEPOSITOS DE MATERIALES EXCEDENTES (DME) | 142d | 2023-05-09 | 2023-09-27 | 3.5 SS+3d, 3.6 SS+3d | 49d |
| 5.2 |  | RESTAURACIÓN DE ÁREAS DE INSTALACIONES PROVISIONALES | 15d | 2023-09-14 | 2023-09-28 | 4.4.2 FS+7d | 48d |
|  | 6 | **SEGURIDAD Y SALUD OCUPACIONAL** |  | 2023-05-01 | 2023-10-30 |  |  |
| 6.1 |  | SEGURIDAD Y SALUD OCUPACIONAL | 183d | 2023-05-01 | 2023-10-30 | H1 | 16d |

| ID | Task | Duration | Start | Finish | Predecessors | Total float |
| --- | --- | --- | --- | --- | --- | --- |
| 6.2 | IMPLEMENTACIÓN DEL PLAN PARA LA VIGILANCIA, PREVENCIÓN Y CONTROL DE COVID-19 EN EL TRABAJO | 183d | 2023-05-01 | 2023-10-30 | H1 | 16d |

## Version 2 (data date 2023-05-10, saved 2023-05-03, file Cronograma OHLA.xer)

Last finish 2023-11-16 → 2023-11-21 (+5d).

Added:

| ID | Task | Duration | Start | Finish | Predecessors |
| --- | --- | --- | --- | --- | --- |
| A1000 | KICK OFF MEETING | 0d | 2023-05-10 | 2023-05-10 |  |
| A1010 | INICIO DEL SERVICIO | 0d | 2023-05-26 | 2023-05-26 | A1000 FS+16d |
| A1015 | INICIO DE EXCAVACIÓN | 0d | 2023-05-31 | 2023-05-31 | A1010 FS+5d, A1070 SS+3d |
| A1020 | FIN DEL SERVICIO | 0d | 2023-11-19 | 2023-11-19 | A1200, A2220, A2490, A1760, A1780, A1070, A2760, A2700, A1050, A2210, A4020, A3850, A3790, A3780, A3740, A3730, A3640, A3630, A3580, A3560, A3550, A3530, A3470, A3450, A3400, A3260, A3160, A3140, A3130, A3080, A2930, A2880, A4130, A4150, A4160 |
| 4 | **DESCOLMATACIÓN DE CAUCE Y OBRAS AUXILIARES** |  | 2023-06-02 | 2023-11-19 |  |
| 1 | **DESBROCE Y DESCOLMATACIÓN** |  | 2023-06-02 | 2023-08-26 |  |
| A1230 | DESCOLMATACIÓN DE CAUCE NATURAL DEL RÍO LACRAMARCA - DIQUE A3-D-01 | 10d | 2023-06-02 | 2023-06-11 | A1220 SS |
| A1880 | DESCOLMATACIÓN DE CAUCE NATURAL DEL RÍO LACRAMARCA - DIQUE A3-I-01 | 32d | 2023-06-02 | 2023-07-03 | A1230 SS |
| A1870 | DESCOLMATACIÓN DE CAUCE NATURAL DEL RÍO LACRAMARCA - DIQUE A3-D-02 | 53d | 2023-06-12 | 2023-08-03 | A1230 |
| A1890 | DESCOLMATACIÓN DE CAUCE NATURAL DEL RÍO LACRAMARCA - DIQUE A3-I-02 | 20d | 2023-07-04 | 2023-07-23 | A1880 |
| A1900 | DESCOLMATACIÓN DE CAUCE NATURAL DEL RÍO LACRAMARCA - DIQUE A3-I-03 | 34d | 2023-07-24 | 2023-08-26 | A1890 |
| 2 | **DESVIO DEL CAUCE** |  | 2023-06-03 | 2023-11-19 |  |
| 1 | **A3-D-01** |  | 2023-07-06 | 2023-07-15 |  |
| A1240 | CONFORMACIÓN DE DESVIO EN CAUCE DE RÍO - DIQUE A3-D-01 | 5d | 2023-07-06 | 2023-07-10 | A1230 SS, A1330 FF+2d |
| A1250 | RELLENO NO ESTRUCTURAL CON MATERIAL PROPIO - DIQUE A3-D-01 | 7d | 2023-07-09 | 2023-07-15 | A1330 |
| 2 | **A3-D-02** |  | 2023-07-23 | 2023-11-11 |  |
| A1790 | CONFORMACIÓN DE DESVIO EN CAUCE DE RÍO - DIQUE A3-D-02 - TRAMO 1 | 5d | 2023-07-23 | 2023-07-27 | A1870 SS+2d, A1510 FF+2d |
| A1800 | RELLENO NO ESTRUCTURAL CON MATERIAL PROPIO - DIQUE A3-D-02 - TRAMO 1 | 7d | 2023-08-02 | 2023-08-08 | A1420, A1250 |
| A2630 | CONFORMACIÓN DE DESVIO EN CAUCE DE RÍO - DIQUE A3-D-02 - TRAMO 2 | 5d | 2023-08-16 | 2023-08-20 | A1600 FF+2d |
| A2640 | RELLENO NO ESTRUCTURAL CON MATERIAL PROPIO - DIQUE A3-D-02 - TRAMO 2 | 7d | 2023-08-26 | 2023-09-01 | A1980, A1800 |
| A2650 | CONFORMACIÓN DE DESVIO EN CAUCE DE RÍO - DIQUE A3-D-02 - TRAMO 3 | 5d | 2023-09-08 | 2023-09-12 | A1690 FF+2d |
| A2660 | RELLENO NO ESTRUCTURAL CON MATERIAL PROPIO - DIQUE A3-D-02 - TRAMO 3 | 7d | 2023-09-19 | 2023-09-25 | A2070, A2640 |
| A2670 | CONFORMACIÓN DE DESVIO EN CAUCE DE RÍO - DIQUE A3-D-02 - TRAMO 4 | 5d | 2023-09-25 | 2023-09-29 | A2340 FF+2d |
| A2680 | RELLENO NO ESTRUCTURAL CON MATERIAL PROPIO - DIQUE A3-D-02 - TRAMO 4 | 7d | 2023-10-13 | 2023-10-19 | A2160, A2660 |
| A2690 | CONFORMACIÓN DE DESVIO EN CAUCE DE RÍO - DIQUE A3-D-02 - TRAMO 5 | 5d | 2023-10-18 | 2023-10-22 | A2430 FF+2d |
| A2700 | RELLENO NO ESTRUCTURAL CON MATERIAL PROPIO - DIQUE A3-D-02 - TRAMO 5 | 7d | 2023-11-05 | 2023-11-11 | A2250, A2680 |
| 3 | **A3-I-01** |  | 2023-06-03 | 2023-08-01 |  |
| A1810 | CONFORMACIÓN DE DESVIO EN CAUCE DE RÍO - DIQUE A3-I-01 | 5d | 2023-06-03 | 2023-06-07 | A1880 SS+1d |
| A1820 | RELLENO NO ESTRUCTURAL CON MATERIAL PROPIO - DIQUE A3-I-01 | 7d | 2023-07-26 | 2023-08-01 | A1510 |
| 4 | **A3-I-02** |  | 2023-07-06 | 2023-08-25 |  |
| A1830 | CONFORMACIÓN DE DESVIO EN CAUCE DE RÍO - DIQUE A3-I-02 | 5d | 2023-07-06 | 2023-07-10 | A1890 SS+2d, A1330 FF+2d |
| A1840 | RELLENO NO ESTRUCTURAL CON MATERIAL PROPIO - DIQUE A3-I-02 | 7d | 2023-08-19 | 2023-08-25 | A1600, A1820 |
| 5 | **A3-I-03** |  | 2023-07-30 | 2023-11-19 |  |
| A1850 | CONFORMACIÓN DE DESVIO EN CAUCE DE RÍO - DIQUE A3-I-03 - TRAMO 1 | 5d | 2023-07-30 | 2023-08-03 | A1900 SS+2d, A1420 FF+2d |
| A2710 | CONFORMACIÓN DE DESVIO EN CAUCE DE RÍO - DIQUE A3-I-03 - TRAMO 2 | 5d | 2023-08-23 | 2023-08-27 | A1980 FF+2d |
| A1860 | RELLENO NO ESTRUCTURAL CON MATERIAL PROPIO - DIQUE A3-I-03 -TRAMO 1 | 7d | 2023-09-11 | 2023-09-17 | A1690, A1840 |
| A2730 | CONFORMACIÓN DE DESVIO EN CAUCE DE RÍO - DIQUE A3-I-03 - TRAMO 3 | 5d | 2023-09-16 | 2023-09-20 | A2070 FF+2d |
| A2720 | RELLENO NO ESTRUCTURAL CON MATERIAL PROPIO - DIQUE A3-I-03 -TRAMO 2 | 7d | 2023-09-28 | 2023-10-04 | A2340, A1860 |
| A2750 | CONFORMACIÓN DE DESVIO EN CAUCE DE RÍO - DIQUE A3-I-03 - TRAMO 4 | 5d | 2023-10-10 | 2023-10-14 | A2160 FF+2d |
| A2740 | RELLENO NO ESTRUCTURAL CON MATERIAL PROPIO - DIQUE A3-I-03 -TRAMO 3 | 7d | 2023-10-21 | 2023-10-27 | A2430, A2720 |
| A2760 | RELLENO NO ESTRUCTURAL CON MATERIAL PROPIO - DIQUE A3-I-03 -TRAMO 4 | 7d | 2023-11-13 | 2023-11-19 | A2520, A2740 |
| 1 | **TRAMO 1** |  | 2023-07-11 | 2023-08-04 |  |
| 2 | **TRAMO 2** |  | 2023-08-04 | 2023-08-28 |  |
| 3 | **TRAMO 3** |  | 2023-08-28 | 2023-09-21 |  |
| 4 | **TRAMO 4** |  | 2023-09-21 | 2023-10-15 |  |
| 5 | **TRAMO 5** |  | 2023-10-15 | 2023-11-07 |  |
| 1 | **Sector liberado** |  | 2023-07-11 | 2023-07-28 |  |
| 2 | **Sector por Liberar - Km 20+980 - km 21+300** |  | 2023-10-24 | 2023-11-13 |  |
| A4040 | EXCAVACIÓN DE UÑA CON EQUIPO | 3d | 2023-10-27 | 2023-10-29 | A4030 SS+1d, A2190 |
| A4050 | PERFILADO Y COMPACTACIÓN EN ZONA DE CORTE | 4d | 2023-10-28 | 2023-10-31 | A4030 SS+1d, A2200 |
| A4110 | PREPARACIÓN DE FUNDACIÓN DE CUERPO DE DIQUE | 3d | 2023-10-29 | 2023-10-31 | A4050 SS, A2260 |
| A4060 | CONFORMACIÓN DE CUERPO DE DIQUE CON MATERIAL PROPIO | 3d | 2023-10-30 | 2023-11-01 | A4110 SS+1d, A2210 |
| A4080 | GEOTEXTIL NO TEJIDO 400 G/M2, INC. COLOCACIÓN | 2d | 2023-11-01 | 2023-11-02 | A4060 SS+2d, A2230 |
| A4090 | COLOCACION Y ACOMODO DE ROCA EN UÑA DE DIQUE | 2d | 2023-11-04 | 2023-11-05 | A4080 SS+2d, A2240 |
| A4100 | COLOCACION Y ACOMODO DE ROCA EN TALUD DE DIQUE | 5d | 2023-11-06 | 2023-11-10 | A4090 SS+2d, A2250 |
| A4070 | CONFORMACIÓN DE CORONA DE DIQUE CON MATERIAL PROPIO | 2d | 2023-11-12 | 2023-11-13 | A4100 FF+3d, A2220 |
| A1540 | EXCAVACIÓN DE UÑA CON EQUIPO | 14d | 2023-07-29 | 2023-08-11 | A1530 SS+1d, A1450 |
| A1550 | PERFILADO Y COMPACTACIÓN EN ZONA DE CORTE | 11d | 2023-08-01 | 2023-08-11 | A1530 SS+4d |
| A1580 | GEOTEXTIL NO TEJIDO 400 G/M2, INC. COLOCACIÓN | 11d | 2023-08-03 | 2023-08-13 | A1550 SS+2d |
| A1590 | COLOCACION Y ACOMODO DE ROCA EN UÑA DE DIQUE | 10d | 2023-08-05 | 2023-08-14 | A1580 SS+2d |
| A1610 | PREPARACIÓN DE FUNDACIÓN DE CUERPO DE DIQUE | 3d | 2023-08-05 | 2023-08-07 | A1530 SS+8d |
| A1560 | CONFORMACIÓN DE CUERPO DE DIQUE CON MATERIAL PROPIO | 3d | 2023-08-06 | 2023-08-08 | A1610 SS+1d |
| A1600 | COLOCACION Y ACOMODO DE ROCA EN TALUD DE DIQUE | 12d | 2023-08-07 | 2023-08-18 | A1590 SS+2d |
| A1570 | CONFORMACIÓN DE CORONA DE DIQUE CON MATERIAL PROPIO | 6d | 2023-08-16 | 2023-08-21 | A1600 FF+3d, A1480 |
| 1 | **TRAMO 1** |  | 2023-08-21 | 2023-09-13 |  |
| A1630 | EXCAVACIÓN DE UÑA CON EQUIPO | 11d | 2023-08-22 | 2023-09-01 | A1620 SS+1d, A1540 |
| A1640 | PERFILADO Y COMPACTACIÓN EN ZONA DE CORTE | 12d | 2023-08-22 | 2023-09-02 | A1620 SS+1d |
| A1670 | GEOTEXTIL NO TEJIDO 400 G/M2, INC. COLOCACIÓN | 12d | 2023-08-23 | 2023-09-03 | A1640 SS+1d |
| A1680 | COLOCACION Y ACOMODO DE ROCA EN UÑA DE DIQUE | 16d | 2023-08-25 | 2023-09-09 | A1670 SS+2d |
| A1690 | COLOCACION Y ACOMODO DE ROCA EN TALUD DE DIQUE | 15d | 2023-08-27 | 2023-09-10 | A1680 SS+2d |
| A1700 | PREPARACIÓN DE FUNDACIÓN DE CUERPO DE DIQUE | 5d | 2023-08-28 | 2023-09-01 | A1620 |
| A1650 | CONFORMACIÓN DE CUERPO DE DIQUE CON MATERIAL PROPIO | 5d | 2023-08-29 | 2023-09-02 | A1700 SS+1d, A1560 |
| A1660 | CONFORMACIÓN DE CORONA DE DIQUE CON MATERIAL PROPIO | 6d | 2023-09-08 | 2023-09-13 | A1690 FF+3d, A1570 |
| 2 | **TRAMO 2** |  | 2023-09-13 | 2023-11-19 |  |
| 1 | **Sector liberado** |  | 2023-09-13 | 2023-09-30 |  |
| A2270 | EXCAVACIÓN EN TERRENO NATURAL CON EQUIPO | 4d | 2023-09-13 | 2023-09-16 | A2650 |
| A2280 | EXCAVACIÓN DE UÑA CON EQUIPO | 7d | 2023-09-14 | 2023-09-20 | A2270 SS+1d, A1630 |
| A2290 | PERFILADO Y COMPACTACIÓN EN ZONA DE CORTE | 8d | 2023-09-14 | 2023-09-21 | A2270 SS+1d |
| A2320 | GEOTEXTIL NO TEJIDO 400 G/M2, INC. COLOCACIÓN | 7d | 2023-09-15 | 2023-09-21 | A2290 SS+1d |
| A2330 | COLOCACION Y ACOMODO DE ROCA EN UÑA DE DIQUE | 10d | 2023-09-17 | 2023-09-26 | A2320 SS+2d |
| A2350 | PREPARACIÓN DE FUNDACIÓN DE CUERPO DE DIQUE | 3d | 2023-09-17 | 2023-09-19 | A2270 |
| A2300 | CONFORMACIÓN DE CUERPO DE DIQUE CON MATERIAL PROPIO | 3d | 2023-09-18 | 2023-09-20 | A2350 SS+1d, A1650 |
| A2340 | COLOCACION Y ACOMODO DE ROCA EN TALUD DE DIQUE | 9d | 2023-09-19 | 2023-09-27 | A2330 SS+2d |
| A2310 | CONFORMACIÓN DE CORONA DE DIQUE CON MATERIAL PROPIO | 3d | 2023-09-28 | 2023-09-30 | A2340 FF+3d, A1660 |
| 2 | **Sector por Liberar - Km 23+760 - km 24+100** |  | 2023-10-28 | 2023-11-19 |  |
| A4120 | EXCAVACIÓN EN TERRENO NATURAL CON EQUIPO | 3d | 2023-10-28 | 2023-10-30 | A4030 |
| A4130 | EXCAVACIÓN DE UÑA CON EQUIPO | 4d | 2023-10-30 | 2023-11-02 | A4120 SS+1d, A4040 |
| A4140 | PERFILADO Y COMPACTACIÓN EN ZONA DE CORTE | 5d | 2023-11-01 | 2023-11-05 | A4120 SS+1d, A4050 |
| A4200 | PREPARACIÓN DE FUNDACIÓN DE CUERPO DE DIQUE | 2d | 2023-11-01 | 2023-11-02 | A4120, A4110 |
| A4150 | CONFORMACIÓN DE CUERPO DE DIQUE CON MATERIAL PROPIO | 2d | 2023-11-02 | 2023-11-03 | A4200 SS+1d, A4060 |
| A4170 | GEOTEXTIL NO TEJIDO 400 G/M2, INC. COLOCACIÓN | 3d | 2023-11-03 | 2023-11-05 | A4140 SS+1d, A4080 |
| A4180 | COLOCACION Y ACOMODO DE ROCA EN UÑA DE DIQUE | 7d | 2023-11-06 | 2023-11-12 | A4170 SS+2d, A4090 |
| A4190 | COLOCACION Y ACOMODO DE ROCA EN TALUD DE DIQUE | 6d | 2023-11-11 | 2023-11-16 | A4180 SS+2d, A4100 |
| A4160 | CONFORMACIÓN DE CORONA DE DIQUE CON MATERIAL PROPIO | 2d | 2023-11-18 | 2023-11-19 | A4190 FF+3d, A4070 |
| 3 | **TRAMO 3** |  | 2023-09-30 | 2023-10-23 |  |
| A2360 | EXCAVACIÓN EN TERRENO NATURAL CON EQUIPO | 7d | 2023-09-30 | 2023-10-06 | A2670 |
| A2370 | EXCAVACIÓN DE UÑA CON EQUIPO | 11d | 2023-10-01 | 2023-10-11 | A2360 SS+1d, A2280 |
| A2380 | PERFILADO Y COMPACTACIÓN EN ZONA DE CORTE | 12d | 2023-10-01 | 2023-10-12 | A2360 SS+1d |
| A2410 | GEOTEXTIL NO TEJIDO 400 G/M2, INC. COLOCACIÓN | 12d | 2023-10-02 | 2023-10-13 | A2380 SS+1d |
| A2420 | COLOCACION Y ACOMODO DE ROCA EN UÑA DE DIQUE | 16d | 2023-10-04 | 2023-10-19 | A2410 SS+2d |
| A2430 | COLOCACION Y ACOMODO DE ROCA EN TALUD DE DIQUE | 15d | 2023-10-06 | 2023-10-20 | A2420 SS+2d |
| A2440 | PREPARACIÓN DE FUNDACIÓN DE CUERPO DE DIQUE | 5d | 2023-10-07 | 2023-10-11 | A2360 |
| A2390 | CONFORMACIÓN DE CUERPO DE DIQUE CON MATERIAL PROPIO | 5d | 2023-10-08 | 2023-10-12 | A2440 SS+1d, A2300 |
| A2400 | CONFORMACIÓN DE CORONA DE DIQUE CON MATERIAL PROPIO | 6d | 2023-10-18 | 2023-10-23 | A2430 FF+3d, A2310 |
| 4 | **TRAMO 4** |  | 2023-10-23 | 2023-11-15 |  |
| A2450 | EXCAVACIÓN EN TERRENO NATURAL CON EQUIPO | 7d | 2023-10-23 | 2023-10-29 | A2690 |
| A2460 | EXCAVACIÓN DE UÑA CON EQUIPO | 11d | 2023-10-24 | 2023-11-03 | A2450 SS+1d, A2370 |
| A2470 | PERFILADO Y COMPACTACIÓN EN ZONA DE CORTE | 12d | 2023-10-24 | 2023-11-04 | A2450 SS+1d |
| A2500 | GEOTEXTIL NO TEJIDO 400 G/M2, INC. COLOCACIÓN | 12d | 2023-10-25 | 2023-11-05 | A2470 SS+1d |
| A2510 | COLOCACION Y ACOMODO DE ROCA EN UÑA DE DIQUE | 16d | 2023-10-27 | 2023-11-11 | A2500 SS+2d |
| A2520 | COLOCACION Y ACOMODO DE ROCA EN TALUD DE DIQUE | 15d | 2023-10-29 | 2023-11-12 | A2510 SS+2d |
| A2530 | PREPARACIÓN DE FUNDACIÓN DE CUERPO DE DIQUE | 5d | 2023-10-30 | 2023-11-03 | A2450 |
| A2480 | CONFORMACIÓN DE CUERPO DE DIQUE CON MATERIAL PROPIO | 5d | 2023-10-31 | 2023-11-04 | A2530 SS+1d, A2390 |
| A2490 | CONFORMACIÓN DE CORONA DE DIQUE CON MATERIAL PROPIO | 6d | 2023-11-10 | 2023-11-15 | A2520 FF+3d, A2400 |
| 1 | **A3-RA-D-01** |  | 2023-10-27 | 2023-11-01 |  |
| A1710 | EXCAVACIÓN EN TERRENO NATURAL CON EQUIPO | 3d | 2023-10-27 | 2023-10-29 | A2190 |
| 2 | **A3-RA-I-01** |  | 2023-11-04 | 2023-11-09 |  |
| A1740 | EXCAVACIÓN EN TERRENO NATURAL CON EQUIPO | 3d | 2023-11-04 | 2023-11-06 | A2460 |
| A1750 | CONFORMACIÓN DE CUERPO DE RAMPA CON MATERIAL PROPIO | 3d | 2023-11-07 | 2023-11-09 | A1740 |
| A1760 | CONFORMACIÓN DE CORONACIÓN DE RAMPA | 3d | 2023-11-07 | 2023-11-09 | A1750 SS, A1730 |
| 4 | **TUBERIA** |  | 2023-06-08 | 2023-07-28 |  |
| A3570 | EXCAVACIÓN EN TERRENO NATURAL CON EQUIPO | 36d | 2023-08-19 | 2023-09-23 | A1600 |
| A3660 | EXCAVACIÓN EN TERRENO NATURAL CON EQUIPO | 4d | 2023-07-09 | 2023-07-12 | A1330, A3650 |
| A3860 | MOVILIZACIÓN DE EQUIPOS Y HERRAMIENTAS (ARQUITECTURA Y PAISAJISMO) | 2d | 2023-08-22 | 2023-08-23 | A1570 |
| A4020 | DEMOVILIZACIÓN DE EQUIPOS Y HERRAMIENTAS (ARQUITECTURA Y PAISAJISMO) | 2d | 2023-11-02 | 2023-11-03 | A4010, A3900 |

Removed: H1 INICIO DE PLAZO CONTRACTUAL - ACCESO AL SITIO (16 días calendario despues del KOM); H2 INICIO DE EXCAVACION; H4 FIN DE PLAZO DE CONTRACTUAL - CULMINACION DE OBRAS; DESCOLMATACIÓN DE CAUCE y OBRAS AUXILIARES; 1.4.2 DESCOLMATACIÓN DE CAUCE NATURAL DEL RÍO LACRAMARCA; 1.4.3 CONFORMACIÓN DE DESVIO EN CAUCE DE RÍO; 1.4.4 RELLENO NO ESTRUCTURAL CON MATERIAL PROPIO; DIQUE DE TIERRA COMPACTADA A3-I-01- 1 ETAPA; DIQUE DE TIERRA COMPACTADA A3-I-01- 2 ETAPA; 1.5.3.100 LIBERACIÓN DE PREDIOS A3-I-01; DIQUE DE TIERRA COMPACTADA A3-I-03- 1 ETAPA; DIQUE DE TIERRA COMPACTADA A3-I-03- 2 ETAPA; 1.5.5.108 LIBERACION DE PREDIOS A3-I-03; TUBERIAS; TRANSPORTE DE MATERIAL; 3.5 TRANSPORTE DE MATERIAL EXCEDENTE PARA DISTANCIAS <1KM; 3.6 TRANSPORTE DE MATERIAL EXCEDENTE PARA DISTANCIAS >1KM; 3.3 TRANSPORTE DE ROCA PARA DISTANCIAS <1KM; 3.4 TRANSPORTE DE ROCA PARA DISTANCIAS >1KM; 3.1 TRANSPORTE DE MATERIAL GRANULAR PARA DISTANCIAS <1KM; 3.2 TRANSPORTE DE MATERIAL GRANULAR PARA DISTANCIAS >1KM; 4.1.1 MOVILIZACIÓN Y DEMOVILIZACIÓN DE EQUIPOS Y HERRAMIENTAS (ARQUITECTURA Y PAISAJISMO); SEGURIDAD Y SALUD OCUPACIONAL; 6.1 SEGURIDAD Y SALUD OCUPACIONAL; 6.2 IMPLEMENTACIÓN DEL PLAN PARA LA VIGILANCIA, PREVENCIÓN Y CONTROL DE COVID-19 EN EL TRABAJO

Changed:

| ID | Task | Start | Finish | Duration | Total float | Predecessors | Other |
| --- | --- | --- | --- | --- | --- | --- | --- |
| 0 | **HITOS** | 2023-05-01 → 2023-05-10 (+9d) | 2023-11-16 → 2023-11-19 (+3d) |  |  |  |  |
| A1016 | INICIO DE RELLENO DE DIQUE | 2023-05-22 → 2023-06-22 (+31d) | 2023-05-22 → 2023-06-22 (+31d) |  | 178d → 0d | A1990 FS+3d → A1015 SS+22d, A1340 |  |
| 1 | **DEFENSAS RIBEREÑAS** | 2023-05-01 → 2023-05-26 (+25d) | 2023-11-15 → 2023-11-21 (+6d) |  |  |  |  |
| 1 | **OBRAS PRELIMINARES** | 2023-05-01 → 2023-05-28 (+27d) | 2023-10-18 → 2023-11-17 (+30d) |  |  |  |  |
| A1030 | CARTEL DE IDENTIFICACIÓN OBRA 4.80 x 3.60 m. | 2023-05-14 → 2023-05-28 (+14d) | 2023-05-18 → 2023-05-29 (+11d) | 5d → 2d | 181d → 2d | A1060, INICIO DE PLAZO CONTRACTUAL - ACCESO AL SITIO (16 días calendario despues del KOM) → A1060 SS+2d |  |
| A1040 | INSTALACIONES PROVISIONALES PARA LA OBRA | 2023-05-01 → 2023-06-01 (+31d) | 2023-05-13 → 2023-11-16 (+187d) | 13d → 169d | 29d → 0d | INICIO DE PLAZO CONTRACTUAL - ACCESO AL SITIO (16 días calendario despues del KOM) → A1100 SS+1d, A1030 |  |
| A1050 | MANTENIMIENTO DE TRÁNSITO Y SEGURIDAD VIAL | 2023-05-13 → 2023-06-17 (+35d) | 2023-10-18 → 2023-11-17 (+30d) | 159d → 154d | 28d → 2d | A1060 FS-1d → A1100 |  |
| 2 | **TRABAJOS PRELIMINARES** | 2023-05-01 → 2023-05-26 (+25d) | 2023-11-15 → 2023-11-21 (+6d) |  |  |  |  |
| A1060 | MOVILIZACION DE EQUIPOS | 2023-05-01 → 2023-05-26 (+25d) | 2023-05-13 → 2023-06-25 (+43d) | 13d → 31d | 28d → 0d | INICIO DE PLAZO CONTRACTUAL - ACCESO AL SITIO (16 días calendario despues del KOM) → A1010 |  |
| A1070 | TOPOGRAFÍA Y GEOREFERENCIACIÓN | 2023-05-01 → 2023-05-28 (+27d) | 2023-10-17 → 2023-11-17 (+31d) | 170d → 174d | 29d → 0d | A1040 SS → A1060 SS+2d |  |
| A1080 | DESMOVILIZACION DE EQUIPOS | 2023-10-02 → 2023-10-30 (+28d) | 2023-11-15 → 2023-11-21 (+6d) | 45d → 23d |  | TRANSPORTE DE MATERIAL EXCEDENTE PARA DISTANCIAS <1KM, TRANSPORTE DE ROCA PARA DISTANCIAS <1KM, TRANSPORTE DE ROCA PARA DISTANCIAS >1KM → A1020 FF+2d |  |
| 3 | **MEJORAMIENTO DE VÍAS EXISTENTES** | 2023-05-08 → 2023-05-31 (+23d) | 2023-06-01 → 2023-07-30 (+59d) |  |  |  |  |
| 1 | **MOVIMIENTO DE TIERRAS** | 2023-05-08 → 2023-05-31 (+23d) | 2023-06-01 → 2023-06-16 (+15d) |  |  |  |  |
| A1090 | ROCE Y LIMPIEZA DE MALEZA | 2023-05-08 → 2023-05-31 (+23d) | 2023-05-11 → 2023-06-16 (+36d) | 4d → 17d | 167d → 0d | A1070 SS+7d → A1015 |  |
| A1100 | MEJORAMIENTO DE VIAS EXISTENTES | 2023-05-11 → 2023-05-31 (+20d) | 2023-06-01 → 2023-06-16 (+15d) | 22d → 17d | 167d → 0d | A1090 SS+3d → A1090 SS |  |
| 2 | **REPOSICIÓN DE ESTRUCTURAS** | 2023-05-15 → 2023-06-20 (+36d) | 2023-05-23 → 2023-07-24 (+62d) |  |  |  |  |
| A1150 | DEMOLICIÓN DE ESTRUCTURAS EXISTENTES | 2023-05-15 → 2023-06-20 (+36d) | 2023-05-17 → 2023-06-21 (+35d) | 3d → 2d | 168d → 112d | A1100 SS+4d → A1070 SS+23d |  |
| A1160 | REPOSICIÓN DE PASE DE AGUA TUBO HDPE Ø=18" | 2023-05-18 → 2023-06-23 (+36d) | 2023-05-20 → 2023-06-24 (+35d) | 3d → 2d | 168d → 112d | A1150 → A1150 SS+3d |  |
| A1170 | REPOSICIÓN DE PASE DE AGUA TUBO HDPE Ø=36" | 2023-05-18 → 2023-06-23 (+36d) | 2023-05-20 → 2023-06-24 (+35d) | 3d → 2d | 168d → 112d |  |  |
| A1180 | SUMINISTRO Y MONTAJE DE PANELES DE C°A° 1.6mx1.0mx0.20m EN PASE DE AGUA | 2023-05-21 → 2023-06-25 (+35d) | 2023-05-23 → 2023-07-24 (+62d) | 3d → 30d | 168d → 112d | A1170 → A1170 SS+2d |  |
| A1190 | SUMINISTRO Y MONTAJE DE PANELES DE C°A° 2.20mx1.0mx0.20m EN PASE DE AGUA | 2023-05-21 → 2023-06-25 (+35d) | 2023-05-23 → 2023-07-24 (+62d) | 3d → 30d | 168d → 112d |  |  |
| 4 | **CABEZAL DE ENTRADA Y SALIDA** | 2023-05-24 → 2023-07-25 (+62d) | 2023-05-31 → 2023-07-30 (+60d) |  |  |  |  |
| A1210 | ENCOFRADO Y DESENCOFRADO RECTO | 2023-05-24 → 2023-07-25 (+62d) | 2023-05-28 → 2023-07-27 (+60d) | 5d → 3d | 168d → 112d |  |  |
| A1200 | CONCRETOS | 2023-05-29 → 2023-07-28 (+60d) | 2023-05-31 → 2023-07-30 (+60d) |  | 168d → 112d |  |  |
| A1220 | DESBROCE Y LIMPIEZA EN ZONA NO BOSCOSA | 2023-05-01 → 2023-06-02 (+32d) | 2023-06-12 → 2023-08-16 (+65d) | 43d → 76d | 146d → 0d | A1060 SS → A1070 SS+4d, A1015, A1040 SS+1d | resources Operador Tractor [487.46 h]; Tractor D8 [487 h]; Excavadora [426 h]; Operador Excavadora [426 h]; Operador Volquete [1157 h]; Volquete [1157 h] → none |
| 5 | **DIQUES DE TIERRA COMPACTADA CON ENROCADO** | 2023-05-06 → 2023-06-08 (+33d) | 2023-11-15 → 2023-11-19 (+4d) |  |  |  |  |
| 1 | **DIQUE DE TIERRA COMPACTADA A3-D-01** | 2023-06-13 → 2023-06-08 (-5d) | 2023-08-06 → 2023-07-11 (-26d) |  |  |  |  |
| A1260 | EXCAVACIÓN EN TERRENO NATURAL CON EQUIPO | 2023-06-13 → 2023-06-08 (-5d) | 2023-06-19 → 2023-06-17 (-2d) | 7d → 10d | 65d → 0d | INICIO DE EXCAVACION, A1350, A1360, A1980 → A1810 | resources Excavadora [56 h]; Tractor D6 [28 h]; Operador Excavadora [56 h]; Operador Tractor [28 h] → none |
| A1270 | EXCAVACIÓN DE UÑA CON EQUIPO | 2023-06-20 → 2023-06-09 (-11d) | 2023-06-23 → 2023-06-17 (-6d) | 4d → 9d | 65d → 91d | A1260 → A1260 SS+1d | resources Excavadora [29 h]; Operador Excavadora [29 h] → none |
| A1280 | PERFILADO Y COMPACTACIÓN EN ZONA DE CORTE | 2023-06-24 → 2023-06-09 (-15d) |  | 5d → 20d | 65d → 0d | A1270 → A1260 SS+1d | resources Operador Rodillo [17 h]; Rodillo [17 h]; Operador Motoniveladora [36 h]; Motoniveladora [36 h] → none |
| A1340 | PREPARACIÓN DE FUNDACIÓN DE CUERPO DE DIQUE | 2023-06-29 → 2023-06-09 (-20d) | 2023-07-01 → 2023-06-21 (-10d) | 3d → 13d | 65d → 0d | A1280 → A1280 SS | resources Rodillo [7 h]; Motoniveladora [7 h]; Operador Rodillo [7 h]; Operador Motoniveladora [7 h] → none |
| A1290 | CONFORMACIÓN DE CUERPO DE DIQUE CON MATERIAL PROPIO | 2023-07-02 → 2023-06-22 (-10d) | 2023-07-06 → 2023-06-26 (-10d) |  | 65d → 0d | A1340 → A1016 | resources Operador Excavadora [39 h]; Excavadora [39 h]; Motoniveladora [38 h]; Operador Motoniveladora [38 h]; Operador Rodillo [38 h]; Rodillo [38 h] → none |
| A1310 | GEOTEXTIL NO TEJIDO 400 G/M2, INC. COLOCACIÓN | 2023-07-07 → 2023-06-24 (-13d) | 2023-07-18 → 2023-06-29 (-19d) | 12d → 6d | 65d → 0d | A1290 → A1290 SS+2d |  |
| A1320 | COLOCACION Y ACOMODO DE ROCA EN UÑA DE DIQUE | 2023-07-11 → 2023-06-25 (-16d) | 2023-07-20 → 2023-06-30 (-20d) | 10d → 6d | 65d → 0d | A1310 SS+4d → A1310 SS+1d | resources Operador Excavadora [447 h]; Excavadora [447 h] → none |
| A1330 | COLOCACION Y ACOMODO DE ROCA EN TALUD DE DIQUE | 2023-07-18 → 2023-06-27 (-21d) | 2023-07-31 → 2023-07-08 (-23d) | 14d → 12d | 65d → 0d | A1320 SS+7d → A1320 SS+2d | resources Excavadora [682 h]; Operador Excavadora [682 h] → none |
| A1300 | CONFORMACIÓN DE CORONA DE DIQUE CON MATERIAL PROPIO | 2023-08-01 → 2023-07-06 (-26d) | 2023-08-06 → 2023-07-11 (-26d) |  | 68d → 97d | A1330 → A1330 FF+3d | resources Motoniveladora [23 h]; Rodillo [23 h]; Excavadora [24 h]; Operador Motoniveladora [23 h]; Operador Rodillo [23 h]; Operador Excavadora [24 h] → none |
| 2 | **DIQUE DE TIERRA COMPACTADA A3-D-02** | 2023-05-06 → 2023-07-11 (+66d) | 2023-09-20 → 2023-11-07 (+48d) |  |  |  |  |
| A1350 | EXCAVACIÓN EN TERRENO NATURAL CON EQUIPO | 2023-05-06 → 2023-07-11 (+66d) | 2023-05-31 → 2023-07-19 (+49d) | 26d → 9d |  | INICIO DE EXCAVACION → A1830 | resources Operador Excavadora [485 h]; Excavadora [485 h]; Operador Tractor [240 h]; Tractor D6 [240 h] → none |
| A1360 | EXCAVACIÓN DE UÑA CON EQUIPO | 2023-05-27 → 2023-07-12 (+46d) | 2023-06-07 → 2023-07-22 (+45d) | 12d → 11d | 0d → 67d | A1350 FS-5d → A1350 SS+1d, A1270 | resources Operador Excavadora [206 h]; Excavadora [206 h] → none |
| A1370 | PERFILADO Y COMPACTACIÓN EN ZONA DE CORTE | 2023-06-08 → 2023-07-12 (+34d) | 2023-06-18 → 2023-07-23 (+35d) | 11d → 12d |  | A1360 → A1350 SS+1d | resources Operador Rodillo [105 h]; Operador Motoniveladora [223 h]; Rodillo [105 h]; Motoniveladora [223 h] → none |
| A1400 | GEOTEXTIL NO TEJIDO 400 G/M2, INC. COLOCACIÓN | 2023-06-29 → 2023-07-14 (+15d) | 2023-08-12 → 2023-07-26 (-17d) | 45d → 13d |  | A1380 FS-2d → A1370 SS+2d |  |
| A1410 | COLOCACION Y ACOMODO DE ROCA EN UÑA DE DIQUE | 2023-07-02 → 2023-07-16 (+14d) | 2023-08-27 → 2023-07-31 (-27d) | 57d → 16d |  | A1400 SS+3d → A1400 SS+2d | resources Operador Excavadora [3210 h]; Excavadora [3210 h] → none |
| A1420 | COLOCACION Y ACOMODO DE ROCA EN TALUD DE DIQUE | 2023-07-17 → 2023-07-18 (+1d) | 2023-09-02 → 2023-08-01 (-32d) | 48d → 15d |  | A1410 SS+15d → A1410 SS+2d | resources Operador Excavadora [3908 h]; Excavadora [3908 h] → none |
| A1430 | PREPARACIÓN DE FUNDACIÓN DE CUERPO DE DIQUE | 2023-06-19 → 2023-07-20 (+31d) | 2023-06-24 → 2023-07-24 (+30d) | 6d → 5d | 0d → 77d | A1370 → A1350 | resources Operador Motoniveladora [26 h]; Operador Rodillo [26 h]; Motoniveladora [26 h]; Rodillo [26 h] → none |
| A1380 | CONFORMACIÓN DE CUERPO DE DIQUE CON MATERIAL PROPIO | 2023-06-22 → 2023-07-21 (+29d) | 2023-06-30 → 2023-07-25 (+25d) | 9d → 5d | 0d → 77d | A1430 FS-3d → A1430 SS+1d | resources Operador Excavadora [164 h]; Operador Rodillo [160 h]; Excavadora [164 h]; Rodillo [160 h]; Operador Motoniveladora [160 h]; Motoniveladora [160 h] → none |
| A1390 | CONFORMACIÓN DE CORONA DE DIQUE CON MATERIAL PROPIO | 2023-09-03 → 2023-07-30 (-35d) | 2023-09-20 → 2023-08-04 (-47d) | 18d → 6d | 23d → 79d | A1420 → A1420 FF+3d, A1300 | resources Excavadora [119 h]; Rodillo [116 h]; Motoniveladora [116 h]; Operador Excavadora [119 h]; Operador Rodillo [116 h]; Operador Motoniveladora [116 h] → none |
| A1910 | EXCAVACIÓN EN TERRENO NATURAL CON EQUIPO | 2023-05-06 → 2023-08-04 (+90d) | 2023-05-12 → 2023-08-12 (+92d) | 7d → 9d |  | INICIO DE EXCAVACION → A1850 | resources Operador Excavadora [126 h]; Operador Tractor [62 h]; Excavadora [126 h]; Tractor D6 [62 h] → none |
| A1920 | EXCAVACIÓN DE UÑA CON EQUIPO | 2023-05-13 → 2023-08-05 (+84d) | 2023-05-14 → 2023-08-15 (+93d) | 2d → 11d | 0d → 54d | A1910 → A1910 SS+1d, A1360 | resources Operador Excavadora [28 h]; Excavadora [28 h] → none |
| A1930 | PERFILADO Y COMPACTACIÓN EN ZONA DE CORTE | 2023-05-15 → 2023-08-05 (+82d) | 2023-05-16 → 2023-08-16 (+92d) | 2d → 12d |  | A1920 → A1910 SS+1d | resources Rodillo [15 h]; Motoniveladora [32 h]; Operador Rodillo [15 h]; Operador Motoniveladora [32 h] → none |
| A1960 | GEOTEXTIL NO TEJIDO 400 G/M2, INC. COLOCACIÓN | 2023-05-23 → 2023-08-07 (+76d) | 2023-05-25 → 2023-08-18 (+85d) | 3d → 12d |  | A1940 → A1930 SS+2d |  |
| A1970 | COLOCACION Y ACOMODO DE ROCA EN UÑA DE DIQUE | 2023-05-26 → 2023-08-09 (+75d) | 2023-06-01 → 2023-08-24 (+84d) | 7d → 16d |  | A1960 → A1960 SS+2d | resources Operador Excavadora [437 h]; Excavadora [437 h] → none |
| A1980 | COLOCACION Y ACOMODO DE ROCA EN TALUD DE DIQUE | 2023-06-02 → 2023-08-11 (+70d) | 2023-06-12 → 2023-08-25 (+74d) | 11d → 15d | 65d → 0d | A1970, A1970 FF → A1970 SS+2d | resources Operador Excavadora [669 h]; Excavadora [669 h] → none |
| A1990 | PREPARACIÓN DE FUNDACIÓN DE CUERPO DE DIQUE | 2023-05-17 → 2023-08-13 (+88d) | 2023-05-18 → 2023-08-17 (+91d) | 2d → 5d | 0d → 58d | A1930 → A1910 | resources Operador Motoniveladora [9 h]; Operador Rodillo [9 h]; Motoniveladora [9 h]; Rodillo [9 h] → none |
| A1940 | CONFORMACIÓN DE CUERPO DE DIQUE CON MATERIAL PROPIO | 2023-05-19 → 2023-08-14 (+87d) | 2023-05-22 → 2023-08-18 (+88d) | 4d → 5d | 0d → 58d | A1990 → A1990 SS+1d, A1380 | resources Operador Excavadora [66 h]; Operador Rodillo [64 h]; Operador Motoniveladora [64 h]; Motoniveladora [64 h]; Excavadora [66 h]; Rodillo [64 h] → none |
| A1950 | CONFORMACIÓN DE CORONA DE DIQUE CON MATERIAL PROPIO | 2023-06-13 → 2023-08-23 (+71d) | 2023-06-16 → 2023-08-28 (+73d) | 4d → 6d | 152d → 61d | A1980 → A1980 FF+3d, A1390 | resources Rodillo [23 h]; Motoniveladora [23 h]; Excavadora [23 h]; Operador Excavadora [23 h]; Operador Rodillo [23 h]; Operador Motoniveladora [23 h] → none |
| A2000 | EXCAVACIÓN EN TERRENO NATURAL CON EQUIPO | 2023-07-27 → 2023-08-28 (+32d) | 2023-07-31 → 2023-09-05 (+36d) | 5d → 9d |  | LIBERACIÓN DE PREDIOS A3-I-01 → A2710 | resources Operador Excavadora [126 h]; Operador Tractor [62 h]; Excavadora [126 h]; Tractor D6 [62 h] → none |
| A2010 | EXCAVACIÓN DE UÑA CON EQUIPO | 2023-08-01 → 2023-08-29 (+28d) | 2023-08-03 → 2023-09-08 (+36d) | 3d → 11d | 0d → 41d | A2000 → A2000 SS+1d, A1920 | resources Operador Excavadora [28 h]; Excavadora [28 h] → none |
| A2020 | PERFILADO Y COMPACTACIÓN EN ZONA DE CORTE | 2023-08-04 → 2023-08-29 (+25d) | 2023-08-05 → 2023-09-09 (+35d) | 2d → 12d |  | A2010 → A2000 SS+1d | resources Rodillo [15 h]; Motoniveladora [32 h]; Operador Rodillo [15 h]; Operador Motoniveladora [32 h] → none |
| A2050 | GEOTEXTIL NO TEJIDO 400 G/M2, INC. COLOCACIÓN | 2023-08-11 → 2023-08-31 (+20d) | 2023-08-15 → 2023-09-11 (+27d) | 5d → 12d |  | A2030 → A2020 SS+2d |  |
| A2060 | COLOCACION Y ACOMODO DE ROCA EN UÑA DE DIQUE | 2023-08-16 → 2023-09-02 (+17d) | 2023-08-20 → 2023-09-17 (+28d) | 5d → 16d |  | A2050 → A2050 SS+2d | resources Operador Excavadora [437 h]; Excavadora [437 h] → none |
| A2070 | COLOCACION Y ACOMODO DE ROCA EN TALUD DE DIQUE | 2023-08-21 → 2023-09-04 (+14d) | 2023-08-30 → 2023-09-18 (+19d) | 10d → 15d |  | A2060, A2060 FF → A2060 SS+2d | resources Operador Excavadora [669 h]; Excavadora [669 h] → none |
| A2080 | PREPARACIÓN DE FUNDACIÓN DE CUERPO DE DIQUE | 2023-08-06 → 2023-09-06 (+31d) | 2023-08-07 → 2023-09-10 (+34d) | 2d → 5d | 0d → 39d | A2020 → A2000 | resources Operador Motoniveladora [9 h]; Operador Rodillo [9 h]; Motoniveladora [9 h]; Rodillo [9 h] → none |
| A2030 | CONFORMACIÓN DE CUERPO DE DIQUE CON MATERIAL PROPIO | 2023-08-08 → 2023-09-07 (+30d) | 2023-08-10 → 2023-09-11 (+32d) | 3d → 5d | 0d → 39d | A2080 → A2080 SS+1d, A1940 | resources Operador Excavadora [66 h]; Operador Rodillo [64 h]; Operador Motoniveladora [64 h]; Motoniveladora [64 h]; Excavadora [66 h]; Rodillo [64 h] → none |
| A2040 | CONFORMACIÓN DE CORONA DE DIQUE CON MATERIAL PROPIO | 2023-08-31 → 2023-09-16 (+16d) | 2023-09-01 → 2023-09-21 (+20d) | 2d → 6d | 75d → 43d | A2070 → A2070 FF+3d, A1950 | resources Rodillo [23 h]; Motoniveladora [23 h]; Excavadora [23 h]; Operador Excavadora [23 h]; Operador Rodillo [23 h]; Operador Motoniveladora [23 h] → none |
| A2090 | EXCAVACIÓN EN TERRENO NATURAL CON EQUIPO | 2023-05-06 → 2023-09-21 (+138d) | 2023-06-01 → 2023-09-29 (+120d) | 27d → 9d | 12d → 0d | INICIO DE EXCAVACION → A2730 | resources Excavadora [171 h]; Tractor D6 [85 h]; Operador Excavadora [171 h]; Operador Tractor [85 h] → none |
| A2100 | EXCAVACIÓN DE UÑA CON EQUIPO | 2023-06-02 → 2023-09-22 (+112d) | 2023-06-09 → 2023-10-02 (+115d) | 8d → 11d | 12d → 28d | A2090 → A2090 SS+1d, A2010 | resources Operador Excavadora [38 h]; Excavadora [38 h] → none |
| A2110 | PERFILADO Y COMPACTACIÓN EN ZONA DE CORTE | 2023-06-10 → 2023-09-22 (+104d) | 2023-06-16 → 2023-10-03 (+109d) | 7d → 12d | 12d → 0d | A2100 → A2090 SS+1d | resources Operador Rodillo [19 h]; Operador Motoniveladora [40 h]; Rodillo [19 h]; Motoniveladora [40 h] → none |
| A2140 | GEOTEXTIL NO TEJIDO 400 G/M2, INC. COLOCACIÓN | 2023-06-24 → 2023-09-24 (+92d) | 2023-07-04 → 2023-10-05 (+93d) | 11d → 12d | 12d → 0d | A2120 → A2110 SS+2d |  |
| A2150 | COLOCACION Y ACOMODO DE ROCA EN UÑA DE DIQUE | 2023-06-27 → 2023-09-26 (+91d) | 2023-07-19 → 2023-10-11 (+84d) | 23d → 16d | 12d → 0d | A2140 SS+3d → A2140 SS+2d | resources Operador Excavadora [596 h]; Excavadora [596 h] → none |
| A2160 | COLOCACION Y ACOMODO DE ROCA EN TALUD DE DIQUE | 2023-07-12 → 2023-09-28 (+78d) | 2023-07-27 → 2023-10-12 (+77d) | 16d → 15d | 12d → 0d | A2150 SS+15d → A2150 SS+2d | resources Operador Excavadora [750 h]; Excavadora [750 h] → none |

| ID | Task | Start | Finish | Duration | Total float | Predecessors | Other |
| --- | --- | --- | --- | --- | --- | --- | --- |
| A2170 | PREPARACIÓN DE FUNDACIÓN DE CUERPO DE DIQUE | 2023-06-17 → 2023-09-30 (+105d) | 2023-06-19 → 2023-10-04 (+107d) | 3d → 5d | 12d → 20d | A2110 → A2090 | resources Operador Rodillo [4 h]; Operador Motoniveladora [4 h]; Rodillo [4 h]; Motoniveladora [4 h] → none |
| A2120 | CONFORMACIÓN DE CUERPO DE DIQUE CON MATERIAL PROPIO | 2023-06-20 → 2023-10-01 (+103d) | 2023-06-23 → 2023-10-05 (+104d) | 4d → 5d | 12d → 20d | A2170 → A2170 SS+1d, A2030 | resources Excavadora [14 h]; Operador Excavadora [14 h]; Rodillo [14 h]; Operador Rodillo [14 h]; Motoniveladora [14 h]; Operador Motoniveladora [14 h] → none |
| A2130 | CONFORMACIÓN DE CORONA DE DIQUE CON MATERIAL PROPIO | 2023-07-28 → 2023-10-10 (+74d) | 2023-08-02 → 2023-10-15 (+74d) |  | 105d → 25d | A2160 → A2160 FF+3d, A2040 | resources Excavadora [28 h]; Operador Excavadora [28 h]; Rodillo [27 h]; Operador Rodillo [27 h]; Motoniveladora [27 h]; Operador Motoniveladora [27 h] → none |
| A2180 | EXCAVACIÓN EN TERRENO NATURAL CON EQUIPO | 2023-05-06 → 2023-10-15 (+162d) | 2023-05-27 → 2023-10-23 (+149d) | 22d → 9d | 70d → 0d | INICIO DE EXCAVACION → A2750 | resources Operador Excavadora [315 h]; Excavadora [315 h]; Operador Tractor [155 h]; Tractor D6 [155 h] → none |
| A2190 | EXCAVACIÓN DE UÑA CON EQUIPO | 2023-05-28 → 2023-10-16 (+141d) | 2023-06-08 → 2023-10-26 (+140d) | 12d → 11d | 70d → 15d | A2180 → A2180 SS+1d, A2100 | resources Operador Excavadora [170 h]; Excavadora [170 h] → none |
| A2200 | PERFILADO Y COMPACTACIÓN EN ZONA DE CORTE | 2023-06-09 → 2023-10-16 (+129d) | 2023-06-19 → 2023-10-27 (+130d) | 11d → 12d | 70d → 0d | A2190 → A2180 SS+1d | resources Operador Motoniveladora [181 h]; Operador Rodillo [85 h]; Rodillo [85 h]; Motoniveladora [181 h] → none |
| A2230 | GEOTEXTIL NO TEJIDO 400 G/M2, INC. COLOCACIÓN | 2023-07-02 → 2023-10-17 (+107d) | 2023-08-03 → 2023-10-28 (+86d) | 33d → 12d | 70d → 0d | A2210 → A2200 SS+1d |  |
| A2240 | COLOCACION Y ACOMODO DE ROCA EN UÑA DE DIQUE | 2023-07-05 → 2023-10-19 (+106d) | 2023-08-02 → 2023-11-03 (+93d) | 29d → 16d | 70d → 0d | A2230 SS+3d → A2230 SS+2d | resources Operador Excavadora [2646 h]; Excavadora [2646 h] → none |
| A2250 | COLOCACION Y ACOMODO DE ROCA EN TALUD DE DIQUE | 2023-07-20 → 2023-10-21 (+93d) | 2023-08-24 → 2023-11-04 (+72d) | 36d → 15d | 70d → 1d | A2240 SS+15d → A2240 SS+2d | resources Operador Excavadora [3250 h]; Excavadora [3250 h] → none |
| A2260 | PREPARACIÓN DE FUNDACIÓN DE CUERPO DE DIQUE | 2023-06-20 → 2023-10-24 (+126d) | 2023-06-24 → 2023-10-28 (+126d) |  | 70d → 1d | A2200 → A2180 | resources Operador Rodillo [25 h]; Operador Motoniveladora [25 h]; Motoniveladora [25 h]; Rodillo [25 h] → none |
| A2210 | CONFORMACIÓN DE CUERPO DE DIQUE CON MATERIAL PROPIO | 2023-06-23 → 2023-10-25 (+124d) | 2023-07-01 → 2023-10-29 (+120d) | 9d → 5d | 70d → 1d | A2260 FS-2d → A2260 SS+1d, A2120 | resources Operador Excavadora [133 h]; Operador Rodillo [130 h]; Operador Motoniveladora [130 h]; Rodillo [130 h]; Motoniveladora [130 h]; Excavadora [133 h] → none |
| A2220 | CONFORMACIÓN DE CORONA DE DIQUE CON MATERIAL PROPIO | 2023-08-25 → 2023-11-02 (+69d) | 2023-09-06 → 2023-11-07 (+62d) | 13d → 6d | 70d → 8d | A2250 → A2250 FF+3d, A2130 | resources Operador Excavadora [97 h]; Operador Rodillo [95 h]; Operador Motoniveladora [95 h]; Excavadora [97 h]; Rodillo [95 h]; Motoniveladora [95 h] → none |
| 3 | **DIQUE DE TIERRA COMPACTADA A3-I-01** | 2023-05-06 → 2023-07-11 (+66d) | 2023-09-01 → 2023-11-13 (+73d) |  |  |  |  |
| A1440 | EXCAVACIÓN EN TERRENO NATURAL CON EQUIPO | 2023-10-13 → 2023-07-11 (-94d) | 2023-10-15 → 2023-07-17 (-90d) | 3d → 7d |  | LIBERACION DE PREDIOS A3-I-03 → A1240 | resources Operador Excavadora [315 h]; Excavadora [315 h]; Operador Tractor [155 h]; Tractor D6 [155 h] → none |
| A1450 | EXCAVACIÓN DE UÑA CON EQUIPO | 2023-10-16 → 2023-07-12 (-96d) | 2023-10-18 → 2023-07-17 (-93d) | 3d → 6d | 0d → 65d | A1440 → A1440 SS+1d | resources Operador Excavadora [170 h]; Excavadora [170 h] → none |
| A1460 | PERFILADO Y COMPACTACIÓN EN ZONA DE CORTE | 2023-10-19 → 2023-07-12 (-99d) | 2023-10-20 → 2023-07-18 (-94d) | 2d → 7d |  | A1450 → A1440 SS+1d | resources Operador Motoniveladora [181 h]; Operador Rodillo [85 h]; Rodillo [85 h]; Motoniveladora [181 h] → none |
| A1520 | PREPARACIÓN DE FUNDACIÓN DE CUERPO DE DIQUE | 2023-10-21 → 2023-07-12 (-101d) | 2023-10-22 → 2023-07-16 (-98d) | 2d → 5d |  | A1460 → A1460 SS | resources Operador Rodillo [25 h]; Operador Motoniveladora [25 h]; Motoniveladora [25 h]; Rodillo [25 h] → none |
| A1470 | CONFORMACIÓN DE CUERPO DE DIQUE CON MATERIAL PROPIO | 2023-10-21 → 2023-07-13 (-100d) | 2023-10-22 → 2023-07-17 (-97d) | 2d → 5d |  | A1520 FS-2d → A1520 SS+1d | resources Operador Excavadora [133 h]; Operador Rodillo [130 h]; Operador Motoniveladora [130 h]; Rodillo [130 h]; Motoniveladora [130 h]; Excavadora [133 h] → none |
| A1490 | GEOTEXTIL NO TEJIDO 400 G/M2, INC. COLOCACIÓN | 2023-10-23 → 2023-07-15 (-100d) | 2023-10-26 → 2023-07-18 (-100d) |  |  | A1470 → A1470 SS+2d |  |
| A1500 | COLOCACION Y ACOMODO DE ROCA EN UÑA DE DIQUE | 2023-10-26 → 2023-07-17 (-101d) | 2023-10-29 → 2023-07-20 (-101d) |  |  | A1490 SS+3d → A1490 SS+2d | resources Operador Excavadora [2646 h]; Excavadora [2646 h] → none |
| A1510 | COLOCACION Y ACOMODO DE ROCA EN TALUD DE DIQUE | 2023-11-10 → 2023-07-19 (-114d) | 2023-11-13 → 2023-07-25 (-111d) | 4d → 7d |  | A1500 SS+15d → A1500 SS+2d | resources Operador Excavadora [3250 h]; Excavadora [3250 h] → none |
| A1480 | CONFORMACIÓN DE CORONA DE DIQUE CON MATERIAL PROPIO | 2023-11-14 → 2023-07-26 (-111d) | 2023-11-15 → 2023-07-28 (-110d) | 2d → 3d | 0d → 34d | A1510 → A1510 FF+3d | resources Operador Excavadora [97 h]; Operador Rodillo [95 h]; Operador Motoniveladora [95 h]; Excavadora [97 h]; Rodillo [95 h]; Motoniveladora [95 h] → none |
| A4030 | EXCAVACIÓN EN TERRENO NATURAL CON EQUIPO | 2023-08-25 → 2023-10-24 (+60d) | 2023-08-27 → 2023-10-27 (+61d) | 3d → 4d | 74d → 5d | A2250 → A2180 | resources Excavadora [5 h]; Operador Excavadora [5 h]; Tractor D6 [3 h]; Operador Tractor [3 h] → none |
| 4 | **DIQUE DE TIERRA COMPACTADA A3-I-02** | 2023-05-06 → 2023-07-28 (+83d) | 2023-08-02 → 2023-08-21 (+19d) |  |  |  |  |
| A1530 | EXCAVACIÓN EN TERRENO NATURAL CON EQUIPO | 2023-08-03 → 2023-07-28 (-6d) | 2023-08-09 → 2023-08-11 (+2d) | 7d → 15d | 12d → 0d | A3560 → A1790 |  |
| 5 | **DIQUE DE TIERRA COMPACTADA A3-I-03** | 2023-05-06 → 2023-08-21 (+107d) | 2023-11-15 → 2023-11-19 (+4d) |  |  |  |  |
| A1620 | EXCAVACIÓN EN TERRENO NATURAL CON EQUIPO | 2023-05-08 → 2023-08-21 (+105d) | 2023-05-10 → 2023-08-27 (+109d) | 3d → 7d | 142d → 0d | A3650 → A2630 |  |
| 6 | **RAMPAS** | 2023-08-25 → 2023-10-27 (+63d) | 2023-09-02 → 2023-11-09 (+68d) |  |  |  |  |
| A1720 | CONFORMACIÓN DE CUERPO DE RAMPA CON MATERIAL PROPIO | 2023-08-28 → 2023-10-30 (+63d) | 2023-08-30 → 2023-11-01 (+63d) |  | 74d → 15d | A4030 → A1710 | resources Excavadora [7 h]; Operador Excavadora [7 h]; Rodillo [7 h]; Operador Rodillo [7 h]; Motoniveladora [7 h]; Operador Motoniveladora [7 h] → none |
| A1730 | CONFORMACIÓN DE CORONACIÓN DE RAMPA | 2023-08-31 → 2023-10-30 (+60d) | 2023-09-02 → 2023-11-01 (+60d) |  | 74d → 15d | A1720 → A1720 SS | resources Excavadora [5 h]; Operador Excavadora [5 h]; Motoniveladora [5 h]; Operador Motoniveladora [5 h]; Operador Rodillo [5 h]; Rodillo [5 h] → none |
| 2 | **OBRAS DE ARTE** | 2023-05-01 → 2023-06-01 (+31d) | 2023-11-15 → 2023-11-16 (+1d) |  |  |  |  |
| 1 | **CAPTACIÓN A3-CP-23-95** | 2023-07-17 → 2023-06-16 (-31d) | 2023-11-15 → 2023-10-12 (-34d) |  |  |  |  |
| 1 | **MOVIMIENTO DE TIERRAS** | 2023-07-17 → 2023-06-16 (-31d) | 2023-08-25 → 2023-08-02 (-23d) |  |  |  |  |
| A2770 | EXCAVACIÓN ESTRUCTURAL PARA OBRAS DE ARTE | 2023-07-17 → 2023-06-16 (-31d) | 2023-07-24 → 2023-06-21 (-33d) | 8d → 6d | 0d → 38d | A1420 SS → A3390 |  |
| A2780 | RELLENO ESTRUCTURAL PARA OBRAS DE ARTE, CON MATERIAL PROPIO | 2023-08-21 → 2023-07-29 (-23d) | 2023-08-25 → 2023-08-02 (-23d) |  | 82d → 90d | A2800 → A2800 FS+12d |  |
| 2 | **OBRAS DE CONCRETO** | 2023-07-25 → 2023-06-22 (-33d) | 2023-08-20 → 2023-07-16 (-35d) |  |  |  |  |
| A2790 | CONCRETO f'c=100 kg/cm2 | 2023-07-28 → 2023-06-22 (-36d) | 2023-07-30 → 2023-06-24 (-36d) |  | 0d → 50d | A2810 → A2770 |  |
| A2810 | CONCRETO CICLÓPEO f'c=280 kg/cm2 + 30% P.G. | 2023-07-25 → 2023-06-25 (-30d) | 2023-07-27 → 2023-06-27 (-30d) |  | 0d → 50d | A2770 → A2790 |  |
| A2830 | ACERO DE REFUERZO fy=4200 kg/cm2 | 2023-07-31 → 2023-06-28 (-33d) | 2023-08-10 → 2023-07-10 (-31d) | 11d → 13d | 0d → 50d | A2790 → A2810 |  |
| A2820 | ENCOFRADO Y DESENCOFRADO RECTO | 2023-08-09 → 2023-07-02 (-38d) | 2023-08-15 → 2023-07-11 (-35d) | 7d → 10d | 0d → 53d | A2830 FS-2d → A2830 FF+1d |  |
| A2800 | CONCRETO f'c=280 kg/cm2 | 2023-08-16 → 2023-07-05 (-42d) | 2023-08-20 → 2023-07-16 (-35d) | 5d → 12d | 0d → 55d | A2820 → A2820 SS+3d |  |
| 3 | **ESTRUCTURAS METALICAS** | 2023-08-21 → 2023-07-29 (-23d) | 2023-09-04 → 2023-08-12 (-23d) |  |  |  |  |
| A2840 | COMPUERTA METALICA PLANA DESLIZANTE DE 1.0x1.0m | 2023-08-21 → 2023-07-29 (-23d) | 2023-08-23 → 2023-07-31 (-23d) |  | 72d → 99d | A2800 → A2800 FS+12d |  |
| A2850 | REJILLA DE 1.00x1.00m CON VARILLA DE 1/2" CADA 6,25cm | 2023-08-24 → 2023-08-01 (-23d) | 2023-08-26 → 2023-08-03 (-23d) |  | 72d → 99d |  |  |
| A2860 | BARANDA DE FIERRO GALVANIZADO 1 1/2" | 2023-08-27 → 2023-08-04 (-23d) | 2023-08-29 → 2023-08-06 (-23d) |  | 72d → 99d |  |  |
| A2870 | ESCALERA TIPO GATO | 2023-08-30 → 2023-08-07 (-23d) | 2023-09-01 → 2023-08-09 (-23d) |  | 72d → 99d |  |  |
| A2880 | TAPA METALICA CIRCULAR DN600 MM | 2023-09-02 → 2023-08-10 (-23d) | 2023-09-04 → 2023-08-12 (-23d) |  | 72d → 99d |  |  |
| 4 | **TUBERIAS** | 2023-08-21 → 2023-06-22 (-60d) | 2023-10-16 → 2023-08-18 (-59d) |  |  |  |  |
| A2890 | EXCAVACIÓN ESTRUCTURAL PARA OBRAS DE ARTE (Buzones) | 2023-08-21 → 2023-06-22 (-60d) | 2023-08-25 → 2023-06-24 (-62d) | 5d → 3d | 0d → 38d | A2800 → A2770 |  |
| A2900 | EXCAVACIÓN DE ZANJA | 2023-09-13 → 2023-06-25 (-80d) | 2023-09-25 → 2023-07-19 (-68d) | 13d → 25d | 30d → 38d | A2950, A2800 → A2890 |  |
| A2920 | CAMA DE ARENA | 2023-09-26 → 2023-06-28 (-90d) | 2023-10-01 → 2023-07-22 (-71d) | 6d → 25d | 30d → 93d | A2900 → A2900 SS+3d |  |
| A2940 | CONCRETO f'c=100 kg/cm2 (Buzones) | 2023-08-26 → 2023-06-28 (-59d) | 2023-08-28 → 2023-06-30 (-59d) |  | 30d → 60d | A2890 → A2900 SS+3d, A2790 |  |
| A2990 | SUMINISTRO E INSTALACIÓN DE TUBERÍA GRP DN600 mm SN2500 | 2023-10-02 → 2023-06-29 (-95d) | 2023-10-08 → 2023-07-23 (-77d) | 7d → 25d | 30d → 93d | A2920 → A2920 SS+1d |  |
| A2980 | ACERO DE REFUERZO fy=4200 kg/cm2 (Buzones) | 2023-08-29 → 2023-07-11 (-49d) | 2023-09-02 → 2023-07-14 (-50d) | 5d → 4d | 30d → 50d | A2940 → A2940, A2830 |  |
| A2960 | ENCOFRADO Y DESENCOFRADO RECTO | 2023-09-06 → 2023-07-15 (-53d) | 2023-09-09 → 2023-07-19 (-52d) | 4d → 5d | 30d → 50d | A2970 → A2820, A2980 |  |
| A2970 | ENCOFRADO Y DESENCOFRADO CURVO | 2023-09-01 → 2023-07-15 (-48d) | 2023-09-05 → 2023-07-19 (-48d) |  | 30d → 50d | A2980 FS-2d → A2960 SS |  |
| A2950 | CONCRETO f'c=280 kg/cm2 (Buzones) | 2023-09-10 → 2023-07-20 (-52d) | 2023-09-12 → 2023-07-22 (-52d) |  | 30d → 52d | A2960 → A2970, A2800 |  |
| A2930 | RELLENO COMÚN PARA ZANJAS | 2023-10-09 → 2023-07-24 (-77d) | 2023-10-16 → 2023-08-18 (-59d) | 8d → 26d | 30d → 93d |  |  |
| A2910 | RELLENO ESTRUCTURAL PARA OBRAS DE ARTE CON MATERIAL PROPIO (Buzones) | 2023-09-13 → 2023-08-04 (-40d) | 2023-09-15 → 2023-08-06 (-40d) |  | 61d → 89d | A2950 → A2950 FS+12d, A2780 |  |
| 5 | **CANAL** | 2023-08-26 → 2023-07-20 (-37d) | 2023-10-29 → 2023-09-24 (-35d) |  |  |  |  |
| A3000 | EXCAVACIÓN ESTRUCTURAL PARA OBRAS DE ARTE | 2023-08-26 → 2023-07-20 (-37d) | 2023-09-02 → 2023-07-25 (-39d) | 8d → 6d | 0d → 38d | A2770 FS+5d, A2890 → A2900 |  |
| A3020 | COLOCACIÓN DE CONCRETO f'c=100 kg/cm2 | 2023-09-03 → 2023-07-26 (-39d) | 2023-09-06 → 2023-07-29 (-39d) |  | 0d → 38d | A3000 → A2940, A3000 |  |
| A3050 | ACERO DE REFUERZO fy=4200 kg/cm2 | 2023-09-07 → 2023-07-30 (-39d) | 2023-09-19 → 2023-08-26 (-24d) | 13d → 28d | 0d → 38d | A3020 → A2980, A3020 |  |
| A3040 | ENCOFRADO Y DESENCOFRADO RECTO | 2023-09-12 → 2023-08-01 (-42d) | 2023-10-11 → 2023-09-21 (-20d) | 30d → 52d | 0d → 38d | A3050 SS+5d → A2970, A3050 SS+2d |  |
| A3030 | COLOCACIÓN DE CONCRETO f'c=280 kg/cm2 | 2023-10-16 → 2023-08-03 (-74d) | 2023-10-20 → 2023-09-24 (-26d) | 5d → 53d | 0d → 38d | A3060 → A2950 SS, A3040 SS+2d |  |
| A3060 | JUNTA WATER STOP SIN BULBO 150 mm | 2023-10-12 → 2023-08-03 (-70d) | 2023-10-15 → 2023-09-24 (-21d) | 4d → 53d | 0d → 53d | A3040 → A3030 SS |  |
| A3010 | RELLENO ESTRUCTURAL PARA CANALES, CON MATERIAL PROPIO | 2023-10-21 → 2023-08-07 (-75d) | 2023-10-29 → 2023-08-19 (-71d) | 9d → 13d | 17d → 89d | A3030 → A2910 |  |
| 6 | **OBRAS DE DESCARGA** | 2023-10-21 → 2023-07-26 (-87d) | 2023-11-15 → 2023-10-12 (-34d) |  |  |  |  |
| A3070 | EXCAVACIÓN ESTRUCTURAL PARA OBRAS DE ARTE | 2023-10-21 → 2023-07-26 (-87d) | 2023-10-23 → 2023-07-28 (-87d) |  | 0d → 87d | A3030 → A3000 |  |
| A3090 | CONCRETO f'c=100 kg/cm2 | 2023-10-24 → 2023-07-30 (-86d) | 2023-10-26 → 2023-08-01 (-86d) |  | 0d → 86d | A3070 → A3070, A3020 |  |

| ID | Task | Start | Finish | Duration | Total float | Predecessors |
| --- | --- | --- | --- | --- | --- | --- |
| A3120 | ACERO DE REFUERZO fy=4200 kg/cm2 | 2023-10-27 → 2023-08-27 (-61d) | 2023-10-29 → 2023-08-29 (-61d) |  | 0d → 61d | A3090 → A3090, A3050 |
| A3110 | ENCOFRADO Y DESENCOFRADO RECTO | 2023-10-30 → 2023-09-22 (-38d) | 2023-11-03 → 2023-09-24 (-40d) | 5d → 3d | 0d → 38d | A3120 → A3120, A3040 |
| A3100 | CONCRETO f'c=280 kg/cm2 | 2023-11-05 → 2023-09-25 (-41d) | 2023-11-07 → 2023-09-27 (-41d) |  | 0d → 38d | A3130 → A3110, A3030 |
| A3130 | JUNTA WATER STOP SIN BULBO 150 mm | 2023-11-01 → 2023-09-28 (-34d) | 2023-11-04 → 2023-09-30 (-35d) | 4d → 3d | 0d → 50d | A3110 SS+2d → A3100, A3060 |
| A3080 | RELLENO ESTRUCTURAL PARA OBRAS DE ARTE CON MATERIAL PROPIO | 2023-11-08 → 2023-10-10 (-29d) | 2023-11-10 → 2023-10-12 (-29d) |  | 0d → 38d | A3100 → A3100 FS+12d, A3010 |
| A3140 | COMPUERTA METALICA PLANA DESLIZANTE | 2023-11-11 → 2023-10-10 (-32d) | 2023-11-15 → 2023-10-12 (-34d) | 5d → 3d | 0d → 38d | A3080 → A3100 FS+12d |
| 2 | **CAPTACIÓN A3-CP-21-05** | 2023-08-31 → 2023-06-04 (-88d) | 2023-11-15 → 2023-09-01 (-75d) |  |  |  |
| 1 | **MOVIMIENTO DE TIERRAS** | 2023-08-31 → 2023-06-04 (-88d) | 2023-10-09 → 2023-07-23 (-78d) |  |  |  |
| A3150 | EXCAVACIÓN ESTRUCTURAL PARA OBRAS DE ARTE | 2023-08-31 → 2023-06-04 (-88d) | 2023-09-05 → 2023-06-07 (-90d) | 6d → 4d | 0d → 38d | A2070 → A1070 SS+7d |
| A3160 | RELLENO ESTRUCTURAL PARA OBRAS DE ARTE, CON MATERIAL PROPIO | 2023-10-05 → 2023-07-19 (-78d) | 2023-10-09 → 2023-07-23 (-78d) |  | 37d → 119d | A3180 → A3180 FS+12d |
| 2 | **OBRAS DE CONCRETO** | 2023-09-06 → 2023-06-08 (-90d) | 2023-10-04 → 2023-07-06 (-90d) |  |  |  |
| A3170 | CONCRETO f'c=100 kg/cm2 | 2023-09-09 → 2023-06-08 (-93d) | 2023-09-11 → 2023-06-10 (-93d) |  | 24d → 79d | A3190 → A3150 |
| A3190 | CONCRETO CICLÓPEO f'c=280 kg/cm2 + 30% P.G. | 2023-09-06 → 2023-06-11 (-87d) | 2023-09-08 → 2023-06-13 (-87d) |  | 24d → 79d | A3150 → A3170 |
| A3210 | ACERO DE REFUERZO fy=4200 kg/cm2 | 2023-09-12 → 2023-06-14 (-90d) | 2023-09-22 → 2023-07-04 (-80d) | 11d → 21d | 24d → 79d | A3170 → A3190 |
| A3200 | ENCOFRADO Y DESENCOFRADO RECTO | 2023-09-16 → 2023-06-20 (-88d) | 2023-09-27 → 2023-07-04 (-85d) | 12d → 15d | 24d → 82d | A3210 SS+4d → A3210 SS+6d |
| A3180 | CONCRETO f'c=280 kg/cm2 | 2023-09-28 → 2023-06-26 (-94d) | 2023-10-04 → 2023-07-06 (-90d) | 7d → 11d | 24d → 109d | A3200 → A3200 SS+6d |
| 3 | **ESTRUCTURAS METALICAS** | 2023-10-05 → 2023-07-19 (-78d) | 2023-10-22 → 2023-08-02 (-81d) |  |  |  |
| A3220 | COMPUERTA METALICA PLANA DESLIZANTE DE 1.0x1.0m | 2023-10-05 → 2023-07-19 (-78d) | 2023-10-07 → 2023-07-21 (-78d) |  | 24d → 109d | A3180 → A3180 FS+12d |
| A3230 | REJILLA DE 1.00x1.00m CON VARILLA DE 1/2 CADA 6,25cm | 2023-10-08 → 2023-07-22 (-78d) | 2023-10-10 → 2023-07-24 (-78d) |  | 24d → 109d |  |
| A3240 | BARANDA DE FIERRO GALVANIZADO 1 1/2" | 2023-10-11 → 2023-07-25 (-78d) | 2023-10-16 → 2023-07-27 (-81d) | 6d → 3d | 24d → 109d |  |
| A3250 | ESCALERA TIPO GATO | 2023-10-17 → 2023-07-28 (-81d) | 2023-10-19 → 2023-07-30 (-81d) |  | 24d → 109d |  |
| A3260 | TAPA METALICA CIRCULAR DN600 MM | 2023-10-20 → 2023-07-31 (-81d) | 2023-10-22 → 2023-08-02 (-81d) |  | 24d → 109d |  |
| A3270 | EXCAVACIÓN ESTRUCTURAL PARA OBRAS DE ARTE (Buzones) | 2023-09-06 → 2023-06-08 (-90d) | 2023-09-08 → 2023-06-10 (-90d) |  | 0d → 38d |  |
| A3280 | EXCAVACIÓN DE ZANJA | 2023-09-25 → 2023-06-11 (-106d) | 2023-09-27 → 2023-06-13 (-106d) |  | 0d → 143d | A3340, A3150 → A3270 |
| A3330 | CONCRETO f'c=100 kg/cm2 (Buzones) | 2023-09-09 → 2023-06-11 (-90d) | 2023-09-11 → 2023-06-13 (-90d) |  | 0d → 100d | A3270 → A3270, A3170 |
| A3300 | CAMA DE ARENA | 2023-09-28 → 2023-06-14 (-106d) | 2023-09-30 → 2023-06-16 (-106d) |  | 0d → 143d |  |
| A3380 | SUMINISTRO E INSTALACIÓN DE TUBERÍA GRP DN600 mm SN2500 | 2023-10-01 → 2023-06-17 (-106d) | 2023-10-03 → 2023-06-19 (-106d) |  | 0d → 143d |  |
| A3310 | RELLENO SELECCIONADO PARA ZANJAS CON MATERIAL PROPIO | 2023-10-07 → 2023-06-20 (-109d) | 2023-10-09 → 2023-06-22 (-109d) |  | 37d → 143d | A3320 → A3320 SS |
| A3320 | RELLENO COMÚN PARA ZANJAS | 2023-10-04 → 2023-06-20 (-106d) | 2023-10-06 → 2023-06-22 (-106d) |  | 37d → 143d |  |
| A3370 | ACERO DE REFUERZO fy=4200 kg/cm2 | 2023-09-12 → 2023-07-05 (-69d) | 2023-09-14 → 2023-07-07 (-69d) |  | 0d → 79d | A3330 → A3330, A3210 |
| A3350 | ENCOFRADO Y DESENCOFRADO RECTO | 2023-09-19 → 2023-07-08 (-73d) | 2023-09-21 → 2023-07-10 (-73d) |  | 0d → 79d | A3360 → A3370, A3200 |
| A3360 | ENCOFRADO Y DESENCOFRADO CURVO | 2023-09-15 → 2023-07-08 (-69d) | 2023-09-18 → 2023-07-10 (-70d) | 4d → 3d | 0d → 79d | A3370 → A3350 SS |
| A3340 | CONCRETO f'c=280 kg/cm2 (Buzones) | 2023-09-22 → 2023-07-11 (-73d) | 2023-09-24 → 2023-07-13 (-73d) |  | 0d → 105d | A3350 → A3360, A3180 |
| A3290 | RELLENO ESTRUCTURAL PARA OBRAS DE ARTE CON MATERIAL PROPIO | 2023-09-25 → 2023-07-26 (-61d) | 2023-09-27 → 2023-07-28 (-61d) |  | 49d → 107d | A3340 → A3340 FS+12d |
| 5 | **CANALES** | 2023-10-04 → 2023-06-11 (-115d) | 2023-11-15 → 2023-09-01 (-75d) |  |  |  |
| A3390 | EXCAVACIÓN ESTRUCTURAL PARA OBRAS DE ARTE | 2023-10-04 → 2023-06-11 (-115d) | 2023-10-10 → 2023-06-15 (-117d) | 7d → 5d | 0d → 38d | A3380 → A3270 |
| A3410 | COLOCACIÓN DE CONCRETO f'c=100 kg/cm2 | 2023-10-11 → 2023-06-16 (-117d) | 2023-10-13 → 2023-06-18 (-117d) |  | 0d → 98d | A3390 → A3390, A3330 |
| A3440 | ACERO DE REFUERZO fy=4200 kg/cm2 | 2023-10-14 → 2023-07-08 (-98d) | 2023-10-19 → 2023-07-19 (-92d) | 6d → 12d | 0d → 79d | A3410 → A3410, A3370 |
| A3430 | ENCOFRADO Y DESENCOFRADO | 2023-10-18 → 2023-07-11 (-99d) | 2023-11-02 → 2023-08-08 (-86d) | 16d → 29d | 0d → 79d | A3440 SS+4d → A3440 SS+3d, A3360 |
| A3420 | COLOCACIÓN DE CONCRETO f'c=280 kg/cm2 | 2023-11-06 → 2023-08-09 (-89d) | 2023-11-09 → 2023-08-13 (-88d) | 4d → 5d | 0d → 79d | A3450 → A3430, A3340 |
| A3450 | JUNTA WATER STOP SIN BULBO 150 mm | 2023-11-03 → 2023-08-09 (-86d) | 2023-11-05 → 2023-08-11 (-86d) |  | 0d → 100d | A3430 → A3420 SS |
| A3400 | RELLENO ESTRUCTURAL PARA CANALES, CON MATERIAL PROPIO | 2023-11-10 → 2023-08-26 (-76d) | 2023-11-15 → 2023-09-01 (-75d) | 6d → 7d | 0d → 79d | A3420 → A3420 FS+12d, A3290, A3310 |
| 3 | **RETORNO A3-OA-RE-D-21-55** | 2023-08-01 → 2023-06-01 (-61d) | 2023-09-11 → 2023-07-24 (-49d) |  |  |  |
| 1 | **MOVIMIENTO DE TIERRAS** | 2023-08-01 → 2023-06-01 (-61d) | 2023-09-06 → 2023-07-20 (-48d) |  |  |  |
| A3460 | EXCAVACIÓN ESTRUCTURAL PARA OBRAS DE ARTE | 2023-08-01 → 2023-06-01 (-61d) | 2023-08-03 → 2023-06-03 (-61d) |  | 65d → 118d | A1330 → A1070 SS+4d |
| A3470 | RELLENO ESTRUCTURAL PARA OBRAS DE ARTE, CON MATERIAL PROPIO | 2023-09-04 → 2023-07-18 (-48d) | 2023-09-06 → 2023-07-20 (-48d) |  | 65d → 122d | A3490 → A3490 FS+12d |
| 2 | **OBRAS DE CONCRETO** | 2023-08-04 → 2023-06-04 (-61d) | 2023-09-03 → 2023-07-05 (-60d) |  |  |  |
| A3480 | CONCRETO f'c=100 kg/cm2 | 2023-08-08 → 2023-06-04 (-65d) | 2023-08-10 → 2023-06-06 (-65d) |  | 65d → 118d | A3500 → A3460 |
| A3500 | CONCRETO CICLÓPEO f'c=280 kg/cm2 + 30% P.G. | 2023-08-04 → 2023-06-07 (-58d) | 2023-08-07 → 2023-06-11 (-57d) | 4d → 5d | 65d → 118d | A3460 → A3480 |
| A3520 | ACERO DE REFUERZO fy=4200 kg/cm2 | 2023-08-11 → 2023-06-07 (-65d) | 2023-08-23 → 2023-06-30 (-54d) | 13d → 24d | 65d → 118d | A3480 → A3500 SS |
| A3510 | ENCOFRADO Y DESENCOFRADO | 2023-08-21 → 2023-06-13 (-69d) | 2023-08-26 → 2023-06-30 (-57d) | 6d → 18d | 65d → 118d | A3520 FS-3d → A3520 SS+6d |
| A3490 | CONCRETO f'c=280 kg/cm2 | 2023-08-31 → 2023-07-01 (-61d) | 2023-09-03 → 2023-07-05 (-60d) | 4d → 5d | 65d → 118d | A3530 → A3510 |
| A3530 | JUNTA WATER STOP SIN BULBO 150 mm | 2023-08-27 → 2023-07-01 (-57d) | 2023-08-30 → 2023-07-05 (-56d) | 4d → 5d | 65d → 137d | A3510 → A3490 SS |
| 3 | **ESTRUCTURAS METALICAS** | 2023-09-07 → 2023-07-18 (-51d) | 2023-09-11 → 2023-07-24 (-49d) |  |  |  |
| A3540 | COMPUERTA METALICA PLANA DESLIZANTE DE 1.0x1.6 m | 2023-09-07 → 2023-07-18 (-51d) | 2023-09-09 → 2023-07-21 (-50d) | 3d → 4d | 65d → 118d | A3470 → A3490 FS+12d |
| A3550 | BARANDA DE FIERRO GALVANIZADO 1 1/2" | 2023-09-10 → 2023-07-22 (-50d) | 2023-09-11 → 2023-07-24 (-49d) | 2d → 3d | 65d → 118d |  |
| 4 | **REPOSICIÓN DE CANALES** | 2023-05-01 → 2023-06-18 (+48d) | 2023-11-03 → 2023-11-16 (+13d) |  |  |  |
| 1 | **REPOSICIÓN DE CANAL 1** | 2023-07-28 → 2023-08-12 (+15d) | 2023-11-03 → 2023-11-16 (+13d) |  |  |  |
| 1 | **MOVIMIENTO DE TIERRAS** | 2023-07-28 → 2023-08-12 (+15d) | 2023-11-03 → 2023-11-16 (+13d) |  |  |  |
| A3560 | DEMOLICIÓN DE ESTRUCTURAS EXISTENTES | 2023-07-28 → 2023-08-12 (+15d) | 2023-08-02 → 2023-08-28 (+26d) | 6d → 17d | 12d → 83d | A2160 → A1530 |
| A3580 | RELLENO ESTRUCTURAL PARA OBRAS DE ARTE CON MATERIAL PROPIO | 2023-10-26 → 2023-10-09 (-17d) | 2023-11-03 → 2023-11-16 (+13d) | 9d → 39d | 12d → 3d | A3620 FS-3d → A3620 SS+20d, A3670 |
| 2 | **OBRAS DE CONCRETO** | 2023-08-10 → 2023-08-26 (+16d) | 2023-10-31 → 2023-11-14 (+14d) |  |  |  |
| A3610 | CONCRETO f'c=100 kg/cm2 | 2023-08-10 → 2023-08-26 (+16d) | 2023-08-16 → 2023-09-30 (+45d) | 7d → 36d | 12d → 3d | A1530 → A3570 SS+7d |
| A3600 | ACERO DE REFUERZO fy=4200 kg/cm2 | 2023-08-17 → 2023-08-29 (+12d) | 2023-09-10 → 2023-11-06 (+57d) | 25d → 70d | 12d → 3d | A3610 → A3610 SS+3d |
| A3590 | ENCOFRADO Y DESENCOFRADO RECTO | 2023-08-25 → 2023-09-05 (+11d) | 2023-10-10 → 2023-11-06 (+27d) | 47d → 63d | 12d → 3d | A3600 SS+8d → A3600 SS+7d |
| A3620 | CONCRETO f'c=280 kg/cm2 | 2023-10-19 → 2023-09-19 (-30d) | 2023-10-28 → 2023-11-11 (+14d) | 10d → 54d | 12d → 3d | A3630 → A3590 SS+14d |
| A3630 | JUNTA WATER STOP 6" | 2023-10-11 → 2023-09-19 (-22d) | 2023-10-18 → 2023-11-11 (+24d) | 8d → 54d | 12d → 8d | A3590 → A3620 SS |
| A3640 | MAMPOSTERIA DE PIEDRA, e=20cm, ACABADO CARA VISTA | 2023-10-29 → 2023-11-12 (+14d) | 2023-10-31 → 2023-11-14 (+14d) |  | 15d → 5d |  |
| 2 | **REPOSICIÓN DE CANAL 3** | 2023-05-01 → 2023-06-18 (+48d) | 2023-06-26 → 2023-08-14 (+49d) |  |  |  |
| 1 | **MOVIMIENTO DE TIERRAS** | 2023-05-01 → 2023-06-18 (+48d) | 2023-06-16 → 2023-08-14 (+59d) |  |  |  |

| ID | Task | Start | Finish | Duration | Total float | Predecessors | Other |
| --- | --- | --- | --- | --- | --- | --- | --- |
| A3650 | DEMOLICIÓN DE ESTRUCTURAS EXISTENTES | 2023-05-01 → 2023-06-18 (+48d) | 2023-05-07 → 2023-06-27 (+51d) | 7d → 10d | 142d → 69d | none → A1260 |  |
| A3670 | RELLENO ESTRUCTURAL PARA OBRAS DE ARTE CON MATERIAL PROPIO | 2023-06-14 → 2023-08-12 (+59d) | 2023-06-16 → 2023-08-14 (+59d) |  | 152d → 58d | A3720 → A3720 FS+6d |  |
| 2 | **OBRAS DE CONCRETO** | 2023-05-11 → 2023-07-13 (+63d) | 2023-06-26 → 2023-08-08 (+43d) |  |  |  |  |
| A3710 | CONCRETO f'c=100 kg/cm2 | 2023-05-11 → 2023-07-13 (+63d) | 2023-05-14 → 2023-07-16 (+63d) |  | 142d → 58d | A1620 → A3660 |  |
| A3700 | MALLA ELECTROSOLDADA DE DN6mm EN CUADRICULA 15x15 cm | 2023-05-15 → 2023-07-17 (+63d) | 2023-05-23 → 2023-07-31 (+69d) | 9d → 15d | 142d → 58d |  |  |
| A3680 | ENCOFRADO Y DESENCOFRADO PARA REVESTIMIENTO DE CANALES (CERCHAS) | 2023-05-23 → 2023-07-20 (+58d) | 2023-05-26 → 2023-07-31 (+66d) | 4d → 12d | 142d → 58d | A3700 FS-1d → A3700 SS+3d |  |
| A3690 | ENCOFRADO Y DESENCOFRADO RECTO | 2023-05-27 → 2023-07-20 (+54d) | 2023-06-08 → 2023-07-31 (+53d) | 13d → 12d | 142d → 58d | A3680 → A3680 SS |  |
| A3730 | SELLO DE JUNTA CONSTRUCCIÓN CON MATERIAL ELASTOMÉRICO | 2023-06-14 → 2023-07-20 (+36d) | 2023-06-26 → 2023-07-29 (+33d) | 13d → 10d | 142d → 113d | A3720 → A3680 SS |  |
| A3720 | CONCRETO f'c=280 kg/cm2 | 2023-06-09 → 2023-08-01 (+53d) | 2023-06-13 → 2023-08-05 (+53d) |  | 142d → 58d |  |  |
| A3740 | MAMPOSTERIA DE PIEDRA, e=20cm, ACABADO CARA VISTA | 2023-06-14 → 2023-08-06 (+53d) | 2023-06-16 → 2023-08-08 (+53d) |  | 152d → 103d |  |  |
| 5 | **REPOSICIÓN SIFON INOPERATIVO** | 2023-05-01 → 2023-07-04 (+64d) | 2023-06-12 → 2023-08-12 (+61d) |  |  |  |  |
| A3750 | DEMOLICIÓN DE ESTRUCTURAS EXISTENTES | 2023-05-01 → 2023-07-04 (+64d) | 2023-05-03 → 2023-07-06 (+64d) |  | 105d → 99d | none → A1230, A1880 |  |
| A3760 | EXCAVACIÓN ESTRUCTURAL PARA OBRAS DE ARTE | 2023-05-04 → 2023-07-07 (+64d) | 2023-05-10 → 2023-07-16 (+67d) | 7d → 10d | 105d → 99d |  |  |
| A3770 | COLOCACIÓN CAMA DE ARENA | 2023-05-11 → 2023-07-17 (+67d) | 2023-05-14 → 2023-07-19 (+66d) | 4d → 3d | 105d → 108d |  |  |
| A3810 | CONCRETO f'c=100 kg/cm2 | 2023-06-01 → 2023-07-17 (+46d) | 2023-06-03 → 2023-07-19 (+46d) |  | 156d → 99d | A3780 → A3760 |  |
| A3800 | TUBERÍAS DE 14" HDPE SDR21 DN 355mm | 2023-05-15 → 2023-07-20 (+66d) | 2023-05-21 → 2023-07-25 (+65d) | 7d → 6d | 105d → 108d |  |  |
| A3840 | ACERO DE REFUERZO fy=4200 kg/cm2 | 2023-06-04 → 2023-07-20 (+46d) | 2023-06-06 → 2023-07-22 (+46d) |  | 156d → 99d |  |  |
| A3850 | CODOS HDPE DE 14" DN 355mm | 2023-05-15 → 2023-07-20 (+66d) | 2023-05-21 → 2023-07-25 (+65d) | 7d → 6d | 105d → 117d |  |  |
| A3830 | ENCOFRADO Y DESENCOFRADO RECTO | 2023-06-07 → 2023-07-23 (+46d) | 2023-06-09 → 2023-07-25 (+46d) |  | 156d → 99d |  |  |
| A3790 | RELLENO COMÚN | 2023-05-22 → 2023-07-26 (+65d) | 2023-05-28 → 2023-08-03 (+67d) | 7d → 9d | 105d → 108d | A3800, A3850 → A3800 |  |
| A3820 | CONCRETO f'c=280 kg/cm2 | 2023-06-10 → 2023-07-26 (+46d) | 2023-06-12 → 2023-07-28 (+46d) |  | 156d → 99d |  |  |
| A3780 | RELLENO ESTRUCTURAL PARA OBRAS DE ARTE CON MATERIAL PROPIO | 2023-05-29 → 2023-08-10 (+73d) | 2023-05-31 → 2023-08-12 (+73d) |  | 105d → 99d | A3790 → A3820 FS+12d |  |
| 3 | **ARQUITECTURA Y PAISAJISMO** | 2023-07-28 → 2023-08-22 (+25d) | 2023-09-21 → 2023-11-03 (+43d) |  |  |  |  |
| 1 | **OBRAS PRELIMINARES** | 2023-07-28 → 2023-08-22 (+25d) | 2023-08-05 → 2023-11-03 (+90d) |  |  |  |  |
| A3870 | TRAZO Y REPLANTEO PRELIMINAR | 2023-08-01 → 2023-08-24 (+23d) | 2023-08-05 → 2023-08-25 (+20d) | 5d → 2d | 48d → 16d | MOVILIZACIÓN Y DEMOVILIZACIÓN DE EQUIPOS Y HERRAMIENTAS (ARQUITECTURA Y PAISAJISMO) → A3860 |  |
| 2 | **MOVIMIENTO DE TIERRAS** | 2023-08-06 → 2023-08-26 (+20d) | 2023-08-17 → 2023-09-11 (+25d) |  |  |  |  |
| A3880 | EXCAVACIÓN MANUAL PARA INSTALACIÓN DE BORDILLOS Y CIMENTACIONES | 2023-08-06 → 2023-08-26 (+20d) | 2023-08-08 → 2023-08-27 (+19d) | 3d → 2d | 48d → 16d |  |  |
| A3900 | ELIMINACION DE MATERIAL EXCEDENTE (DME´S) | 2023-08-13 → 2023-08-26 (+13d) | 2023-08-17 → 2023-09-11 (+25d) | 5d → 17d | 90d → 67d | A3890 → A3880 SS |  |
| A3890 | EXCAVACIÓN PARA MEJORAMIENTO DE SUELO CON TIERRA VEGETAL | 2023-08-07 → 2023-08-28 (+21d) | 2023-08-12 → 2023-09-11 (+30d) | 6d → 15d | 48d → 16d | A3880 SS+1d → A3880 |  |
| 3 | **PAVIMENTOS, RECUBRIMIENTOS Y BORDILLOS** | 2023-08-13 → 2023-09-12 (+30d) | 2023-08-30 → 2023-09-22 (+23d) |  |  |  |  |
| A3910 | PISO DE GRAVILLA | 2023-08-13 → 2023-09-12 (+30d) | 2023-08-15 → 2023-09-13 (+29d) | 3d → 2d | 48d → 16d |  |  |
| A3920 | RECUBRIMIENTO DE PIEDRA DEL LUGAR e=0.05cm | 2023-08-16 → 2023-09-14 (+29d) | 2023-08-25 → 2023-09-17 (+23d) | 10d → 4d | 48d → 16d |  |  |
| A3930 | BORDILLOS DE PIEDRA DEL LUGAR | 2023-08-26 → 2023-09-18 (+23d) | 2023-08-30 → 2023-09-22 (+23d) |  | 48d → 16d |  |  |
| 4 | **MOBILIARIOS, BARANDAS Y ESCALERAS** | 2023-08-31 → 2023-09-23 (+23d) | 2023-09-21 → 2023-10-30 (+39d) |  |  |  |  |
| A3940 | ESCALERA DE CONCRETO SOBRE ENROCADO, CIMENTACION Y ANCLAJE | 2023-08-31 → 2023-09-23 (+23d) | 2023-09-03 → 2023-10-02 (+29d) | 4d → 10d | 48d → 16d |  |  |
| A3950 | BARANDA DE MADERA EUCALIPTO CON SOGA, INCLUYE CIMENTACIÓN | 2023-09-04 → 2023-10-03 (+29d) | 2023-09-06 → 2023-10-06 (+30d) | 3d → 4d | 48d → 16d |  |  |
| A3960 | TACHOS DE BASURA, INCLUYE CIMENTACIÓN | 2023-09-16 → 2023-10-07 (+21d) | 2023-09-18 → 2023-10-09 (+21d) |  | 55d → 16d | A3970 → A3950 |  |
| A3970 | BANCAS DE CONCRETO, INCLUYE CIMENTACIÓN | 2023-09-13 → 2023-10-10 (+27d) | 2023-09-15 → 2023-10-19 (+34d) | 3d → 10d | 55d → 16d | A3980 → A3960 |  |
| A3980 | POSTES DE ILUMINACIÓN, INCLUYE LUMINARIA Y CIMENTACIÓN | 2023-09-10 → 2023-10-20 (+40d) | 2023-09-12 → 2023-10-24 (+42d) | 3d → 5d | 55d → 16d | A4000 → A3970 |  |
| A3990 | SEÑALETICA INFORMATIVA | 2023-09-19 → 2023-10-25 (+36d) | 2023-09-21 → 2023-10-27 (+36d) |  | 55d → 16d | A3960 → A3980 |  |
| A4000 | BOLARDOS DE PIEDRA | 2023-09-07 → 2023-10-28 (+51d) | 2023-09-09 → 2023-10-30 (+51d) |  | 55d → 16d | A3950 → A3990 |  |
| 5 | **INSTALACIÓN DE ALCORQUES** | 2023-08-31 → 2023-10-31 (+61d) | 2023-09-02 → 2023-11-01 (+60d) |  |  |  |  |
| A4010 | ALCORQUES DE PIEDRA DE CANTO RODADO PARA ARBOLES | 2023-08-31 → 2023-10-31 (+61d) | 2023-09-02 → 2023-11-01 (+60d) | 3d → 2d | 74d → 16d | A3930 → A4000 |  |
| 4 | **PROGRAMA DE CIERRE DE OBRA** | 2023-05-09 → 2023-06-02 (+24d) | 2023-09-28 → 2023-11-16 (+49d) |  |  |  |  |
| A1770 | ACONDICIONAMIENTO DE DEPOSITOS DE MATERIALES EXCEDENTES (DME) | 2023-05-09 → 2023-06-02 (+24d) | 2023-09-27 → 2023-11-08 (+42d) | 142d → 160d | 49d → 3d | TRANSPORTE DE MATERIAL EXCEDENTE PARA DISTANCIAS <1KM SS+3d, TRANSPORTE DE MATERIAL EXCEDENTE PARA DISTANCIAS >1KM SS+3d → A1220 SS | resources Tractor D6 [1579 h]; Operador Tractor [1579 h] → none |
| A1780 | RESTAURACIÓN DE ÁREAS DE INSTALACIONES PROVISIONALES | 2023-09-14 → 2023-11-09 (+56d) | 2023-09-28 → 2023-11-16 (+49d) | 15d → 8d | 48d → 3d | A3950 FS+7d → A2480, A1770 |  |

## Version 3 (data date 2023-09-25, saved 2023-10-05, file NATIVO A3-LACRAMARCA.xer)

Last finish 2023-11-21 → 2024-05-04 (+165d).

Added:

| ID | Task | Duration | Start | Finish | Predecessors | Constraint | Resources |
| --- | --- | --- | --- | --- | --- | --- | --- |
| 2 | **CONSTRUCCIÓN SUB PROYECTO A3 - RÍO LACRAMARCA** |  | 2023-10-18 | 2024-05-04 |  |  |  |
| 01.02.01 | MOVILIZACION Y DESMOVILIZACION DE EQUIPOS | 13.33d | 2023-10-18 | 2023-11-03 |  | start on or after 2023-10-19 | Camión baranda 3 TON [2 h]; Camión Cisterna 4x2 400 HP Agua (5000 gal) [3 h]; Camión grua [1 h]; Camión Plataforma 4x2 122 HP [1 h]; Camión Volquete (15 m3) [30 h]; Cargador Frontal 195 HP [2 h]; CARGADOR SOBRE LLANTAS DE 200-250 HP [2 h]; Excavadora Sobre Oruga 260 HP [10 h]; Motoniveladora 185 HP [4 h]; Retroexcavador 58 HP [3 h]; Rodillo Vib. Liso Autopropulsado 135 HP 12 TM [4 h]; Tractor S/Orugas (D6T) - 180 HP [5 h] |
| 4 | **DESCOLMATACIÓN DE CAUCE y OBRAS AUXILIARES** |  | 2023-10-30 | 2024-02-26 |  |  |  |
| 1.04.02 | DESCOLMATACIÓN DE CAUCE NATURAL DEL RÍO LACRAMARCA | 73.67d | 2023-11-02 | 2024-02-05 | 1.04.01 SS+2d |  | CAPATAZ [58.09 h]; CUADRADOR/VIGÍA [615.8 h]; Excavadora Sobre Oruga 260 HP [615.8 h]; PEON [1243.21 h]; Tractor S/Orugas (D6T) - 180 HP [615.8 h] |
| 1.04.03 | CONFORMACIÓN DE DESVIO EN CAUCE DE RÍO | 55d | 2023-11-02 | 2024-01-12 | 1.04.02 SS |  | CAPATAZ [457.34 h]; CUADRADOR/VIGÍA [457.34 h]; Excavadora Sobre Oruga 260 HP [228.67 h]; OPERARIO [457.34 h]; PEON [914.67 h]; Tractor S/Orugas (D6T) - 180 HP [457.34 h] |
| 1.04.04 | RELLENO NO ESTRUCTURAL CON MATERIAL PROPIO | 90.67d | 2023-11-02 | 2024-02-26 | 1.04.03 SS |  | Camión Cisterna 4x2 400 HP Agua (5000 gal) [154.92 h]; CAPATAZ [74.59 h]; CUADRADOR/VIGÍA [763.11 h]; Motoniveladora 185 HP [154.92 h]; OPERARIO [763.11 h]; PEON [3058.19 h]; Rodillo Vib. Liso Autopropulsado 135 HP 12 TM [154.92 h]; Tractor S/Orugas (D6T) - 180 HP [763.11 h] |
| 04.01.01 | MOVILIZACIÓN Y DEMOVILIZACIÓN DE EQUIPOS Y HERRAMIENTAS (ARQUITECTURA Y PAISAJISMO) | 1d | 2024-02-20 | 2024-02-20 | 2.05.04 FS+3.67d |  |  |
| 5 | **OBRAS PRELIMINARES PAISAJISMO** |  | 2024-04-11 | 2024-04-16 |  |  |  |
| 04.05.01 | MEJORAMIENTO DE SUELO CON TIERRA DE CHACRA | 1d | 2024-04-11 | 2024-04-11 | 04.04.07 |  | OFICIAL [0.69 h]; PEON [5.5 h] |
| 04.05.02 | UBICACIÓN Y DELIMITACIÓN DE ZONA DE PLANTACIÓN | 1d | 2024-04-12 | 2024-04-12 | 04.05.01 |  | OFICIAL [2.04 h]; PEON [6.13 h] |
| 04.05.03 | DESPEDREGADO DEL TERRENO CON MEDIOS MANUALES | 0.67d | 2024-04-13 | 2024-04-13 | 04.05.02 |  | CAPATAZ [0.14 h]; PEON [5.5 h] |
| 04.05.04 | RASTRILLADO DEL TERRENO | 0.67d | 2024-04-13 | 2024-04-13 | 04.05.03 SS |  | CAPATAZ [0.11 h]; PEON [4.4 h] |
| 04.05.05 | TRAZADO, MARCACIÓN Y ESTACADO | 1d | 2024-04-15 | 2024-04-15 | 04.05.04 |  | PEON [0.55 h]; TOPOGRAFO [0.28 h] |
| 04.05.06 | RETIRO DE DESMONTE Y RESIDUOS SOLIDOS | 1d | 2024-04-16 | 2024-04-16 | 04.05.05 |  | CAPATAZ [0.05 h]; PEON [0.92 h] |
| 6 | **INSTALACION DE PLANTONES (Incluye colocación de sustrato, tierra del lugar, tutores y excavación)** |  | 2024-04-17 | 2024-04-18 |  |  |  |
| 04.10.01 | INST. PROSOPIS PALLIDA KUNTH ALGARROBO (0.80 a 1.50m) | 1d | 2024-04-17 | 2024-04-17 | 04.05.06 |  | OFICIAL [0 h]; PEON [0.08 h] |
| 04.10.02 | INST. ACACIA MACRACANTHA FAIQUE (0.80 a 1.50m) | 1d | 2024-04-17 | 2024-04-17 | 04.10.01 SS |  | OFICIAL [0.01 h]; PEON [0.24 h] |
| 04.10.03 | INST. PARKINSONIA ACULEATA AZOTE DE CRISTO (1.00 a 1.50 m) | 1d | 2024-04-17 | 2024-04-17 | 04.10.02 SS |  | OFICIAL [0.01 h]; PEON [0.24 h] |
| 04.10.04 | INST. SENNA MULTIGLANDULOSA MUTUY (0.60 a 0.80m) | 1d | 2024-04-17 | 2024-04-17 | 04.10.03 SS |  | OFICIAL [0.56 h]; PEON [11.12 h] |
| 04.10.05 | INST. ENCELIA CANESCEN GIRASOL SILVESTRE (0.20m a 0.30m) | 2d | 2024-04-17 | 2024-04-18 | 04.10.04 SS |  | OFICIAL [0.82 h]; PEON [16.48 h] |
| 7 | **INTALACIÓN DE ALCORQUES** |  | 2024-04-19 | 2024-04-19 |  |  |  |
| 5.022 | DESMOVILIZACIÓN | 0.67d | 2024-05-04 | 2024-05-04 | 5.012, 1.06.02.05, 04.04.06 FF, 04.11.01, 1.01.03, 1.03.02.05, 1.03.03.01, 1.04.04, 1.05.01.05, 1.06.03, 1.06.03.05, 1.06.04.05, 1.06.05.05, 2.01.01.02, 2.01.03.05, 2.01.06.08 |  |  |

Removed: HITOS; A1000 KICK OFF MEETING; A1010 INICIO DEL SERVICIO; A1015 INICIO DE EXCAVACIÓN; A1016 INICIO DE RELLENO DE DIQUE; A1020 FIN DEL SERVICIO; A1030 CARTEL DE IDENTIFICACIÓN OBRA 4.80 x 3.60 m.; A1060 MOVILIZACION DE EQUIPOS; A1070 TOPOGRAFÍA Y GEOREFERENCIACIÓN; A1080 DESMOVILIZACION DE EQUIPOS; A1100 MEJORAMIENTO DE VIAS EXISTENTES; DESCOLMATACIÓN DE CAUCE Y OBRAS AUXILIARES; DESBROCE Y DESCOLMATACIÓN; A1230 DESCOLMATACIÓN DE CAUCE NATURAL DEL RÍO LACRAMARCA - DIQUE A3-D-01; A1880 DESCOLMATACIÓN DE CAUCE NATURAL DEL RÍO LACRAMARCA - DIQUE A3-I-01; A1870 DESCOLMATACIÓN DE CAUCE NATURAL DEL RÍO LACRAMARCA - DIQUE A3-D-02; A1890 DESCOLMATACIÓN DE CAUCE NATURAL DEL RÍO LACRAMARCA - DIQUE A3-I-02; A1900 DESCOLMATACIÓN DE CAUCE NATURAL DEL RÍO LACRAMARCA - DIQUE A3-I-03; DESVIO DEL CAUCE; A3-D-01; A1240 CONFORMACIÓN DE DESVIO EN CAUCE DE RÍO - DIQUE A3-D-01; A1250 RELLENO NO ESTRUCTURAL CON MATERIAL PROPIO - DIQUE A3-D-01; A3-D-02; A1790 CONFORMACIÓN DE DESVIO EN CAUCE DE RÍO - DIQUE A3-D-02 - TRAMO 1; A1800 RELLENO NO ESTRUCTURAL CON MATERIAL PROPIO - DIQUE A3-D-02 - TRAMO 1; A2630 CONFORMACIÓN DE DESVIO EN CAUCE DE RÍO - DIQUE A3-D-02 - TRAMO 2; A2640 RELLENO NO ESTRUCTURAL CON MATERIAL PROPIO - DIQUE A3-D-02 - TRAMO 2; A2650 CONFORMACIÓN DE DESVIO EN CAUCE DE RÍO - DIQUE A3-D-02 - TRAMO 3; A2660 RELLENO NO ESTRUCTURAL CON MATERIAL PROPIO - DIQUE A3-D-02 - TRAMO 3; A2670 CONFORMACIÓN DE DESVIO EN CAUCE DE RÍO - DIQUE A3-D-02 - TRAMO 4; A2680 RELLENO NO ESTRUCTURAL CON MATERIAL PROPIO - DIQUE A3-D-02 - TRAMO 4; A2690 CONFORMACIÓN DE DESVIO EN CAUCE DE RÍO - DIQUE A3-D-02 - TRAMO 5; A2700 RELLENO NO ESTRUCTURAL CON MATERIAL PROPIO - DIQUE A3-D-02 - TRAMO 5; A3-I-01; A1810 CONFORMACIÓN DE DESVIO EN CAUCE DE RÍO - DIQUE A3-I-01; A1820 RELLENO NO ESTRUCTURAL CON MATERIAL PROPIO - DIQUE A3-I-01; A3-I-02; A1830 CONFORMACIÓN DE DESVIO EN CAUCE DE RÍO - DIQUE A3-I-02; A1840 RELLENO NO ESTRUCTURAL CON MATERIAL PROPIO - DIQUE A3-I-02; A3-I-03; A1850 CONFORMACIÓN DE DESVIO EN CAUCE DE RÍO - DIQUE A3-I-03 - TRAMO 1; A2710 CONFORMACIÓN DE DESVIO EN CAUCE DE RÍO - DIQUE A3-I-03 - TRAMO 2; A1860 RELLENO NO ESTRUCTURAL CON MATERIAL PROPIO - DIQUE A3-I-03 -TRAMO 1; A2730 CONFORMACIÓN DE DESVIO EN CAUCE DE RÍO - DIQUE A3-I-03 - TRAMO 3; A2720 RELLENO NO ESTRUCTURAL CON MATERIAL PROPIO - DIQUE A3-I-03 -TRAMO 2; A2750 CONFORMACIÓN DE DESVIO EN CAUCE DE RÍO - DIQUE A3-I-03 - TRAMO 4; A2740 RELLENO NO ESTRUCTURAL CON MATERIAL PROPIO - DIQUE A3-I-03 -TRAMO 3; A2760 RELLENO NO ESTRUCTURAL CON MATERIAL PROPIO - DIQUE A3-I-03 -TRAMO 4; TRAMO 1; TRAMO 2; TRAMO 3; TRAMO 4; TRAMO 5; A2190 EXCAVACIÓN DE UÑA CON EQUIPO; A2200 PERFILADO Y COMPACTACIÓN EN ZONA DE CORTE; A2230 GEOTEXTIL NO TEJIDO 400 G/M2, INC. COLOCACIÓN; A2240 COLOCACION Y ACOMODO DE ROCA EN UÑA DE DIQUE; A2250 COLOCACION Y ACOMODO DE ROCA EN TALUD DE DIQUE; A2260 PREPARACIÓN DE FUNDACIÓN DE CUERPO DE DIQUE; A2210 CONFORMACIÓN DE CUERPO DE DIQUE CON MATERIAL PROPIO; A2220 CONFORMACIÓN DE CORONA DE DIQUE CON MATERIAL PROPIO; Sector liberado; A1450 EXCAVACIÓN DE UÑA CON EQUIPO; A1460 PERFILADO Y COMPACTACIÓN EN ZONA DE CORTE; A1520 PREPARACIÓN DE FUNDACIÓN DE CUERPO DE DIQUE; A1470 CONFORMACIÓN DE CUERPO DE DIQUE CON MATERIAL PROPIO; A1490 GEOTEXTIL NO TEJIDO 400 G/M2, INC. COLOCACIÓN; A1500 COLOCACION Y ACOMODO DE ROCA EN UÑA DE DIQUE; A1510 COLOCACION Y ACOMODO DE ROCA EN TALUD DE DIQUE; A1480 CONFORMACIÓN DE CORONA DE DIQUE CON MATERIAL PROPIO; Sector por Liberar - Km 20+980 - km 21+300; A4040 EXCAVACIÓN DE UÑA CON EQUIPO; A4050 PERFILADO Y COMPACTACIÓN EN ZONA DE CORTE; A4110 PREPARACIÓN DE FUNDACIÓN DE CUERPO DE DIQUE; A4060 CONFORMACIÓN DE CUERPO DE DIQUE CON MATERIAL PROPIO; A4080 GEOTEXTIL NO TEJIDO 400 G/M2, INC. COLOCACIÓN; A4090 COLOCACION Y ACOMODO DE ROCA EN UÑA DE DIQUE; A4100 COLOCACION Y ACOMODO DE ROCA EN TALUD DE DIQUE; A4070 CONFORMACIÓN DE CORONA DE DIQUE CON MATERIAL PROPIO; A1530 EXCAVACIÓN EN TERRENO NATURAL CON EQUIPO; A1540 EXCAVACIÓN DE UÑA CON EQUIPO; A1550 PERFILADO Y COMPACTACIÓN EN ZONA DE CORTE; A1580 GEOTEXTIL NO TEJIDO 400 G/M2, INC. COLOCACIÓN; A1590 COLOCACION Y ACOMODO DE ROCA EN UÑA DE DIQUE; A1610 PREPARACIÓN DE FUNDACIÓN DE CUERPO DE DIQUE; A1560 CONFORMACIÓN DE CUERPO DE DIQUE CON MATERIAL PROPIO; A1600 COLOCACION Y ACOMODO DE ROCA EN TALUD DE DIQUE; A1570 CONFORMACIÓN DE CORONA DE DIQUE CON MATERIAL PROPIO; TRAMO 1; A1620 EXCAVACIÓN EN TERRENO NATURAL CON EQUIPO; A1630 EXCAVACIÓN DE UÑA CON EQUIPO; A1640 PERFILADO Y COMPACTACIÓN EN ZONA DE CORTE; A1670 GEOTEXTIL NO TEJIDO 400 G/M2, INC. COLOCACIÓN; A1680 COLOCACION Y ACOMODO DE ROCA EN UÑA DE DIQUE; A1690 COLOCACION Y ACOMODO DE ROCA EN TALUD DE DIQUE; A1700 PREPARACIÓN DE FUNDACIÓN DE CUERPO DE DIQUE; A1650 CONFORMACIÓN DE CUERPO DE DIQUE CON MATERIAL PROPIO; A1660 CONFORMACIÓN DE CORONA DE DIQUE CON MATERIAL PROPIO; TRAMO 2; Sector liberado; A2270 EXCAVACIÓN EN TERRENO NATURAL CON EQUIPO; A2280 EXCAVACIÓN DE UÑA CON EQUIPO; A2290 PERFILADO Y COMPACTACIÓN EN ZONA DE CORTE; A2320 GEOTEXTIL NO TEJIDO 400 G/M2, INC. COLOCACIÓN; A2330 COLOCACION Y ACOMODO DE ROCA EN UÑA DE DIQUE; A2350 PREPARACIÓN DE FUNDACIÓN DE CUERPO DE DIQUE; A2300 CONFORMACIÓN DE CUERPO DE DIQUE CON MATERIAL PROPIO; A2340 COLOCACION Y ACOMODO DE ROCA EN TALUD DE DIQUE; A2310 CONFORMACIÓN DE CORONA DE DIQUE CON MATERIAL PROPIO; Sector por Liberar - Km 23+760 - km 24+100; A4120 EXCAVACIÓN EN TERRENO NATURAL CON EQUIPO; A4130 EXCAVACIÓN DE UÑA CON EQUIPO; A4140 PERFILADO Y COMPACTACIÓN EN ZONA DE CORTE; A4200 PREPARACIÓN DE FUNDACIÓN DE CUERPO DE DIQUE; A4150 CONFORMACIÓN DE CUERPO DE DIQUE CON MATERIAL PROPIO; A4170 GEOTEXTIL NO TEJIDO 400 G/M2, INC. COLOCACIÓN; A4180 COLOCACION Y ACOMODO DE ROCA EN UÑA DE DIQUE; A4190 COLOCACION Y ACOMODO DE ROCA EN TALUD DE DIQUE; A4160 CONFORMACIÓN DE CORONA DE DIQUE CON MATERIAL PROPIO; TRAMO 3; A2360 EXCAVACIÓN EN TERRENO NATURAL CON EQUIPO; A2370 EXCAVACIÓN DE UÑA CON EQUIPO; A2380 PERFILADO Y COMPACTACIÓN EN ZONA DE CORTE; A2410 GEOTEXTIL NO TEJIDO 400 G/M2, INC. COLOCACIÓN; A2420 COLOCACION Y ACOMODO DE ROCA EN UÑA DE DIQUE; A2430 COLOCACION Y ACOMODO DE ROCA EN TALUD DE DIQUE; A2440 PREPARACIÓN DE FUNDACIÓN DE CUERPO DE DIQUE; A2390 CONFORMACIÓN DE CUERPO DE DIQUE CON MATERIAL PROPIO; A2400 CONFORMACIÓN DE CORONA DE DIQUE CON MATERIAL PROPIO; TRAMO 4; A2450 EXCAVACIÓN EN TERRENO NATURAL CON EQUIPO; A2460 EXCAVACIÓN DE UÑA CON EQUIPO; A2470 PERFILADO Y COMPACTACIÓN EN ZONA DE CORTE; A2500 GEOTEXTIL NO TEJIDO 400 G/M2, INC. COLOCACIÓN; A2510 COLOCACION Y ACOMODO DE ROCA EN UÑA DE DIQUE; A2520 COLOCACION Y ACOMODO DE ROCA EN TALUD DE DIQUE; A2530 PREPARACIÓN DE FUNDACIÓN DE CUERPO DE DIQUE; A2480 CONFORMACIÓN DE CUERPO DE DIQUE CON MATERIAL PROPIO; A2490 CONFORMACIÓN DE CORONA DE DIQUE CON MATERIAL PROPIO; A3-RA-D-01; A1710 EXCAVACIÓN EN TERRENO NATURAL CON EQUIPO; A3-RA-I-01; A1740 EXCAVACIÓN EN TERRENO NATURAL CON EQUIPO; A1750 CONFORMACIÓN DE CUERPO DE RAMPA CON MATERIAL PROPIO; A1760 CONFORMACIÓN DE CORONACIÓN DE RAMPA; A3570 EXCAVACIÓN EN TERRENO NATURAL CON EQUIPO; A3660 EXCAVACIÓN EN TERRENO NATURAL CON EQUIPO; A3860 MOVILIZACIÓN DE EQUIPOS Y HERRAMIENTAS (ARQUITECTURA Y PAISAJISMO); A4020 DEMOVILIZACIÓN DE EQUIPOS Y HERRAMIENTAS (ARQUITECTURA Y PAISAJISMO); INSTALACIÓN DE ALCORQUES; A1770 ACONDICIONAMIENTO DE DEPOSITOS DE MATERIALES EXCEDENTES (DME)

Changed:

| ID | Task | Start | Finish | Duration | Total float | Predecessors | Other |
| --- | --- | --- | --- | --- | --- | --- | --- |
| 1 | **DEFENSAS RIBEREÑAS** | 2023-05-26 → 2023-10-18 (+145d) | 2023-11-21 → 2024-05-03 (+164d) |  |  |  |  |
| 1 | **OBRAS PRELIMINARES** | 2023-05-28 → 2023-10-23 (+148d) | 2023-11-17 → 2023-11-04 (-13d) |  |  |  |  |
| 1.01.02 | INSTALACIONES PROVISIONALES PARA LA OBRA | 2023-06-01 → 2023-10-23 (+144d) | 2023-11-16 → 2023-11-04 (-12d) | 169d → 10d | 0d → 136.22d | MEJORAMIENTO DE VIAS EXISTENTES SS+1d, CARTEL DE IDENTIFICACIÓN OBRA 4.80 x 3.60 m. → none | resources none → Camión grua [64 h]; CAPATAZ [80 h]; OPERARIO [480 h]; PEON [640 h] |
| 1.01.03 | MANTENIMIENTO DE TRÁNSITO Y SEGURIDAD VIAL | 2023-06-17 → 2023-10-23 (+128d) | 2023-11-17 → 2023-11-04 (-13d) | 154d → 10d | 2d → 140.22d | MEJORAMIENTO DE VIAS EXISTENTES → 1.01.02 SS | resources none → Camión Cisterna 4x2 400 HP Agua (5000 gal) [1659.4 h]; Camión Volquete (15 m3) [737.6 h]; CAPATAZ [1860.16 h]; CUADRADOR/VIGÍA [3720.32 h]; Excavadora Sobre Oruga 260 HP [368.8 h]; Motoniveladora 185 HP [1075.5 h]; OFICIAL [368.8 h]; OPERARIO [368.8 h]; PEON [3720.32 h]; Retroexcavador 58 HP [717 h]; Rodillo Vib. Liso Autopropulsado 135 HP 12 TM [1075.5 h]; Tractor S/Orugas (D6T) - 180 HP [368.8 h] |
| 2 | **TRABAJOS PRELIMINARES** | 2023-05-26 → 2023-10-18 (+145d) | 2023-11-21 → 2023-11-03 (-18d) |  |  |  |  |
| 3 | **MEJORAMIENTO DE VÍAS EXISTENTES** | 2023-05-31 → 2023-10-23 (+145d) | 2023-07-30 → 2023-11-09 (+102d) |  |  |  |  |
| 1 | **MOVIMIENTO DE TIERRAS** | 2023-05-31 → 2023-10-23 (+145d) | 2023-06-16 → 2023-10-28 (+134d) |  |  |  |  |
| 1.03.01.01 | ROCE Y LIMPIEZA DE MALEZA | 2023-05-31 → 2023-10-23 (+145d) | 2023-06-16 → 2023-10-28 (+134d) | 17d → 5.33d |  | INICIO DE EXCAVACIÓN → 01.02.01 SS+4d | resources none → AYUDANTE DE NIVELADOR [1428.96 h]; AYUDANTE DE TOPOGRAFO [2857.92 h]; Camión baranda 3 TON [14.93 h]; CAPATAZ [7.46 h]; CUADRADOR/VIGÍA [14.93 h]; PEON [29.86 h]; Retroexcavador 58 HP [7.46 h]; TOPOGRAFO [2857.92 h]; Tractor S/Orugas (D6T) - 180 HP [7.46 h]; OP. NIVELADOR [1428.96 h] |
| 2 | **REPOSICIÓN DE ESTRUCTURAS** | 2023-06-20 → 2023-11-06 (+139d) | 2023-07-24 → 2023-11-08 (+107d) |  |  |  |  |
| 1.03.02.01 | DEMOLICIÓN DE ESTRUCTURAS EXISTENTES | 2023-06-20 → 2023-11-06 (+139d) | 2023-06-21 → 2023-11-06 (+138d) | 2d → 1d | 112d → 136.22d | TOPOGRAFÍA Y GEOREFERENCIACIÓN SS+23d → 1.01.02 | resources none → Camión Volquete (15 m3) [7.47 h]; CAPATAZ [0.75 h]; OPERARIO [14.93 h]; PEON [14.93 h]; Retroexcavador 58 HP [7.47 h] |
| 1.03.02.02 | REPOSICIÓN DE PASE DE AGUA TUBO HDPE Ø=18" | 2023-06-23 → 2023-11-07 (+137d) | 2023-06-24 → 2023-11-07 (+136d) | 2d → 1d | 112d → 137.22d | 1.03.02.01 SS+3d → 1.03.02.01 | resources none → CAPATAZ [0.4 h]; OPERARIO [8 h]; PEON [16 h]; Retroexcavador 58 HP [4 h] |
| 1.03.02.03 | REPOSICIÓN DE PASE DE AGUA TUBO HDPE Ø=36" | 2023-06-23 → 2023-11-07 (+137d) | 2023-06-24 → 2023-11-07 (+136d) | 2d → 1d | 112d → 137.22d |  | resources none → CAPATAZ [0.5 h]; OPERARIO [10 h]; PEON [20 h]; Retroexcavador 58 HP [5 h] |
| 1.03.02.04 | SUMINISTRO Y MONTAJE DE PANELES DE C°A° 1.6mx1.0mx0.20m EN PASE DE AGUA | 2023-06-25 → 2023-11-08 (+136d) | 2023-07-24 → 2023-11-08 (+107d) | 30d → 1d | 112d → 137.22d | 1.03.02.03 SS+2d → 1.03.02.03 | resources none → CAPATAZ [0.28 h]; PEON [5.6 h] |
| 1.03.02.05 | SUMINISTRO Y MONTAJE DE PANELES DE C°A° 2.20mx1.0mx0.20m EN PASE DE AGUA | 2023-06-25 → 2023-11-08 (+136d) | 2023-07-24 → 2023-11-08 (+107d) | 30d → 1d | 112d → 137.22d |  | resources none → CAPATAZ [0.2 h]; PEON [4 h] |
| 3 | **CABEZAL DE ENTRADA Y SALIDA** | 2023-07-25 → 2023-11-07 (+105d) | 2023-07-30 → 2023-11-09 (+102d) |  |  |  |  |
| 1.03.03.02 | ENCOFRADO Y DESENCOFRADO RECTO | 2023-07-25 → 2023-11-07 (+105d) | 2023-07-27 → 2023-11-08 (+104d) | 3d → 2d | 112d → 136.22d | 1.03.02.05 → 1.03.02.01 SS+1d | resources none → CAPATAZ [7.06 h]; OPERARIO [14.12 h]; PEON [14.12 h] |
| 1.03.03.01 | CONCRETOS | 2023-07-28 → 2023-11-09 (+104d) | 2023-07-30 → 2023-11-09 (+102d) | 3d → 1d | 112d → 136.22d |  | resources none → CAPATAZ [0.32 h]; OFICIAL [1.61 h]; OPERARIO [3.22 h]; PEON [16.11 h] |
| 1.04.01 | DESBROCE Y LIMPIEZA EN ZONA NO BOSCOSA | 2023-06-02 → 2023-10-30 (+150d) | 2023-08-16 → 2023-12-16 (+122d) | 76d → 37d | 0d → 6.24d | TOPOGRAFÍA Y GEOREFERENCIACIÓN SS+4d, INICIO DE EXCAVACIÓN, 1.01.02 SS+1d → 1.03.01.01 | resources none → Camión Volquete (15 m3) [304.61 h]; CUADRADOR/VIGÍA [304.61 h]; Excavadora Sobre Oruga 260 HP [304.61 h]; OPERARIO [913.84 h]; PEON [1827.68 h]; Tractor S/Orugas (D6T) - 180 HP [152.31 h] |
| 5 | **DIQUES DE TIERRA COMPACTADA CON ENROCADO** | 2023-06-08 → 2023-10-23 (+137d) | 2023-11-19 → 2024-05-03 (+166d) |  |  |  |  |
| 1 | **DIQUE DE TIERRA COMPACTADA A3-D-01** | 2023-06-08 → 2023-10-30 (+144d) | 2023-07-11 → 2024-01-04 (+177d) |  |  |  |  |
| 1.05.01.01 | EXCAVACIÓN EN TERRENO NATURAL CON EQUIPO | 2023-06-08 → 2023-10-30 (+144d) | 2023-06-17 → 2023-10-31 (+136d) | 10d → 2d | 0d → 6.24d | CONFORMACIÓN DE DESVIO EN CAUCE DE RÍO - DIQUE A3-I-01 → 1.04.01 SS | resources none → Camión Volquete (15 m3) [2976.35 h]; CAPATAZ [270.18 h]; CARGADOR SOBRE LLANTAS DE 200-250 HP [2643.39 h]; Excavadora Sobre Oruga 260 HP [225.02 h]; PEON [57.97 h]; Tractor S/Orugas (D6T) - 180 HP [28.99 h] |
| 1.05.01.02 | EXCAVACIÓN DE UÑA CON EQUIPO | 2023-06-09 → 2023-10-30 (+143d) | 2023-06-17 → 2023-10-31 (+136d) | 9d → 2d | 91d → 94.56d | 1.05.01.01 SS+1d → 1.05.01.01 SS | resources none → CAPATAZ [26.51 h]; Excavadora Sobre Oruga 260 HP [53.24 h]; PEON [53.24 h] |
| 1.05.01.03 | PERFILADO Y COMPACTACIÓN EN ZONA DE CORTE | 2023-06-09 → 2023-11-02 (+146d) | 2023-06-28 → 2023-11-08 (+133d) | 20d → 5.67d | 0d → 94.56d | 1.05.01.01 SS+1d → 1.05.01.01, 1.05.01.02 | resources none → Camión Cisterna 4x2 400 HP Agua (5000 gal) [44.77 h]; CAPATAZ [22.38 h]; Motoniveladora 185 HP [44.77 h]; OFICIAL [44.77 h]; PEON [44.77 h]; Rodillo Vib. Liso Autopropulsado 135 HP 12 TM [44.77 h] |
| 1.05.01.09 | PREPARACIÓN DE FUNDACIÓN DE CUERPO DE DIQUE | 2023-06-09 → 2023-11-09 (+153d) | 2023-06-21 → 2023-11-10 (+142d) | 13d → 2d | 0d → 94.56d | 1.05.01.03 SS → 1.05.01.03 | resources none → CAPATAZ [1.02 h]; Excavadora Sobre Oruga 260 HP [2.55 h]; Motoniveladora 185 HP [10.22 h]; OPERARIO [10.22 h]; PEON [20.43 h]; Rodillo Vib. Liso Autopropulsado 135 HP 12 TM [10.22 h] |
| 1.05.01.04 | CONFORMACIÓN DE CUERPO DE DIQUE CON MATERIAL PROPIO | 2023-06-22 → 2023-11-11 (+142d) | 2023-06-26 → 2023-11-17 (+144d) | 5d → 5.67d | 0d → 94.56d | INICIO DE RELLENO DE DIQUE → 1.05.01.09 | resources none → Camión Cisterna 4x2 400 HP Agua (5000 gal) [43.77 h]; CAPATAZ [43.77 h]; Excavadora Sobre Oruga 260 HP [43.77 h]; Motoniveladora 185 HP [43.77 h]; OFICIAL [43.77 h]; OPERARIO [43.77 h]; PEON [174.9 h]; Rodillo Vib. Liso Autopropulsado 135 HP 12 TM [43.77 h] |
| 1.05.01.06 | GEOTEXTIL NO TEJIDO 400 G/M2, INC. COLOCACIÓN | 2023-06-24 → 2023-11-18 (+147d) | 2023-06-29 → 2023-12-05 (+159d) | 6d → 14d | 0d → 94.56d | 1.05.01.04 SS+2d → 1.05.01.04 | resources none → CAPATAZ [10.76 h]; OPERARIO [107.64 h]; PEON [430.54 h] |
| 1.05.01.07 | COLOCACION Y ACOMODO DE ROCA EN UÑA DE DIQUE | 2023-06-25 → 2023-12-06 (+164d) | 2023-06-30 → 2023-12-18 (+171d) | 6d → 8.67d | 0d → 94.56d | 1.05.01.06 SS+1d → 1.05.01.06 | resources none → Camión Volquete (15 m3) [2976.35 h]; CAPATAZ [530.38 h]; CUADRADOR/VIGÍA [2643.4 h]; Excavadora Sobre Oruga 260 HP [432.79 h]; OPERARIO [265.75 h]; PEON [1594.27 h] |
| 1.05.01.08 | COLOCACION Y ACOMODO DE ROCA EN TALUD DE DIQUE | 2023-06-27 → 2023-12-11 (+167d) | 2023-07-08 → 2023-12-29 (+174d) | 12d → 15.33d | 0d → 94.56d |  | resources none → Camión Volquete (15 m3) [2976.35 h]; CAPATAZ [730.3 h]; CUADRADOR/VIGÍA [2643.4 h]; Excavadora Sobre Oruga 260 HP [632.72 h]; OPERARIO [465.67 h]; PEON [4657.71 h] |
| 1.05.01.05 | CONFORMACIÓN DE CORONA DE DIQUE CON MATERIAL PROPIO | 2023-07-06 → 2023-12-30 (+177d) | 2023-07-11 → 2024-01-04 (+177d) | 6d → 3.67d | 97d → 94.56d | 1.05.01.08 FF+3d → 1.05.01.08 | resources none → Camión Cisterna 4x2 400 HP Agua (5000 gal) [28.59 h]; CAPATAZ [28.59 h]; Excavadora Sobre Oruga 260 HP [28.59 h]; Motoniveladora 185 HP [28.59 h]; OFICIAL [28.59 h]; OPERARIO [28.59 h]; PEON [114.26 h]; Rodillo Vib. Liso Autopropulsado 135 HP 12 TM [28.59 h] |
| 2 | **DIQUE DE TIERRA COMPACTADA A3-D-02** | 2023-07-11 → 2023-10-23 (+104d) | 2023-11-07 → 2024-05-03 (+178d) |  |  |  |  |
| 1.06.02.01 | EXCAVACIÓN EN TERRENO NATURAL CON EQUIPO | 2023-07-11 → 2023-10-23 (+104d) | 2023-07-19 → 2023-11-16 (+120d) | 9d → 19.67d |  | CONFORMACIÓN DE DESVIO EN CAUCE DE RÍO - DIQUE A3-I-02 → 1.03.01.01 SS | resources none → Camión Volquete (15 m3) [2976.35 h]; CAPATAZ [312.59 h]; CUADRADOR/VIGÍA [2643.4 h]; Excavadora Sobre Oruga 260 HP [667.94 h]; PEON [500.89 h]; Tractor S/Orugas (D6T) - 180 HP [250.44 h] |
| 1.06.02.02 | EXCAVACIÓN DE UÑA CON EQUIPO | 2023-07-12 → 2023-10-25 (+105d) | 2023-07-22 → 2023-11-17 (+118d) | 11d → 18.67d | 67d → 0d | 1.06.02.01 SS+1d, 1.05.01.02 → 1.06.02.01 SS+2d | resources none → CAPATAZ [190.6 h]; Excavadora Sobre Oruga 260 HP [382.86 h]; PEON [382.86 h] |
| 1.06.02.03 | PERFILADO Y COMPACTACIÓN EN ZONA DE CORTE | 2023-07-12 → 2023-10-28 (+108d) | 2023-07-23 → 2023-12-11 (+141d) | 12d → 32.67d |  | 1.06.02.01 SS+1d → 1.06.02.02 SS+3d | resources none → Camión Cisterna 4x2 400 HP Agua (5000 gal) [278.77 h]; CAPATAZ [139.39 h]; Motoniveladora 185 HP [278.77 h]; OFICIAL [278.77 h]; PEON [278.77 h]; Rodillo Vib. Liso Autopropulsado 135 HP 12 TM [278.77 h] |
| 1.06.02.09 | PREPARACIÓN DE FUNDACIÓN DE CUERPO DE DIQUE | 2023-07-20 → 2023-12-12 (+145d) | 2023-07-24 → 2023-12-18 (+147d) | 5d → 5.67d | 77d → 0d | 1.06.02.01 → 1.06.02.03 | resources none → CAPATAZ [4.15 h]; Excavadora Sobre Oruga 260 HP [10.38 h]; Motoniveladora 185 HP [41.53 h]; OPERARIO [41.53 h]; PEON [83.05 h]; Rodillo Vib. Liso Autopropulsado 135 HP 12 TM [41.53 h] |
| 1.06.02.04 | CONFORMACIÓN DE CUERPO DE DIQUE CON MATERIAL PROPIO | 2023-07-21 → 2023-12-19 (+151d) | 2023-07-25 → 2024-01-17 (+176d) | 5d → 22.67d | 77d → 0d | 1.06.02.09 SS+1d → 1.06.02.09 | resources none → Camión Cisterna 4x2 400 HP Agua (5000 gal) [185.32 h]; CAPATAZ [185.32 h]; Excavadora Sobre Oruga 260 HP [185.32 h]; Motoniveladora 185 HP [185.32 h]; OFICIAL [185.32 h]; OPERARIO [185.32 h]; PEON [740.59 h]; Rodillo Vib. Liso Autopropulsado 135 HP 12 TM [185.32 h] |
| 1.06.02.06 | GEOTEXTIL NO TEJIDO 400 G/M2, INC. COLOCACIÓN | 2023-07-14 → 2023-12-26 (+165d) | 2023-07-26 → 2024-03-06 (+224d) | 13d → 57.33d |  | 1.06.02.03 SS+2d → 1.06.02.04 SS+5d | resources none → CAPATAZ [48.73 h]; OPERARIO [487.29 h]; PEON [1949.15 h] |
| 1.06.02.07 | COLOCACION Y ACOMODO DE ROCA EN UÑA DE DIQUE | 2023-07-16 → 2023-12-29 (+166d) | 2023-07-31 → 2024-03-06 (+219d) | 16d → 54.33d |  | 1.06.02.06 SS+2d → 1.06.02.06 SS+3d | resources none → Camión Volquete (15 m3) [2976.35 h]; CAPATAZ [2175.61 h]; CUADRADOR/VIGÍA [2643.4 h]; Excavadora Sobre Oruga 260 HP [167.05 h]; OPERARIO [1910.98 h]; PEON [11464.2 h] |
| 1.06.02.08 | COLOCACION Y ACOMODO DE ROCA EN TALUD DE DIQUE | 2023-07-18 → 2023-12-30 (+165d) | 2023-08-01 → 2024-04-10 (+253d) | 15d → 79.89d |  | 1.06.02.07 SS+2d → 1.06.02.07 SS+1d | resources none → Camión Volquete (15 m3) [2976.35 h]; CAPATAZ [2933.71 h]; CUADRADOR/VIGÍA [2643.4 h]; Excavadora Sobre Oruga 260 HP [167.05 h]; OPERARIO [2669.08 h]; PEON [2669.08 h] |
| 1.06.02.05 | CONFORMACIÓN DE CORONA DE DIQUE CON MATERIAL PROPIO | 2023-07-30 → 2024-04-11 (+256d) | 2023-08-04 → 2024-05-03 (+273d) | 6d → 18d | 79d → 0d | 1.06.02.08 FF+3d, 1.05.01.05 → 1.06.02.08 | resources none → Camión Cisterna 4x2 400 HP Agua (5000 gal) [144.43 h]; CAPATAZ [144.43 h]; Excavadora Sobre Oruga 260 HP [144.43 h]; Motoniveladora 185 HP [144.43 h]; OFICIAL [144.43 h]; OPERARIO [144.43 h]; PEON [577.21 h]; Rodillo Vib. Liso Autopropulsado 135 HP 12 TM [144.43 h] |
| 3 | **DIQUE DE TIERRA COMPACTADA A3-I-01** | 2023-07-11 → 2023-11-02 (+114d) | 2023-11-13 → 2024-01-02 (+50d) |  |  |  |  |
| 1.06.03.01 | EXCAVACIÓN EN TERRENO NATURAL CON EQUIPO | 2023-08-04 → 2023-11-02 (+90d) | 2023-08-12 → 2023-11-11 (+91d) | 9d → 8.33d | 0d → 6.24d | CONFORMACIÓN DE DESVIO EN CAUCE DE RÍO - DIQUE A3-I-03 - TRAMO 1 → 1.05.01.01 | resources none → Camión Volquete (15 m3) [2976.35 h]; CAPATAZ [312.59 h]; CUADRADOR/VIGÍA [2643.4 h]; Excavadora Sobre Oruga 260 HP [667.94 h]; PEON [500.89 h]; Tractor S/Orugas (D6T) - 180 HP [250.44 h] |
| 1.06.03.02 | EXCAVACIÓN DE UÑA CON EQUIPO | 2023-08-05 → 2023-11-02 (+89d) | 2023-08-15 → 2023-11-13 (+90d) | 11d → 9.33d | 54d → 96.56d | 1.06.03.01 SS+1d, 1.06.02.02 → 1.06.03.01 SS | resources none → CAPATAZ [190.6 h]; Excavadora Sobre Oruga 260 HP [382.86 h]; PEON [382.86 h] |
| 1.06.03.03 | PERFILADO Y COMPACTACIÓN EN ZONA DE CORTE | 2023-08-05 → 2023-11-04 (+91d) | 2023-08-16 → 2023-11-14 (+90d) | 12d → 8.33d | 0d → 96.56d | 1.06.03.01 SS+1d → 1.06.03.02 SS+2d | resources none → Camión Cisterna 4x2 400 HP Agua (5000 gal) [278.77 h]; CAPATAZ [139.39 h]; Motoniveladora 185 HP [287.77 h]; OFICIAL [278.77 h]; PEON [278.77 h]; Rodillo Vib. Liso Autopropulsado 135 HP 12 TM [278.77 h] |
| 1.06.03.09 | PREPARACIÓN DE FUNDACIÓN DE CUERPO DE DIQUE | 2023-08-13 → 2023-11-15 (+94d) | 2023-08-17 → 2023-11-16 (+91d) | 5d → 2d | 58d → 96.56d | 1.06.03.01 → 1.06.03.03 | resources none → CAPATAZ [4.15 h]; Excavadora Sobre Oruga 260 HP [10.38 h]; Motoniveladora 185 HP [41.53 h]; OPERARIO [41.53 h]; PEON [83.05 h]; Rodillo Vib. Liso Autopropulsado 135 HP 12 TM [41.53 h] |
| 1.06.03.04 | CONFORMACIÓN DE CUERPO DE DIQUE CON MATERIAL PROPIO | 2023-08-14 → 2023-11-17 (+95d) | 2023-08-18 → 2023-11-28 (+102d) | 5d → 9.33d | 58d → 96.56d | 1.06.03.09 SS+1d, 1.06.02.04 → 1.06.03.09 | resources none → Camión Cisterna 4x2 400 HP Agua (5000 gal) [185.32 h]; CAPATAZ [185.32 h]; Excavadora Sobre Oruga 260 HP [185.32 h]; Motoniveladora 185 HP [185.32 h]; OFICIAL [185.32 h]; OPERARIO [185.32 h]; PEON [740.59 h]; Rodillo Vib. Liso Autopropulsado 135 HP 12 TM [185.32 h] |
| 1.06.03.06 | GEOTEXTIL NO TEJIDO 400 G/M2, INC. COLOCACIÓN | 2023-08-07 → 2023-11-22 (+107d) | 2023-08-18 → 2023-12-07 (+111d) | 12d → 13d | 0d → 96.56d | 1.06.03.03 SS+2d → 1.06.03.04 SS+4d | resources none → CAPATAZ [48.73 h]; OPERARIO [487.29 h]; PEON [1949.15 h] |
| 1.06.03.07 | COLOCACION Y ACOMODO DE ROCA EN UÑA DE DIQUE | 2023-08-09 → 2023-11-28 (+111d) | 2023-08-24 → 2023-12-12 (+110d) | 16d → 10.67d | 0d → 96.56d | 1.06.03.06 SS+2d → 1.06.03.06 SS+4.33d | resources none → Camión Volquete (15 m3) [2976.35 h]; CAPATAZ [2175.61 h]; CUADRADOR/VIGÍA [2643.4 h]; Excavadora Sobre Oruga 260 HP [2078.03 h]; OPERARIO [1910.98 h]; PEON [11464.2 h] |
| 1.06.03.08 | COLOCACION Y ACOMODO DE ROCA EN TALUD DE DIQUE | 2023-08-11 → 2023-12-01 (+112d) | 2023-08-25 → 2023-12-27 (+124d) | 15d → 19d | 0d → 96.56d | 1.06.03.07 SS+2d → 1.06.03.07 SS+3d | resources none → Camión Volquete (15 m3) [2976.35 h]; CAPATAZ [2933.71 h]; CUADRADOR/VIGÍA [2643.4 h]; Excavadora Sobre Oruga 260 HP [2836.13 h]; OPERARIO [2669.08 h]; PEON [26696.8 h] |
| 1.06.03.05 | CONFORMACIÓN DE CORONA DE DIQUE CON MATERIAL PROPIO | 2023-08-23 → 2023-12-28 (+127d) | 2023-08-28 → 2024-01-02 (+127d) | 6d → 3.67d | 61d → 96.56d | 1.06.03.08 FF+3d, 1.06.02.05 → 1.06.03.08 | resources none → Camión Cisterna 4x2 400 HP Agua (5000 gal) [144.43 h]; CAPATAZ [144.43 h]; Excavadora Sobre Oruga 260 HP [144.43 h]; Motoniveladora 185 HP [144.43 h]; OFICIAL [144.43 h]; OPERARIO [144.43 h]; PEON [577.21 h]; Rodillo Vib. Liso Autopropulsado 135 HP 12 TM [144.43 h] |
| 4 | **DIQUE DE TIERRA COMPACTADA A3-I-02** | 2023-07-28 → 2023-11-13 (+108d) | 2023-08-21 → 2024-02-17 (+180d) |  |  |  |  |
| 1.06.04.01 | EXCAVACIÓN EN TERRENO NATURAL CON EQUIPO | 2023-08-28 → 2023-11-13 (+77d) | 2023-09-05 → 2023-12-11 (+97d) | 9d → 22d | 0d → 6.24d | CONFORMACIÓN DE DESVIO EN CAUCE DE RÍO - DIQUE A3-I-03 - TRAMO 2 → 1.06.03.01 | resources none → Camión Volquete (15 m3) [2976.35 h]; CAPATAZ [277.02 h]; CUADRADOR/VIGÍA [2643.4 h]; Excavadora Sobre Oruga 260 HP [296.44 h]; PEON [129.39 h]; Tractor S/Orugas (D6T) - 180 HP [64.69 h] |
| 1.06.04.02 | EXCAVACIÓN DE UÑA CON EQUIPO | 2023-08-29 → 2023-11-13 (+76d) | 2023-09-08 → 2023-12-12 (+95d) | 11d → 23d | 41d → 59.22d | 1.06.04.01 SS+1d, 1.06.03.02 → 1.06.04.01 SS | resources none → CAPATAZ [25.94 h]; Excavadora Sobre Oruga 260 HP [52.11 h]; PEON [52.11 h] |
| 1.06.04.03 | PERFILADO Y COMPACTACIÓN EN ZONA DE CORTE | 2023-08-29 → 2023-12-13 (+106d) | 2023-09-09 → 2023-12-22 (+104d) | 12d → 8d | 0d → 59.22d | 1.06.04.01 SS+1d → 1.06.04.02 | resources none → Camión Cisterna 4x2 400 HP Agua (5000 gal) [39.2 h]; CAPATAZ [19.6 h]; Motoniveladora 185 HP [39.2 h]; OFICIAL [39.2 h]; PEON [39.2 h]; Rodillo Vib. Liso Autopropulsado 135 HP 12 TM [39.2 h] |
| 1.06.04.09 | PREPARACIÓN DE FUNDACIÓN DE CUERPO DE DIQUE | 2023-09-06 → 2023-12-22 (+107d) | 2023-09-10 → 2023-12-23 (+104d) | 5d → 1d | 39d → 59.22d | 1.06.04.01 → 1.06.04.03 | resources none → CAPATAZ [1.02 h]; Excavadora Sobre Oruga 260 HP [2.55 h]; Motoniveladora 185 HP [10.22 h]; OPERARIO [10.22 h]; PEON [20.43 h]; Rodillo Vib. Liso Autopropulsado 135 HP 12 TM [10.22 h] |
| 1.06.04.04 | CONFORMACIÓN DE CUERPO DE DIQUE CON MATERIAL PROPIO | 2023-09-07 → 2023-12-23 (+107d) | 2023-09-11 → 2023-12-27 (+107d) | 5d → 1.67d | 39d → 59.22d | 1.06.04.09 SS+1d, 1.06.03.04 → 1.06.04.09 | resources none → Camión Cisterna 4x2 400 HP Agua (5000 gal) [74.58 h]; CAPATAZ [74.58 h]; Excavadora Sobre Oruga 260 HP [74.58 h]; Motoniveladora 185 HP [74.58 h]; OFICIAL [74.58 h]; OPERARIO [74.58 h]; PEON [298.02 h]; Rodillo Vib. Liso Autopropulsado 135 HP 12 TM [74.58 h] |
| 1.06.04.06 | GEOTEXTIL NO TEJIDO 400 G/M2, INC. COLOCACIÓN | 2023-08-31 → 2023-12-27 (+118d) | 2023-09-11 → 2024-01-11 (+122d) | 12d → 11.33d | 0d → 59.22d | 1.06.04.03 SS+2d → 1.06.04.04 | resources none → CAPATAZ [10.55 h]; OPERARIO [105.53 h]; PEON [422.13 h] |
| 1.06.04.07 | COLOCACION Y ACOMODO DE ROCA EN UÑA DE DIQUE | 2023-09-02 → 2024-01-02 (+122d) | 2023-09-17 → 2024-01-29 (+134d) | 16d → 21.67d | 0d → 59.22d | 1.06.04.06 SS+2d → 1.06.04.06 SS+4d | resources none → Camión Volquete (15 m3) [2976.35 h]; CAPATAZ [524.72 h]; Excavadora Sobre Oruga 260 HP [427.14 h]; OPERARIO [260.09 h]; PEON [1560.34 h] |
| 1.06.04.08 | COLOCACION Y ACOMODO DE ROCA EN TALUD DE DIQUE | 2023-09-04 → 2024-01-05 (+123d) | 2023-09-18 → 2024-02-12 (+147d) | 15d → 30.33d | 0d → 59.22d | 1.06.04.07 SS+2d → 1.06.04.07 SS+2.67d | resources none → Camión Volquete (15 m3) [2976.35 h]; CAPATAZ [721.35 h]; CUADRADOR/VIGÍA [2643.4 h]; Excavadora Sobre Oruga 260 HP [623.77 h]; OPERARIO [456.72 h]; PEON [4568.23 h] |
| 1.06.04.05 | CONFORMACIÓN DE CORONA DE DIQUE CON MATERIAL PROPIO | 2023-09-16 → 2024-02-12 (+149d) | 2023-09-21 → 2024-02-17 (+149d) | 6d → 4.67d | 43d → 59.22d | 1.06.04.08 FF+3d, 1.06.03.05 → 1.06.04.08 | resources none → Camión Cisterna 4x2 400 HP Agua (5000 gal) [28.01 h]; CAPATAZ [28.01 h]; Excavadora Sobre Oruga 260 HP [28.01 h]; Motoniveladora 185 HP [28.01 h]; OFICIAL [28.01 h]; OPERARIO [28.01 h]; PEON [111.94 h]; Rodillo Vib. Liso Autopropulsado 135 HP 12 TM [28.01 h] |
| 5 | **DIQUE DE TIERRA COMPACTADA A3-I-03** | 2023-08-21 → 2023-12-12 (+113d) | 2023-11-19 → 2024-04-22 (+155d) |  |  |  |  |
| 1.06.05.01 | EXCAVACIÓN EN TERRENO NATURAL CON EQUIPO | 2023-09-21 → 2023-12-12 (+82d) | 2023-09-29 → 2024-01-06 (+99d) | 9d → 19.67d | 0d → 6.24d | CONFORMACIÓN DE DESVIO EN CAUCE DE RÍO - DIQUE A3-I-03 - TRAMO 3 → 1.06.04.01 | resources none → Camión Volquete (15 m3) [2976.35 h]; CAPATAZ [281.53 h]; CUADRADOR/VIGÍA [2643.4 h]; Excavadora Sobre Oruga 260 HP [343.59 h]; PEON [176.54 h]; Tractor S/Orugas (D6T) - 180 HP [88.27 h] |
| 1.06.05.02 | EXCAVACIÓN DE UÑA CON EQUIPO | 2023-09-22 → 2023-12-12 (+81d) | 2023-10-02 → 2024-01-06 (+96d) | 11d → 19.67d | 28d → 6.24d | 1.06.05.01 SS+1d, 1.06.04.02 → 1.06.05.01 SS | resources none → CAPATAZ [35.35 h]; Excavadora Sobre Oruga 260 HP [71.01 h]; PEON [71.01 h] |
| 1.06.05.03 | PERFILADO Y COMPACTACIÓN EN ZONA DE CORTE | 2023-09-22 → 2023-12-15 (+84d) | 2023-10-03 → 2023-12-23 (+81d) | 12d → 7.33d | 0d → 6.24d | 1.06.05.01 SS+1d → 1.06.05.01 SS+3d, 1.06.05.02 SS+3d | resources none → Camión Cisterna 4x2 400 HP Agua (5000 gal) [48.82 h]; CAPATAZ [24.41 h]; Motoniveladora 185 HP [48.82 h]; OFICIAL [48.82 h]; PEON [48.82 h]; Rodillo Vib. Liso Autopropulsado 135 HP 12 TM [48.82 h] |
| 1.06.05.09 | PREPARACIÓN DE FUNDACIÓN DE CUERPO DE DIQUE | 2023-09-30 → 2023-12-26 (+87d) | 2023-10-04 → 2023-12-30 (+87d) | 5d → 4.67d | 20d → 6.24d | 1.06.05.01 → 1.06.05.03 | resources none → CAPATAZ [0.57 h]; Excavadora Sobre Oruga 260 HP [1.42 h]; Motoniveladora 185 HP [5.66 h]; OPERARIO [5.66 h]; PEON [11.33 h]; Rodillo Vib. Liso Autopropulsado 135 HP 12 TM [5.66 h] |
| 1.06.05.04 | CONFORMACIÓN DE CUERPO DE DIQUE CON MATERIAL PROPIO | 2023-10-01 → 2024-01-02 (+93d) | 2023-10-05 → 2024-01-23 (+110d) | 5d → 18d | 20d → 6.24d | 1.06.05.09 SS+1d, 1.06.04.04 → 1.06.05.09 | resources none → Camión Cisterna 4x2 400 HP Agua (5000 gal) [15.45 h]; CAPATAZ [15.45 h]; Excavadora Sobre Oruga 260 HP [15.45 h]; Motoniveladora 185 HP [15.45 h]; OFICIAL [15.45 h]; OPERARIO [15.45 h]; PEON [61.73 h]; Rodillo Vib. Liso Autopropulsado 135 HP 12 TM [15.45 h] |
| 1.06.05.06 | GEOTEXTIL NO TEJIDO 400 G/M2, INC. COLOCACIÓN | 2023-09-24 → 2024-01-24 (+122d) | 2023-10-05 → 2024-02-02 (+120d) | 12d → 8.67d | 0d → 6.24d | 1.06.05.03 SS+2d → 1.06.05.04 | resources none → CAPATAZ [9.5 h]; OPERARIO [95.04 h]; PEON [380.16 h] |
| 1.06.05.07 | COLOCACION Y ACOMODO DE ROCA EN UÑA DE DIQUE | 2023-09-26 → 2024-02-03 (+130d) | 2023-10-11 → 2024-03-12 (+153d) | 16d → 31d | 0d → 6.24d | 1.06.05.06 SS+2d → 1.06.05.06 | resources none → Camión Volquete (15 m3) [2976.35 h]; CAPATAZ [619.08 h]; CUADRADOR/VIGÍA [2643.4 h]; Excavadora Sobre Oruga 260 HP [521.5 h]; OPERARIO [354.45 h]; PEON [2126.4 h] |
| 1.06.05.08 | COLOCACION Y ACOMODO DE ROCA EN TALUD DE DIQUE | 2023-09-28 → 2024-02-08 (+133d) | 2023-10-12 → 2024-04-04 (+175d) | 15d → 44d | 0d → 6.24d | 1.06.05.07 SS+2d → 1.06.05.07 SS+4d | resources none → Camión Volquete (15 m3) [2976.35 h]; CAPATAZ [776.13 h]; CUADRADOR/VIGÍA [2643.4 h]; Excavadora Sobre Oruga 260 HP [678.55 h]; OPERARIO [511.5 h]; PEON [5116.14 h] |
| 1.06.05.05 | CONFORMACIÓN DE CORONA DE DIQUE CON MATERIAL PROPIO | 2023-10-10 → 2024-04-05 (+178d) | 2023-10-15 → 2024-04-22 (+190d) | 6d → 14.22d | 25d → 8.67d | 1.06.05.08 FF+3d, 1.06.04.05 → 1.06.05.08 | resources none → Camión Cisterna 4x2 400 HP Agua (5000 gal) [33.2 h]; CAPATAZ [33.2 h]; Excavadora Sobre Oruga 260 HP [33.2 h]; Motoniveladora 185 HP [33.2 h]; OFICIAL [33.2 h]; OPERARIO [33.2 h]; PEON [132.69 h]; Rodillo Vib. Liso Autopropulsado 135 HP 12 TM [33.2 h] |
| 6 | **RAMPAS** | 2023-10-27 → 2024-01-08 (+73d) | 2023-11-09 → 2024-01-15 (+67d) |  |  |  |  |

| ID | Task | Start | Finish | Duration | Total float | Predecessors | Other |
| --- | --- | --- | --- | --- | --- | --- | --- |
| 1.06.01 | EXCAVACIÓN EN TERRENO NATURAL CON EQUIPO | 2023-10-15 → 2024-01-08 (+85d) | 2023-10-23 → 2024-01-10 (+79d) | 9d → 3d | 0d → 86.22d | CONFORMACIÓN DE DESVIO EN CAUCE DE RÍO - DIQUE A3-I-03 - TRAMO 4 → 1.06.05.01 | resources none → CAPATAZ [0.38 h]; Excavadora Sobre Oruga 260 HP [4.02 h]; PEON [4.02 h]; Tractor S/Orugas (D6T) - 180 HP [2.01 h] |
| 1.06.02 | CONFORMACIÓN DE CUERPO DE RAMPA CON MATERIAL PROPIO | 2023-10-30 → 2024-01-11 (+73d) | 2023-11-01 → 2024-01-12 (+72d) | 3d → 2.25d | 15d → 97d | EXCAVACIÓN EN TERRENO NATURAL CON EQUIPO → 1.06.01 | resources none → Camión Cisterna 4x2 400 HP Agua (5000 gal) [6.32 h]; CAPATAZ [6.32 h]; Excavadora Sobre Oruga 260 HP [6.32 h]; Motoniveladora 185 HP [6.32 h]; OFICIAL [6.32 h]; OPERARIO [6.32 h]; PEON [25.27 h]; Rodillo Vib. Liso Autopropulsado 135 HP 12 TM [6.32 h] |
| 1.06.03 | CONFORMACIÓN DE CORONACIÓN DE RAMPA | 2023-10-30 → 2024-01-13 (+75d) | 2023-11-01 → 2024-01-15 (+75d) | 3d → 1.67d | 15d → 86.22d | 1.06.02 SS → 1.06.02 | resources none → Camión Cisterna 4x2 400 HP Agua (5000 gal) [4.32 h]; CAPATAZ [4.32 h]; Excavadora Sobre Oruga 260 HP [4.32 h]; Motoniveladora 185 HP [4.32 h]; OFICIAL [4.32 h]; OPERARIO [4.32 h]; PEON [17.26 h]; Rodillo Vib. Liso Autopropulsado 135 HP 12 TM [4.32 h] |
| 2 | **OBRAS DE ARTE** | 2023-06-01 → 2023-11-22 (+174d) | 2023-11-16 → 2024-03-23 (+128d) |  |  |  |  |
| 1 | **CAPTACIÓN A3-CP-23-95** | 2023-06-16 → 2023-11-22 (+159d) | 2023-10-12 → 2024-02-21 (+132d) |  |  |  |  |
| 1 | **MOVIMIENTO DE TIERRAS** | 2023-06-16 → 2023-11-22 (+159d) | 2023-08-02 → 2024-01-03 (+154d) |  |  |  |  |
| 2.01.01.01 | EXCAVACIÓN ESTRUCTURAL PARA OBRAS DE ARTE | 2023-06-16 → 2023-11-22 (+159d) | 2023-06-21 → 2023-11-29 (+161d) | 6d → 6.33d | 38d → 10.33d | 2.02.05.01 → 1.06.04.01 SS+8d | resources none → CAPATAZ [5.2 h]; CUADRADOR/VIGÍA [51.99 h]; PEON [207.98 h]; Retroexcavador 58 HP [51.99 h] |
| 2.01.01.02 | RELLENO ESTRUCTURAL PARA OBRAS DE ARTE, CON MATERIAL PROPIO | 2023-07-29 → 2023-12-23 (+147d) | 2023-08-02 → 2024-01-03 (+154d) | 5d → 7.33d | 90d → 95.56d | 2.01.02.02 FS+12d → 2.01.02.03, 2.01.02.04 FF+6d | resources none → CAPATAZ [4.86 h]; CUADRADOR/VIGÍA [48.57 h]; PEON [194.28 h]; Retroexcavador 58 HP [12.15 h]; Rodillo Vib. Liso Autopropulsado 135 HP 12 TM [48.57 h] |
| 2 | **OBRAS DE CONCRETO** | 2023-06-22 → 2023-11-30 (+161d) | 2023-07-16 → 2023-12-26 (+163d) |  |  |  |  |
| 2.01.02.01 | CONCRETO f'c=100 kg/cm2 | 2023-06-22 → 2023-11-30 (+161d) | 2023-06-24 → 2023-11-30 (+159d) | 3d → 1d | 50d → 95.56d |  | resources none → CAPATAZ [0.25 h]; OFICIAL [1.23 h]; OPERARIO [2.45 h]; PEON [12.27 h] |
| 2.01.02.05 | ACERO DE REFUERZO fy=4200 kg/cm2 | 2023-06-28 → 2023-12-01 (+156d) | 2023-07-10 → 2023-12-12 (+155d) | 13d → 7.67d | 50d → 95.56d | 2.01.02.03 → 2.01.02.01 | resources none → CAPATAZ [22.75 h]; OPERARIO [229.58 h]; PEON [229.58 h] |
| 2.01.02.04 | ENCOFRADO Y DESENCOFRADO RECTO | 2023-07-02 → 2023-12-05 (+156d) | 2023-07-11 → 2023-12-26 (+168d) | 10d → 14.33d | 53d → 95.89d | 2.01.02.05 FF+1d → 2.01.02.05 SS+2d, 2.01.02.03 FF+1d | resources none → CAPATAZ [31.4 h]; OPERARIO [62.8 h]; PEON [62.8 h] |
| 2.01.02.02 | CONCRETO f'c=280 kg/cm2 | 2023-07-05 → 2023-12-13 (+161d) | 2023-07-16 → 2023-12-21 (+158d) | 12d → 7.67d | 55d → 95.56d | 2.01.02.04 SS+3d → 2.01.02.05 | resources none → OFICIAL [122.05 h]; OPERARIO [61.02 h]; PEON [610.24 h] |
| 2.01.02.03 | CONCRETO CICLÓPEO f'c=280 kg/cm2 + 30% P.G. | 2023-06-25 → 2023-12-22 (+180d) | 2023-06-27 → 2023-12-22 (+178d) | 3d → 1d | 50d → 95.56d | 2.01.02.01 → 2.01.02.02 | resources none → CAPATAZ [0.45 h]; OPERARIO [2.24 h]; PEON [4.48 h] |
| 3 | **ESTRUCTURAS METALICAS** | 2023-07-29 → 2023-12-22 (+146d) | 2023-08-12 → 2023-12-27 (+137d) |  |  |  |  |
| 2.01.03.01 | COMPUERTA METALICA PLANA DESLIZANTE DE 1.0x1.0m | 2023-07-29 → 2023-12-22 (+146d) | 2023-07-31 → 2023-12-22 (+144d) | 3d → 1d | 99d → 100.22d | 2.01.02.02 FS+12d → 2.01.02.02 | resources none → OFICIAL [4 h]; OPERARIO [4 h]; PEON [12 h] |
| 2.01.03.02 | REJILLA DE 1.00x1.00m CON VARILLA DE 1/2" CADA 6,25cm | 2023-08-01 → 2023-12-22 (+143d) | 2023-08-03 → 2023-12-22 (+141d) | 3d → 1d | 99d → 100.22d | 2.01.03.01 → 2.01.03.01 SS | resources none → OPERARIO [1.6 h]; PEON [3.2 h] |
| 2.01.03.03 | BARANDA DE FIERRO GALVANIZADO 1 1/2" | 2023-08-04 → 2023-12-23 (+141d) | 2023-08-06 → 2023-12-23 (+139d) | 3d → 0.67d | 99d → 100.22d | 2.01.03.02 → 2.01.03.02 SS+1d | resources none → CAPATAZ [0.12 h]; OFICIAL [2.4 h]; OPERARIO [2.4 h]; PEON [1.2 h] |
| 2.01.03.04 | ESCALERA TIPO GATO | 2023-08-07 → 2023-12-26 (+141d) | 2023-08-09 → 2023-12-26 (+139d) | 3d → 1d | 99d → 100.22d | 2.01.03.03 → 2.01.03.03 SS+0.67d | resources none → CAPATAZ [0.2 h]; OPERARIO [2 h]; PEON [4 h] |
| 2.01.03.05 | TAPA METALICA CIRCULAR DN600 MM | 2023-08-10 → 2023-12-27 (+139d) | 2023-08-12 → 2023-12-27 (+137d) | 3d → 1d | 99d → 100.22d |  | resources none → OPERARIO [5.33 h]; PEON [5.33 h] |
| 4 | **TUBERIAS** | 2023-06-22 → 2023-11-30 (+161d) | 2023-08-18 → 2023-12-30 (+134d) |  |  |  |  |
| 2.01.04.01 | EXCAVACIÓN ESTRUCTURAL PARA OBRAS DE ARTE (Buzones) | 2023-06-22 → 2023-11-30 (+161d) | 2023-06-24 → 2023-12-02 (+161d) | 3d → 2.67d | 38d → 55.89d |  | resources none → CAPATAZ [1.85 h]; CUADRADOR/VIGÍA [18.46 h]; PEON [73.86 h]; Retroexcavador 58 HP [18.46 h] |
| 2.01.04.02 | EXCAVACIÓN DE ZANJA | 2023-06-25 → 2023-11-30 (+158d) | 2023-07-19 → 2023-12-14 (+148d) | 25d → 10.67d | 38d → 55.89d | 2.01.04.01 → 2.01.04.01 SS | resources none → CAPATAZ [8.19 h]; CUADRADOR/VIGÍA [81.86 h]; PEON [327.45 h]; Retroexcavador 58 HP [81.86 h] |
| 2.01.04.06 | CONCRETO f'c=100 kg/cm2 (Buzones) | 2023-06-28 → 2023-12-04 (+159d) | 2023-06-30 → 2023-12-04 (+157d) | 3d → 1d | 60d → 55.89d | 2.01.04.02 SS+3d, 2.01.02.01 → 2.01.04.01 | resources none → CAPATAZ [0.25 h]; OFICIAL [1.23 h]; OPERARIO [2.45 h]; PEON [12.27 h] |
| 2.01.04.10 | ACERO DE REFUERZO fy=4200 kg/cm2 (Buzones) | 2023-07-11 → 2023-12-05 (+147d) | 2023-07-14 → 2023-12-07 (+146d) | 4d → 3d | 50d → 55.89d | 2.01.04.06, 2.01.02.05 → 2.01.04.06 | resources none → CAPATAZ [1.88 h]; OPERARIO [18.94 h]; PEON [18.94 h] |
| 2.01.04.08 | ENCOFRADO Y DESENCOFRADO RECTO | 2023-07-15 → 2023-12-11 (+149d) | 2023-07-19 → 2023-12-12 (+146d) | 5d → 2d | 50d → 55.89d | 2.01.02.04, 2.01.04.10 → 2.01.04.10 | resources none → CAPATAZ [31.4 h]; OPERARIO [62.8 h]; PEON [62.8 h] |
| 2.01.04.09 | ENCOFRADO Y DESENCOFRADO CURVO | 2023-07-15 → 2023-12-11 (+149d) | 2023-07-19 → 2023-12-13 (+147d) | 5d → 3d | 50d → 55.89d |  | resources none → CAPATAZ [8.14 h]; OPERARIO [16.29 h]; PEON [16.29 h] |
| 2.01.04.07 | CONCRETO f'c=280 kg/cm2 (Buzones) | 2023-07-20 → 2023-12-14 (+147d) | 2023-07-22 → 2023-12-14 (+145d) | 3d → 1d | 52d → 55.89d | 2.01.04.09, 2.01.02.02 → 2.01.04.09 | resources none → OFICIAL [11.39 h]; OPERARIO [5.7 h]; PEON [59.96 h] |
| 2.01.04.03 | RELLENO ESTRUCTURAL PARA OBRAS DE ARTE CON MATERIAL PROPIO (Buzones) | 2023-08-04 → 2023-12-15 (+133d) | 2023-08-06 → 2023-12-18 (+134d) | 3d → 2d | 89d → 55.89d | 2.01.04.07 FS+12d, 2.01.01.02 → 2.01.04.07 | resources none → CAPATAZ [1.17 h]; CUADRADOR/VIGÍA [11.65 h]; PEON [46.6 h]; Retroexcavador 58 HP [2.91 h]; Rodillo Vib. Liso Autopropulsado 135 HP 12 TM [11.65 h] |
| 2.01.04.04 | CAMA DE ARENA | 2023-06-28 → 2023-12-15 (+170d) | 2023-07-22 → 2023-12-15 (+146d) | 25d → 1d | 93d → 89.89d | 2.01.04.02 SS+3d → 2.01.04.02 | resources none → CAPATAZ [2.78 h]; PEON [22.21 h] |
| 2.01.04.11 | SUMINISTRO E INSTALACIÓN DE TUBERÍA GRP DN600 mm SN2500 | 2023-06-29 → 2023-12-16 (+170d) | 2023-07-23 → 2023-12-18 (+148d) | 25d → 1.67d | 93d → 89.89d | 2.01.04.04 SS+1d → 2.01.04.04 | resources none → CAPATAZ [1.26 h]; CUADRADOR/VIGÍA [12.62 h]; OFICIAL [12.62 h]; PEON [25.24 h]; Retroexcavador 58 HP [12.62 h] |
| 2.01.04.05 | RELLENO COMÚN PARA ZANJAS | 2023-07-24 → 2023-12-19 (+148d) | 2023-08-18 → 2023-12-30 (+134d) | 26d → 9.33d | 93d → 89.89d |  | resources none → Camión Cisterna 4x2 400 HP Agua (5000 gal) [78.59 h]; CAPATAZ [7.86 h]; CUADRADOR/VIGÍA [78.59 h]; PEON [314.36 h]; Rodillo Vib. Liso Autopropulsado 135 HP 12 TM [78.59 h] |
| 5 | **CANAL** | 2023-07-20 → 2023-12-15 (+148d) | 2023-09-24 → 2024-02-10 (+139d) |  |  |  |  |
| 2.01.05.01 | EXCAVACIÓN ESTRUCTURAL PARA OBRAS DE ARTE | 2023-07-20 → 2023-12-15 (+148d) | 2023-07-25 → 2023-12-22 (+150d) | 6d → 6.67d | 38d → 55.89d | 2.01.04.02 → 2.01.04.02, 2.01.04.03 SS | resources none → CAPATAZ [5.2 h]; CUADRADOR/VIGÍA [51.99 h]; PEON [207.98 h] |
| 2.01.05.03 | COLOCACIÓN DE CONCRETO f'c=100 kg/cm2 | 2023-07-26 → 2023-12-23 (+150d) | 2023-07-29 → 2023-12-27 (+151d) | 4d → 2.67d | 38d → 55.89d | 2.01.04.06, 2.01.05.01 → 2.01.05.01 | resources none → CAPATAZ [3.98 h]; OFICIAL [19.9 h]; OPERARIO [39.8 h]; PEON [198.99 h] |
| 2.01.05.06 | ACERO DE REFUERZO fy=4200 kg/cm2 | 2023-07-30 → 2023-12-28 (+151d) | 2023-08-26 → 2024-01-09 (+136d) | 28d → 9.33d | 38d → 55.89d | 2.01.04.10, 2.01.05.03 → 2.01.05.03 | resources none → CAPATAZ [22.75 h]; OPERARIO [229.58 h]; PEON [229.58 h] |
| 2.01.05.05 | ENCOFRADO Y DESENCOFRADO RECTO | 2023-08-01 → 2024-01-02 (+154d) | 2023-09-21 → 2024-02-03 (+135d) | 52d → 27.33d | 38d → 55.89d | 2.01.04.09, 2.01.05.06 SS+2d → 2.01.05.06 SS+2.67d | resources none → CAPATAZ [21.4 h]; OPERARIO [62.8 h]; PEON [62.8 h] |
| 2.01.05.04 | COLOCACIÓN DE CONCRETO f'c=280 kg/cm2 | 2023-08-03 → 2024-01-05 (+155d) | 2023-09-24 → 2024-01-27 (+125d) | 53d → 18.67d | 38d → 55.89d | 2.01.04.07 SS, 2.01.05.05 SS+2d → 2.01.05.05 SS+3d | resources none → OFICIAL [174.63 h]; OPERARIO [87.31 h]; PEON [873.11 h] |
| 2.01.05.07 | JUNTA WATER STOP SIN BULBO 150 mm | 2023-08-03 → 2024-01-29 (+179d) | 2023-09-24 → 2024-01-31 (+129d) | 53d → 3d | 53d → 55.89d | 2.01.05.04 SS → 2.01.05.04 | resources none → OPERARIO [16.08 h]; PEON [16.08 h] |
| 2.01.05.02 | RELLENO ESTRUCTURAL PARA CANALES, CON MATERIAL PROPIO | 2023-08-07 → 2024-02-01 (+178d) | 2023-08-19 → 2024-02-10 (+175d) | 13d → 8.33d | 89d → 55.89d | 2.01.04.03 → 2.01.05.07, 2.01.04.05 SS | resources none → CAPATAZ [13.06 h]; CUADRADOR/VIGÍA [130.48 h]; PEON [521.87 h] |
| 6 | **OBRAS DE DESCARGA** | 2023-07-26 → 2024-02-12 (+201d) | 2023-10-12 → 2024-02-21 (+132d) |  |  |  |  |
| 2.01.06.01 | EXCAVACIÓN ESTRUCTURAL PARA OBRAS DE ARTE | 2023-07-26 → 2024-02-12 (+201d) | 2023-07-28 → 2024-02-12 (+199d) | 3d → 1d | 87d → 55.89d | 2.01.05.01 → 2.01.05.02 | resources none → CAPATAZ [5.2 h]; CUADRADOR/VIGÍA [51.99 h]; PEON [207.98 h] |
| 2.01.06.03 | CONCRETO f'c=100 kg/cm2 | 2023-07-30 → 2024-02-13 (+198d) | 2023-08-01 → 2024-02-13 (+196d) | 3d → 1d | 86d → 55.89d | 2.01.06.01, 2.01.05.03 → 2.01.06.01 | resources none → CAPATAZ [0.25 h]; OFICIAL [1.23 h]; OPERARIO [2.45 h]; PEON [12.27 h] |
| 2.01.06.06 | ACERO DE REFUERZO fy=4200 kg/cm2 | 2023-08-27 → 2024-02-14 (+171d) | 2023-08-29 → 2024-02-14 (+169d) | 3d → 1d | 61d → 55.89d | 2.01.06.03, 2.01.05.06 → 2.01.06.03 | resources none → CAPATAZ [22.75 h]; OPERARIO [229.58 h]; PEON [229.58 h] |
| 2.01.06.04 | CONCRETO f'c=280 kg/cm2 | 2023-09-25 → 2024-02-15 (+143d) | 2023-09-27 → 2024-02-15 (+141d) | 3d → 1d | 38d → 55.89d | 2.01.06.05, 2.01.05.04 → 2.01.06.05 SS | resources none → OFICIAL [122.05 h]; OPERARIO [61.02 h]; PEON [610.24 h] |
| 2.01.06.05 | ENCOFRADO Y DESENCOFRADO RECTO | 2023-09-22 → 2024-02-15 (+146d) | 2023-09-24 → 2024-02-17 (+146d) | 3d → 2.67d | 38d → 55.89d | 2.01.06.06, 2.01.05.05 → 2.01.06.06 | resources none → CAPATAZ [31.4 h]; OPERARIO [62.8 h]; PEON [62.8 h] |
| 2.01.06.07 | JUNTA WATER STOP SIN BULBO 150 mm | 2023-09-28 → 2024-02-16 (+141d) | 2023-09-30 → 2024-02-19 (+142d) | 3d → 2.67d | 50d → 55.89d | 2.01.06.04, 2.01.05.07 → 2.01.06.04 | resources none → OPERARIO [16.08 h]; PEON [16.08 h] |
| 2.01.06.02 | RELLENO ESTRUCTURAL PARA OBRAS DE ARTE CON MATERIAL PROPIO | 2023-10-10 → 2024-02-20 (+133d) | 2023-10-12 → 2024-02-20 (+131d) | 3d → 1d | 38d → 55.89d | 2.01.06.04 FS+12d, 2.01.05.02 → 2.01.06.07 | resources none → CAPATAZ [0.47 h]; CUADRADOR/VIGÍA [4.66 h]; PEON [18.62 h] |
| 2.01.06.08 | COMPUERTA METALICA PLANA DESLIZANTE | 2023-10-10 → 2024-02-21 (+134d) | 2023-10-12 → 2024-02-21 (+132d) | 3d → 1d | 38d → 55.89d | 2.01.06.04 FS+12d → 2.01.06.02 | resources none → OFICIAL [8 h]; OPERARIO [8 h]; PEON [24 h] |
| 2 | **CAPTACIÓN A3-CP-21-05** | 2023-06-04 → 2023-11-22 (+171d) | 2023-09-01 → 2024-01-26 (+147d) |  |  |  |  |
| 1 | **MOVIMIENTO DE TIERRAS** | 2023-06-04 → 2023-11-22 (+171d) | 2023-07-23 → 2024-01-26 (+187d) |  |  |  |  |
| 2.02.01.01 | EXCAVACIÓN ESTRUCTURAL PARA OBRAS DE ARTE | 2023-06-04 → 2023-11-22 (+171d) | 2023-06-07 → 2023-11-27 (+173d) | 4d → 4.23d | 38d → 10.33d | TOPOGRAFÍA Y GEOREFERENCIACIÓN SS+7d → 2.01.01.01 SS+0.1d | resources none → CAPATAZ [5.2 h]; CUADRADOR/VIGÍA [51.99 h]; PEON [207.98 h]; Retroexcavador 58 HP [51.99 h] |
| 2.02.01.02 | RELLENO ESTRUCTURAL PARA OBRAS DE ARTE, CON MATERIAL PROPIO | 2023-07-19 → 2024-01-18 (+183d) | 2023-07-23 → 2024-01-26 (+187d) | 5d → 7.67d | 119d → 64.56d | 2.02.02.02 FS+12d → 2.02.02.03 | resources none → CAPATAZ [4.86 h]; CUADRADOR/VIGÍA [48.57 h]; PEON [194.28 h]; Retroexcavador 58 HP [12.15 h]; Rodillo Vib. Liso Autopropulsado 135 HP 12 TM [48.57 h] |
| 2 | **OBRAS DE CONCRETO** | 2023-06-08 → 2023-11-28 (+173d) | 2023-07-06 → 2024-01-22 (+200d) |  |  |  |  |
| 2.02.02.01 | CONCRETO f'c=100 kg/cm2 | 2023-06-08 → 2023-11-28 (+173d) | 2023-06-10 → 2023-11-28 (+171d) | 3d → 1d | 79d → 64.56d |  | resources none → CAPATAZ [0.25 h]; OFICIAL [1.23 h]; OPERARIO [2.45 h]; PEON [12.27 h] |
| 2.02.02.05 | ACERO DE REFUERZO fy=4200 kg/cm2 | 2023-06-14 → 2023-11-29 (+168d) | 2023-07-04 → 2024-01-06 (+186d) | 21d → 28.33d | 79d → 64.56d | 2.02.02.03 → 2.02.02.01 | resources none → CAPATAZ [22.75 h]; OPERARIO [229.58 h]; PEON [229.58 h] |
| 2.02.02.04 | ENCOFRADO Y DESENCOFRADO RECTO | 2023-06-20 → 2023-12-02 (+165d) | 2023-07-04 → 2024-01-22 (+202d) | 15d → 37.67d | 82d → 67.56d | 2.02.02.05 SS+6d → 2.02.02.05 SS+3d | resources none → CAPATAZ [31.4 h]; OPERARIO [62.8 h]; PEON [62.8 h] |
| 2.02.02.02 | CONCRETO f'c=280 kg/cm2 | 2023-06-26 → 2024-01-08 (+196d) | 2023-07-06 → 2024-01-16 (+194d) | 11d → 7.67d | 109d → 64.56d | 2.02.02.04 SS+6d → 2.02.02.05 | resources none → OFICIAL [122.05 h]; OPERARIO [61.02 h]; PEON [610.24 h] |
| 2.02.02.03 | CONCRETO CICLÓPEO f'c=280 kg/cm2 + 30% P.G. | 2023-06-11 → 2024-01-17 (+220d) | 2023-06-13 → 2024-01-17 (+218d) | 3d → 1d | 79d → 64.56d | 2.02.02.01 → 2.02.02.02 | resources none → CAPATAZ [0.45 h]; OPERARIO [2.24 h]; PEON [4.48 h] |
| 3 | **ESTRUCTURAS METALICAS** | 2023-07-19 → 2024-01-17 (+182d) | 2023-08-02 → 2024-01-23 (+174d) |  |  |  |  |
| 2.02.03.01 | COMPUERTA METALICA PLANA DESLIZANTE DE 1.0x1.0m | 2023-07-19 → 2024-01-17 (+182d) | 2023-07-21 → 2024-01-17 (+180d) | 3d → 1d | 109d → 67.56d | 2.02.02.02 FS+12d → 2.02.02.02 | resources none → OFICIAL [4 h]; OPERARIO [4 h]; PEON [12 h] |
| 2.02.03.02 | REJILLA DE 1.00x1.00m CON VARILLA DE 1/2 CADA 6,25cm | 2023-07-22 → 2024-01-17 (+179d) | 2023-07-24 → 2024-01-17 (+177d) | 3d → 1d | 109d → 67.56d | 2.02.03.01 → 2.02.03.01 SS | resources none → OPERARIO [1.6 h]; PEON [3.2 h] |
| 2.02.03.03 | BARANDA DE FIERRO GALVANIZADO 1 1/2" | 2023-07-25 → 2024-01-18 (+177d) | 2023-07-27 → 2024-01-18 (+175d) | 3d → 1d | 109d → 67.56d | 2.02.03.02 → 2.02.03.02 SS+1d | resources none → CAPATAZ [0.12 h]; OFICIAL [2.4 h]; OPERARIO [2.4 h]; PEON [1.2 h] |
| 2.02.03.04 | ESCALERA TIPO GATO | 2023-07-28 → 2024-01-22 (+178d) | 2023-07-30 → 2024-01-22 (+176d) | 3d → 0.67d | 109d → 67.56d | 2.02.03.03 → 2.02.03.03 FS+2d | resources none → CAPATAZ [0.2 h]; OPERARIO [2 h]; PEON [4 h] |
| 2.02.03.05 | TAPA METALICA CIRCULAR DN600 MM | 2023-07-31 → 2024-01-23 (+176d) | 2023-08-02 → 2024-01-23 (+174d) | 3d → 1d | 109d → 67.56d | 2.02.03.04 → 2.02.03.04, 2.02.02.04 | resources none → OPERARIO [5.33 h]; PEON [5.33 h] |
| 4 | **TUBERIA** | 2023-06-08 → 2023-11-28 (+173d) | 2023-07-28 → 2023-12-06 (+131d) |  |  |  |  |
| 2.02.04.01 | EXCAVACIÓN ESTRUCTURAL PARA OBRAS DE ARTE (Buzones) | 2023-06-08 → 2023-11-28 (+173d) | 2023-06-10 → 2023-11-28 (+171d) | 3d → 1d | 38d → 10.33d |  | resources none → CAPATAZ [1.85 h]; CUADRADOR/VIGÍA [18.46 h]; PEON [73.86 h]; Retroexcavador 58 HP [18.46 h] |
| 2.02.04.02 | EXCAVACIÓN DE ZANJA | 2023-06-11 → 2023-11-28 (+170d) | 2023-06-13 → 2023-11-28 (+168d) | 3d → 1d | 143d → 71.22d | 2.02.04.01 → 2.02.04.01 SS | resources none → CAPATAZ [8.19 h]; CUADRADOR/VIGÍA [81.86 h]; PEON [327.45 h]; Retroexcavador 58 HP [81.86 h] |
| 2.02.04.04 | CAMA DE ARENA | 2023-06-14 → 2023-11-29 (+168d) | 2023-06-16 → 2023-11-29 (+166d) | 3d → 1d | 143d → 71.22d |  | resources none → CAPATAZ [2.78 h]; PEON [22.21 h] |
| 2.02.04.07 | CONCRETO f'c=100 kg/cm2 (Buzones) | 2023-06-11 → 2023-11-29 (+171d) | 2023-06-13 → 2023-11-29 (+169d) | 3d → 1d | 100d → 32.22d | 2.02.04.01, 2.02.02.01 → 2.02.04.01 | resources none → CAPATAZ [0.25 h]; OFICIAL [1.23 h]; OPERARIO [2.45 h]; PEON [12.27 h] |

| ID | Task | Start | Finish | Duration | Total float | Predecessors | Other |
| --- | --- | --- | --- | --- | --- | --- | --- |
| 2.02.04.11 | ACERO DE REFUERZO fy=4200 kg/cm2 | 2023-07-05 → 2023-11-30 (+148d) | 2023-07-07 → 2023-11-30 (+146d) | 3d → 1d | 79d → 32.22d | 2.02.04.07, 2.02.02.05 → 2.02.04.07 | resources none → CAPATAZ [1.88 h]; OPERARIO [18.94 h]; PEON [18.94 h] |
| 2.02.04.12 | SUMINISTRO E INSTALACIÓN DE TUBERÍA GRP DN600 mm SN2500 | 2023-06-17 → 2023-11-30 (+166d) | 2023-06-19 → 2023-11-30 (+164d) | 3d → 1d | 143d → 71.22d |  | resources none → CAPATAZ [0.09 h]; Excavadora Sobre Oruga 260 HP [0.91 h]; OFICIAL [0.91 h]; PEON [1.81 h] |
| 2.02.04.05 | RELLENO SELECCIONADO PARA ZANJAS CON MATERIAL PROPIO | 2023-06-20 → 2023-12-01 (+164d) | 2023-06-22 → 2023-12-04 (+165d) | 3d → 2.67d | 143d → 71.22d | 2.02.04.06 SS → 2.02.04.12 | resources none → CAPATAZ [0.96 h]; CUADRADOR/VIGÍA [9.63 h]; PEON [38.53 h]; Retroexcavador 58 HP [2.41 h]; Rodillo Vib. Liso Autopropulsado 135 HP 12 TM [9.63 h] |
| 2.02.04.09 | ENCOFRADO Y DESENCOFRADO RECTO | 2023-07-08 → 2023-12-01 (+146d) | 2023-07-10 → 2023-12-01 (+144d) | 3d → 1d | 79d → 32.22d | 2.02.04.11, 2.02.02.04 → 2.02.04.11 | resources none → CAPATAZ [31.4 h]; OPERARIO [62.8 h]; PEON [62.8 h] |
| 2.02.04.10 | ENCOFRADO Y DESENCOFRADO CURVO | 2023-07-08 → 2023-12-02 (+147d) | 2023-07-10 → 2023-12-05 (+148d) | 3d → 2.67d | 79d → 32.22d | 2.02.04.09 SS → 2.02.04.09 | resources none → CAPATAZ [8.14 h]; OPERARIO [16.29 h]; PEON [16.29 h] |
| 2.02.04.08 | CONCRETO f'c=280 kg/cm2 (Buzones) | 2023-07-11 → 2023-12-04 (+146d) | 2023-07-13 → 2023-12-04 (+144d) | 3d → 1d | 105d → 71.22d | 2.02.04.10, 2.02.02.02 → 2.02.04.10 SS+0.67d | resources none → OFICIAL [11.39 h]; OPERARIO [5.7 h]; PEON [56.96 h] |
| 2.02.04.06 | RELLENO COMÚN PARA ZANJAS | 2023-06-20 → 2023-12-05 (+168d) | 2023-06-22 → 2023-12-05 (+166d) | 3d → 1d | 143d → 71.22d | 2.02.04.12 → 2.02.04.05, 2.02.04.08 | resources none → Camión Cisterna 4x2 400 HP Agua (5000 gal) [78.59 h]; CAPATAZ [7.86 h]; CUADRADOR/VIGÍA [78.59 h]; PEON [314.36 h]; Rodillo Vib. Liso Autopropulsado 135 HP 12 TM [78.59 h] |
| 2.02.04.03 | RELLENO ESTRUCTURAL PARA OBRAS DE ARTE CON MATERIAL PROPIO | 2023-07-26 → 2023-12-06 (+133d) | 2023-07-28 → 2023-12-06 (+131d) | 3d → 1d | 107d → 32.22d | 2.02.04.08 FS+12d → 2.02.04.10 | resources none → CAPATAZ [1.17 h]; CUADRADOR/VIGÍA [11.65 h]; PEON [46.6 h]; Retroexcavador 58 HP [2.91 h]; Rodillo Vib. Liso Autopropulsado 135 HP 12 TM [11.65 h] |
| 5 | **CANALES** | 2023-06-11 → 2023-11-28 (+170d) | 2023-09-01 → 2024-01-18 (+139d) |  |  |  |  |
| 2.02.05.01 | EXCAVACIÓN ESTRUCTURAL PARA OBRAS DE ARTE | 2023-06-11 → 2023-11-28 (+170d) | 2023-06-15 → 2023-12-04 (+172d) | 5d → 5.67d | 38d → 10.33d | 2.02.04.01 → 2.02.04.01 SS | resources none → CAPATAZ [5.2 h]; CUADRADOR/VIGÍA [51.99 h]; PEON [207.98 h] |
| 2.02.05.03 | COLOCACIÓN DE CONCRETO f'c=100 kg/cm2 | 2023-06-16 → 2023-12-05 (+172d) | 2023-06-18 → 2023-12-05 (+170d) | 3d → 1d | 98d → 71.22d | 2.02.05.01, 2.02.04.07 → 2.02.05.01 | resources none → CAPATAZ [3.98 h]; OFICIAL [19.9 h]; OPERARIO [39.8 h]; PEON [198.99 h] |
| 2.02.05.06 | ACERO DE REFUERZO fy=4200 kg/cm2 | 2023-07-08 → 2023-12-06 (+151d) | 2023-07-19 → 2023-12-20 (+154d) | 12d → 10d | 79d → 71.22d | 2.02.05.03, 2.02.04.11 → 2.02.05.03, 2.02.04.06 | resources none → CAPATAZ [22.75 h]; OPERARIO [229.58 h]; PEON [229.58 h] |
| 2.02.05.05 | ENCOFRADO Y DESENCOFRADO | 2023-07-11 → 2023-12-11 (+153d) | 2023-08-08 → 2024-01-09 (+154d) | 29d → 22.67d | 79d → 71.22d | 2.02.05.06 SS+3d, 2.02.04.10 → 2.02.05.06 SS+2d | resources none → CAPATAZ [31.4 h]; OPERARIO [62.8 h]; PEON [62.8 h] |
| 2.02.05.07 | JUNTA WATER STOP SIN BULBO 150 mm | 2023-08-09 → 2023-12-14 (+127d) | 2023-08-11 → 2023-12-14 (+125d) | 3d → 1d | 100d → 87.22d | 2.02.05.04 SS → 2.02.05.05 SS+3d | resources none → OPERARIO [16.08 h]; PEON [16.08 h] |
| 2.02.05.04 | COLOCACIÓN DE CONCRETO f'c=280 kg/cm2 | 2023-08-09 → 2023-12-15 (+128d) | 2023-08-13 → 2023-12-18 (+127d) | 5d → 2.67d | 79d → 87.22d | 2.02.05.05, 2.02.04.08 → 2.02.05.07 | resources none → OFICIAL [174.63 h]; OPERARIO [87.31 h]; PEON [873.11 h] |
| 2.02.05.02 | RELLENO ESTRUCTURAL PARA CANALES, CON MATERIAL PROPIO | 2023-08-26 → 2024-01-10 (+137d) | 2023-09-01 → 2024-01-18 (+139d) | 7d → 7.67d | 79d → 71.22d | 2.02.05.04 FS+12d, 2.02.04.03, 2.02.04.05 → 2.02.05.05, 2.02.05.04 | resources none → CAPATAZ [13.06 h]; CUADRADOR/VIGÍA [130.48 h]; PEON [521.87 h]; Retroexcavador 58 HP [32.63 h]; Rodillo Vib. Liso Autopropulsado 135 HP 12 TM [130.48 h] |
| 3 | **RETORNO A3-OA-RE-D-21-55** | 2023-06-01 → 2023-11-28 (+180d) | 2023-07-24 → 2024-01-06 (+166d) |  |  |  |  |
| 1 | **MOVIMIENTO DE TIERRAS** | 2023-06-01 → 2023-11-28 (+180d) | 2023-07-20 → 2024-01-05 (+169d) |  |  |  |  |
| 2.03.01.01 | EXCAVACIÓN ESTRUCTURAL PARA OBRAS DE ARTE | 2023-06-01 → 2023-11-28 (+180d) | 2023-06-03 → 2023-11-28 (+178d) | 3d → 1d | 118d → 10.33d | TOPOGRAFÍA Y GEOREFERENCIACIÓN SS+4d → 2.02.05.01 SS | resources none → CAPATAZ [5.2 h]; CUADRADOR/VIGÍA [51.99 h]; PEON [207.98 h]; Retroexcavador 58 HP [51.99 h] |
| 2.03.01.02 | RELLENO ESTRUCTURAL PARA OBRAS DE ARTE, CON MATERIAL PROPIO | 2023-07-18 → 2024-01-05 (+171d) | 2023-07-20 → 2024-01-05 (+169d) | 3d → 1d | 122d → 81.56d | 2.03.02.02 FS+12d → 2.03.02.03 | resources none → CAPATAZ [4.86 h]; CUADRADOR/VIGÍA [48.57 h]; PEON [194.28 h]; Retroexcavador 58 HP [12.15 h]; Rodillo Vib. Liso Autopropulsado 135 HP 12 TM [48.57 h] |
| 2 | **OBRAS DE CONCRETO** | 2023-06-04 → 2023-11-29 (+178d) | 2023-07-05 → 2024-01-06 (+185d) |  |  |  |  |
| 2.03.02.01 | CONCRETO f'c=100 kg/cm2 | 2023-06-04 → 2023-11-29 (+178d) | 2023-06-06 → 2023-11-29 (+176d) | 3d → 1d | 118d → 10.33d |  | resources none → CAPATAZ [0.25 h]; OFICIAL [1.23 h]; OPERARIO [2.45 h]; PEON [12.27 h] |
| 2.03.02.05 | ACERO DE REFUERZO fy=4200 kg/cm2 | 2023-06-07 → 2023-11-30 (+176d) | 2023-06-30 → 2023-12-23 (+176d) | 24d → 18d | 118d → 10.33d | 2.03.02.03 SS → 2.03.02.01 | resources none → CAPATAZ [22.75 h]; OPERARIO [229.58 h]; PEON [229.58 h] |
| 2.03.02.04 | ENCOFRADO Y DESENCOFRADO | 2023-06-13 → 2023-12-07 (+177d) | 2023-06-30 → 2024-01-06 (+190d) | 18d → 21.67d | 118d → 32.22d | 2.03.02.05 SS+6d → 2.03.02.05 SS+5.67d, 2.02.04.03 | resources none → CAPATAZ [31.4 h]; OPERARIO [62.8 h]; PEON [62.8 h] |
| 2.03.02.06 | JUNTA WATER STOP SIN BULBO 150 mm | 2023-07-01 → 2023-12-26 (+178d) | 2023-07-05 → 2023-12-28 (+176d) | 5d → 3d | 137d → 81.56d | 2.03.02.02 SS → 2.03.02.05 | resources none → OPERARIO [16.08 h]; PEON [16.08 h] |
| 2.03.02.02 | CONCRETO f'c=280 kg/cm2 | 2023-07-01 → 2023-12-29 (+181d) | 2023-07-05 → 2024-01-02 (+181d) | 5d → 2.67d | 118d → 81.56d | 2.03.02.04 → 2.03.02.06 | resources none → OFICIAL [122.05 h]; OPERARIO [61.02 h]; PEON [610.24 h] |
| 2.03.02.03 | CONCRETO CICLÓPEO f'c=280 kg/cm2 + 30% P.G. | 2023-06-07 → 2024-01-03 (+210d) | 2023-06-11 → 2024-01-04 (+207d) | 5d → 2d | 118d → 81.56d | 2.03.02.01 → 2.03.02.02 | resources none → CAPATAZ [0.45 h]; OPERARIO [2.24 h]; PEON [4.48 h] |
| 3 | **ESTRUCTURAS METALICAS** | 2023-07-18 → 2024-01-03 (+169d) | 2023-07-24 → 2024-01-04 (+164d) |  |  |  |  |
| 2.03.03.01 | COMPUERTA METALICA PLANA DESLIZANTE DE 1.0x1.6 m | 2023-07-18 → 2024-01-03 (+169d) | 2023-07-21 → 2024-01-04 (+167d) | 4d → 2d | 118d → 83.56d | 2.03.02.02 FS+12d → 2.03.02.02 | resources none → OFICIAL [4 h]; OPERARIO [4 h]; PEON [12 h] |
| 2.03.03.02 | BARANDA DE FIERRO GALVANIZADO 1 1/2" | 2023-07-22 → 2024-01-03 (+165d) | 2023-07-24 → 2024-01-03 (+163d) | 3d → 1d | 118d → 83.56d | 2.03.03.01 → 2.03.03.01 SS | resources none → CAPATAZ [0.12 h]; OFICIAL [2.4 h]; OPERARIO [2.4 h]; PEON [1.2 h] |
| 4 | **REPOSICIÓN DE CANALES** | 2023-06-18 → 2023-12-23 (+188d) | 2023-11-16 → 2024-03-23 (+128d) |  |  |  |  |
| 1 | **REPOSICIÓN DE CANAL 1** | 2023-08-12 → 2023-12-23 (+133d) | 2023-11-16 → 2024-03-23 (+128d) |  |  |  |  |
| 1 | **MOVIMIENTO DE TIERRAS** | 2023-08-12 → 2023-12-23 (+133d) | 2023-11-16 → 2024-03-02 (+107d) |  |  |  |  |
| 2.04.01.01.01 | DEMOLICIÓN DE ESTRUCTURAS EXISTENTES | 2023-08-12 → 2023-12-23 (+133d) | 2023-08-28 → 2024-01-04 (+129d) | 17d → 8.33d | 83d → 10.33d | EXCAVACIÓN EN TERRENO NATURAL CON EQUIPO → 2.03.02.05 SS+17.33d | resources none → CAPATAZ [6.98 h]; CUADRADOR/VIGÍA [69.68 h]; Excavadora Sobre Oruga 260 HP [69.68 h]; OPERARIO [139.32 h]; PEON [139.32 h] |
| 2.04.01.01.02 | EXCAVACIÓN EN TERRENO NATURAL CON EQUIPO | 2023-07-11 → 2024-01-05 (+178d) | 2023-07-17 → 2024-01-08 (+175d) | 7d → 2.67d | 0d → 31.22d | CONFORMACIÓN DE DESVIO EN CAUCE DE RÍO - DIQUE A3-D-01 → 2.04.01.01.01 | resources none → CAPATAZ [2.42 h]; CUADRADOR/VIGÍA [23.12 h]; Excavadora Sobre Oruga 260 HP [23.12 h]; PEON [45.89 h]; Tractor S/Orugas (D6T) - 180 HP [23.12 h] |
| 2.04.01.01.03 | RELLENO ESTRUCTURAL PARA OBRAS DE ARTE CON MATERIAL PROPIO | 2023-10-09 → 2024-02-15 (+129d) | 2023-11-16 → 2024-03-02 (+107d) | 39d → 14d | 3d → 33.56d | 2.04.01.02.04 SS+20d, 2.04.02.01.03 → 2.04.01.02.04 | resources none → CAPATAZ [0.47 h]; CUADRADOR/VIGÍA [4.66 h]; PEON [18.62 h]; Retroexcavador 58 HP [1.16 h]; Rodillo Vib. Liso Autopropulsado 135 HP 12 TM [4.66 h] |
| 2 | **OBRAS DE CONCRETO** | 2023-08-26 → 2024-01-09 (+136d) | 2023-11-14 → 2024-03-23 (+130d) |  |  |  |  |
| 2.04.01.02.03 | CONCRETO f'c=100 kg/cm2 | 2023-08-26 → 2024-01-09 (+136d) | 2023-09-30 → 2024-01-18 (+110d) | 36d → 8.67d | 3d → 31.22d | EXCAVACIÓN EN TERRENO NATURAL CON EQUIPO SS+7d → 2.04.01.01.02, 2.03.02.04 | resources none → CAPATAZ [0.25 h]; OFICIAL [1.23 h]; OPERARIO [2.45 h]; PEON [12.27 h] |
| 2.04.01.02.02 | ACERO DE REFUERZO fy=4200 kg/cm2 | 2023-08-29 → 2024-01-19 (+143d) | 2023-11-06 → 2024-02-19 (+105d) | 70d → 25.33d | 3d → 31.22d | 2.04.01.02.03 SS+3d → 2.04.01.02.03 | resources none → CAPATAZ [22.75 h]; OPERARIO [229.58 h]; PEON [229.58 h] |
| 2.04.01.02.01 | ENCOFRADO Y DESENCOFRADO RECTO | 2023-09-05 → 2024-01-24 (+141d) | 2023-11-06 → 2024-03-23 (+138d) | 63d → 49d | 3d → 31.22d | 2.04.01.02.02 SS+7d → 2.04.01.02.02 SS+3.67d | resources none → CAPATAZ [31.4 h]; OPERARIO [62.8 h]; PEON [62.8 h] |
| 2.04.01.02.05 | JUNTA WATER STOP 6" | 2023-09-19 → 2024-01-26 (+129d) | 2023-11-11 → 2024-01-29 (+79d) | 54d → 2.67d | 8d → 33.56d | 2.04.01.02.04 SS → 2.04.01.02.01 SS+2d | resources none → OPERARIO [47.42 h]; PEON [47.42 h] |
| 2.04.01.02.04 | CONCRETO f'c=280 kg/cm2 | 2023-09-19 → 2024-01-29 (+132d) | 2023-11-11 → 2024-02-14 (+95d) | 54d → 14.33d | 3d → 33.56d | 2.04.01.02.01 SS+14d → 2.04.01.02.05 SS+1.67d | resources none → OFICIAL [122.05 h]; OPERARIO [61.02 h]; PEON [610.24 h] |
| 2.04.01.02.06 | MAMPOSTERIA DE PIEDRA, e=20cm, ACABADO CARA VISTA | 2023-11-12 → 2024-02-15 (+95d) | 2023-11-14 → 2024-02-15 (+93d) | 3d → 1d | 5d → 47.56d |  | resources none → CAPATAZ [0.24 h]; OFICIAL [2.4 h]; OPERARIO [2.4 h]; PEON [12 h] |
| 2 | **REPOSICIÓN DE CANAL 3** | 2023-06-18 → 2024-01-05 (+201d) | 2023-08-14 → 2024-03-07 (+206d) |  |  |  |  |
| 1 | **MOVIMIENTO DE TIERRAS** | 2023-06-18 → 2024-01-05 (+201d) | 2023-08-14 → 2024-03-06 (+205d) |  |  |  |  |
| 2.04.02.01.01 | DEMOLICIÓN DE ESTRUCTURAS EXISTENTES | 2023-06-18 → 2024-01-05 (+201d) | 2023-06-27 → 2024-01-11 (+198d) | 10d → 5.67d | 69d → 10.33d | 1.05.01.01 → 2.04.01.01.01 | resources none → CAPATAZ [6.98 h]; CUADRADOR/VIGÍA [69.68 h]; Excavadora Sobre Oruga 260 HP [69.68 h]; OPERARIO [139.32 h]; PEON [139.32 h] |
| 2.04.02.01.02 | EXCAVACIÓN EN TERRENO NATURAL CON EQUIPO | 2023-10-24 → 2024-01-12 (+80d) | 2023-10-27 → 2024-01-12 (+77d) | 4d → 1d | 5d → 31.56d | 1.06.01 → 2.04.02.01.01 | resources none → CAPATAZ [2.42 h]; CUADRADOR/VIGÍA [23.12 h]; Excavadora Sobre Oruga 260 HP [23.12 h]; PEON [45.89 h]; Tractor S/Orugas (D6T) - 180 HP [23.12 h] |
| 2.04.02.01.03 | RELLENO ESTRUCTURAL PARA OBRAS DE ARTE CON MATERIAL PROPIO | 2023-08-12 → 2024-03-06 (+207d) | 2023-08-14 → 2024-03-06 (+205d) | 3d → 1d | 58d → 31.56d | 2.04.02.02.05 FS+6d → 2.04.02.02.01, 2.04.01.01.03 | resources none → CAPATAZ [0.47 h]; CUADRADOR/VIGÍA [4.66 h]; PEON [18.62 h]; Retroexcavador 58 HP [1.16 h]; Rodillo Vib. Liso Autopropulsado 135 HP 12 TM [4.66 h] |
| 2 | **OBRAS DE CONCRETO** | 2023-07-13 → 2024-01-13 (+184d) | 2023-08-08 → 2024-03-07 (+212d) |  |  |  |  |
| 2.04.02.02.04 | CONCRETO f'c=100 kg/cm2 | 2023-07-13 → 2024-01-13 (+184d) | 2023-07-16 → 2024-01-16 (+184d) | 4d → 2.67d | 58d → 31.56d | EXCAVACIÓN EN TERRENO NATURAL CON EQUIPO → 2.04.02.01.02 | resources none → CAPATAZ [0.25 h]; OFICIAL [1.23 h]; OPERARIO [2.45 h]; PEON [12.27 h] |
| 2.04.02.02.03 | MALLA ELECTROSOLDADA DE DN6mm EN CUADRICULA 15x15 cm | 2023-07-17 → 2024-01-17 (+184d) | 2023-07-31 → 2024-02-21 (+205d) | 15d → 29.33d | 58d → 31.56d |  | resources none → CAPATAZ [74.09 h]; OPERARIO [740.91 h]; PEON [1481.82 h] |
| 2.04.02.02.02 | ENCOFRADO Y DESENCOFRADO RECTO | 2023-07-20 → 2024-02-01 (+196d) | 2023-07-31 → 2024-03-02 (+215d) | 12d → 25.33d | 58d → 31.56d | 2.04.02.02.01 SS → 2.04.02.02.03 SS+12.33d | resources none → CAPATAZ [31.4 h]; OPERARIO [62.8 h]; PEON [62.8 h] |
| 2.04.02.02.05 | CONCRETO f'c=280 kg/cm2 | 2023-08-01 → 2024-02-22 (+205d) | 2023-08-05 → 2024-02-26 (+205d) | 5d → 3.67d | 58d → 31.56d | 2.04.02.02.02 → 2.04.02.02.03 | resources none → OFICIAL [122.05 h]; OPERARIO [61.02 h]; PEON [610.24 h] |
| 2.04.02.02.06 | SELLO DE JUNTA CONSTRUCCIÓN CON MATERIAL ELASTOMÉRICO | 2023-07-20 → 2024-02-27 (+222d) | 2023-07-29 → 2024-03-06 (+221d) | 10d → 7.67d | 113d → 31.56d | 2.04.02.02.01 SS → 2.04.02.02.05 | resources none → CAPATAZ [12.36 h]; OFICIAL [123.55 h]; PEON [123.55 h] |
| 2.04.02.02.01 | ENCOFRADO Y DESENCOFRADO PARA REVESTIMIENTO DE CANALES (CERCHAS) | 2023-07-20 → 2024-03-04 (+228d) | 2023-07-31 → 2024-03-05 (+218d) | 12d → 2d | 58d → 31.56d | 2.04.02.02.03 SS+3d → 2.04.02.02.02 | resources none → CAPATAZ [7.21 h]; OPERARIO [14.41 h]; PEON [14.41 h] |
| 2.04.02.02.07 | MAMPOSTERIA DE PIEDRA, e=20cm, ACABADO CARA VISTA | 2023-08-06 → 2024-03-07 (+214d) | 2023-08-08 → 2024-03-07 (+212d) | 3d → 1d | 103d → 31.56d | 2.04.02.02.05 → 2.04.02.02.06, 2.04.01.02.06, 2.04.02.01.03 | resources none → CAPATAZ [0.24 h]; OFICIAL [2.4 h]; OPERARIO [2.4 h]; PEON [12 h] |
| 3 | **REPOSICIÓN SIFON INOPERATIVO** | 2023-07-04 → 2024-01-12 (+192d) | 2023-08-12 → 2024-02-14 (+186d) |  |  |  |  |
| 2.05.01 | DEMOLICIÓN DE ESTRUCTURAS EXISTENTES | 2023-07-04 → 2024-01-12 (+192d) | 2023-07-06 → 2024-01-12 (+190d) | 3d → 1d | 99d → 10.33d | DESCOLMATACIÓN DE CAUCE NATURAL DEL RÍO LACRAMARCA - DIQUE A3-D-01, DESCOLMATACIÓN DE CAUCE NATURAL DEL RÍO LACRAMARCA - DIQUE A3-I-01 → 2.04.02.01.01 | resources none → CAPATAZ [6.98 h]; CUADRADOR/VIGÍA [69.68 h]; Excavadora Sobre Oruga 260 HP [69.68 h]; OPERARIO [139.32 h]; PEON [139.32 h] |
| 2.05.02 | EXCAVACIÓN ESTRUCTURAL PARA OBRAS DE ARTE | 2023-07-07 → 2024-01-13 (+190d) | 2023-07-16 → 2024-01-26 (+194d) | 10d → 11.33d | 99d → 10.33d |  | resources none → CAPATAZ [5.2 h]; CUADRADOR/VIGÍA [51.99 h]; PEON [207.98 h]; Retroexcavador 58 HP [51.99 h] |
| 2.05.03 | COLOCACIÓN CAMA DE ARENA | 2023-07-17 → 2024-01-27 (+194d) | 2023-07-19 → 2024-01-27 (+192d) | 3d → 0.67d | 108d → 10.33d |  | resources none → CAPATAZ [1.47 h]; PEON [11.79 h] |
| 2.05.06 | TUBERÍAS DE 14" HDPE SDR21 DN 355mm | 2023-07-20 → 2024-01-29 (+193d) | 2023-07-25 → 2024-02-07 (+197d) | 6d → 8.67d | 108d → 10.33d |  | resources none → CAPATAZ [7 h]; OPERARIO [70.06 h]; PEON [210.21 h]; Retroexcavador 58 HP [70.06 h] |
| 2.05.05 | RELLENO COMÚN | 2023-07-26 → 2024-02-08 (+197d) | 2023-08-03 → 2024-02-13 (+194d) | 9d → 4.44d | 108d → 11.56d |  | resources none → Camión Cisterna 4x2 400 HP Agua (5000 gal) [28.57 h]; CAPATAZ [2.86 h]; CUADRADOR/VIGÍA [28.57 h]; PEON [114.27 h]; Rodillo Vib. Liso Autopropulsado 135 HP 12 TM [28.57 h] |
| 2.05.11 | CODOS HDPE DE 14" DN 355mm | 2023-07-20 → 2024-02-08 (+203d) | 2023-07-25 → 2024-02-08 (+198d) | 6d → 1d | 117d → 10.33d | 2.05.06 SS → 2.05.06 | resources none → CAPATAZ [0.32 h]; OPERARIO [3.2 h]; PEON [9.6 h] |
| 2.05.07 | CONCRETO f'c=100 kg/cm2 | 2023-07-17 → 2024-02-09 (+207d) | 2023-07-19 → 2024-02-09 (+205d) | 3d → 1d | 99d → 10.33d | 2.05.02 → 2.05.11 | resources none → CAPATAZ [0.25 h]; OFICIAL [1.23 h]; OPERARIO [2.45 h]; PEON [12.27 h] |
| 2.05.10 | ACERO DE REFUERZO fy=4200 kg/cm2 | 2023-07-20 → 2024-02-10 (+205d) | 2023-07-22 → 2024-02-10 (+203d) | 3d → 0.67d | 99d → 10.33d |  | resources none → CAPATAZ [22.75 h]; OPERARIO [229.58 h]; PEON [229.58 h] |
| 2.05.09 | ENCOFRADO Y DESENCOFRADO RECTO | 2023-07-23 → 2024-02-12 (+204d) | 2023-07-25 → 2024-02-12 (+202d) | 3d → 1d | 99d → 10.33d |  | resources none → CAPATAZ [31.4 h]; OPERARIO [62.8 h]; PEON [62.8 h] |
| 2.05.08 | CONCRETO f'c=280 kg/cm2 | 2023-07-26 → 2024-02-13 (+202d) | 2023-07-28 → 2024-02-13 (+200d) | 3d → 1d | 99d → 10.33d |  | resources none → OFICIAL [122.05 h]; OPERARIO [61.02 h]; PEON [610.24 h] |
| 2.05.04 | RELLENO ESTRUCTURAL PARA OBRAS DE ARTE CON MATERIAL PROPIO | 2023-08-10 → 2024-02-14 (+188d) | 2023-08-12 → 2024-02-14 (+186d) | 3d → 1d | 99d → 10.33d | 2.05.08 FS+12d → 2.05.08, 2.05.05 FF | resources none → CAPATAZ [0.47 h]; CUADRADOR/VIGÍA [4.66 h]; PEON [18.62 h] |
| 3 | **ARQUITECTURA Y PAISAJISMO** | 2023-08-22 → 2024-02-20 (+182d) | 2023-11-03 → 2024-04-19 (+168d) |  |  |  |  |
| 1 | **OBRAS PRELIMINARES** | 2023-08-22 → 2024-02-20 (+182d) | 2023-11-03 → 2024-02-28 (+117d) |  |  |  |  |

| ID | Task | Start | Finish | Duration | Total float | Predecessors | Other |
| --- | --- | --- | --- | --- | --- | --- | --- |
| 04.01.02 | TRAZO Y REPLANTEO PRELIMINAR | 2023-08-24 → 2024-02-21 (+181d) | 2023-08-25 → 2024-02-28 (+187d) | 2d → 6.67d | 16d → 10.33d | MOVILIZACIÓN DE EQUIPOS Y HERRAMIENTAS (ARQUITECTURA Y PAISAJISMO) → 04.01.01 | resources none → OPERARIO [55.06 h]; PEON [110.12 h]; TOPOGRAFO [55.06 h] |
| 2 | **MOVIMIENTO DE TIERRAS** | 2023-08-26 → 2024-02-29 (+187d) | 2023-09-11 → 2024-03-12 (+183d) |  |  |  |  |
| 04.02.01 | EXCAVACIÓN MANUAL PARA INSTALACIÓN DE BORDILLOS Y CIMENTACIONES | 2023-08-26 → 2024-02-29 (+187d) | 2023-08-27 → 2024-02-29 (+186d) | 2d → 1d | 16d → 10.33d |  | resources none → CAPATAZ [0.76 h]; PEON [7.57 h] |
| 04.02.02 | EXCAVACIÓN PARA MEJORAMIENTO DE SUELO CON TIERRA VEGETAL | 2023-08-28 → 2024-02-29 (+185d) | 2023-09-11 → 2024-03-11 (+182d) | 15d → 9.33d | 16d → 10.33d | 04.02.01 → 04.02.01 SS | resources none → CAPATAZ [7.86 h]; PEON [78.63 h] |
| 04.02.03 | ELIMINACION DE MATERIAL EXCEDENTE (DME´S) | 2023-08-26 → 2024-03-12 (+199d) | 2023-09-11 → 2024-03-12 (+183d) | 17d → 1d | 67d → 10.33d | 04.02.01 SS → 04.02.02 | resources none → Camión Volquete (15 m3) [0.74 h]; CAPATAZ [0.12 h]; Excavadora Sobre Oruga 260 HP [0.25 h]; OPERARIO [0.25 h]; PEON [1.49 h]; Tractor S/Orugas (D6T) - 180 HP [0.25 h] |
| 3 | **PAVIMENTOS, RECUBRIMIENTOS Y BORDILLOS** | 2023-09-12 → 2024-03-13 (+183d) | 2023-09-22 → 2024-04-03 (+194d) |  |  |  |  |
| 04.03.01 | PISO DE GRAVILLA | 2023-09-12 → 2024-03-13 (+183d) | 2023-09-13 → 2024-03-13 (+182d) | 2d → 1d | 16d → 10.33d | 04.02.02 → 04.02.03 | resources none → CAPATAZ [0.2 h]; OPERARIO [2 h]; PEON [3.99 h] |
| 04.03.02 | RECUBRIMIENTO DE PIEDRA DEL LUGAR e=0.05cm | 2023-09-14 → 2024-03-14 (+182d) | 2023-09-17 → 2024-03-23 (+188d) | 4d → 8.33d | 16d → 10.33d |  | resources none → CAPATAZ [6.52 h]; OFICIAL [130.46 h]; PEON [130.46 h] |
| 04.03.03 | BORDILLOS DE PIEDRA DEL LUGAR | 2023-09-18 → 2024-03-25 (+189d) | 2023-09-22 → 2024-04-03 (+194d) | 5d → 6.67d | 16d → 10.33d |  | resources none → CAPATAZ [4.96 h]; OFICIAL [99.2 h]; PEON [99.2 h] |
| 4 | **MOBILIARIOS, BARANDAS Y ESCALERAS** | 2023-09-23 → 2024-04-04 (+194d) | 2023-10-30 → 2024-04-11 (+164d) |  |  |  |  |
| 04.04.01 | ESCALERA DE CONCRETO SOBRE ENROCADO, CIMENTACION Y ANCLAJE | 2023-09-23 → 2024-04-04 (+194d) | 2023-10-02 → 2024-04-04 (+185d) | 10d → 1d | 16d → 10.33d |  |  |
| 04.04.02 | BARANDA DE MADERA EUCALIPTO CON SOGA, INCLUYE CIMENTACIÓN | 2023-10-03 → 2024-04-04 (+184d) | 2023-10-06 → 2024-04-04 (+181d) | 4d → 1d | 16d → 10.33d | 04.04.01 → 04.04.01 SS | resources none → CAPATAZ [0.36 h]; PEON [14.4 h] |
| 04.04.03 | TACHOS DE BASURA, INCLUYE CIMENTACIÓN | 2023-10-07 → 2024-04-04 (+180d) | 2023-10-09 → 2024-04-04 (+178d) | 3d → 1d | 16d → 10.33d | 04.04.02 → 04.04.01 SS, 04.04.02 SS |  |
| 04.04.04 | BANCAS DE CONCRETO, INCLUYE CIMENTACIÓN | 2023-10-10 → 2024-04-05 (+178d) | 2023-10-19 → 2024-04-05 (+169d) | 10d → 1d | 16d → 10.33d |  |  |
| 04.04.05 | POSTES DE ILUMINACIÓN, INCLUYE LUMINARIA Y CIMENTACIÓN | 2023-10-20 → 2024-04-06 (+169d) | 2023-10-24 → 2024-04-10 (+169d) | 5d → 3.89d | 16d → 10.33d |  | resources none → CAPATAZ [3.2 h]; OPERARIO [3.2 h]; PEON [64 h] |
| 04.04.07 | BOLARDOS DE PIEDRA | 2023-10-28 → 2024-04-08 (+163d) | 2023-10-30 → 2024-04-10 (+163d) |  | 16d → 10.33d | 04.04.06 → 04.04.05 SS+0.89d | resources none → CAPATAZ [2.4 h]; PEON [6 h] |
| 04.04.06 | SEÑALETICA INFORMATIVA | 2023-10-25 → 2024-04-11 (+169d) | 2023-10-27 → 2024-04-11 (+167d) | 3d → 1d | 16d → 17.67d |  |  |
| 04.11.01 | ALCORQUES DE PIEDRA DE CANTO RODADO PARA ARBOLES | 2023-10-31 → 2024-04-19 (+171d) | 2023-11-01 → 2024-04-19 (+170d) | 2d → 1d | 16d → 10.33d | 04.04.07 → 04.10.05 | resources none → CAPATAZ [0.02 h]; OFICIAL [0.2 h]; PEON [0.4 h] |
| 4 | **PROGRAMA DE CIERRE DE OBRA** | 2023-06-02 → 2024-04-10 (+313d) | 2023-11-16 → 2024-05-04 (+170d) |  |  |  |  |
| 5.012 | RESTAURACIÓN DE ÁREAS DE INSTALACIONES PROVISIONALES | 2023-11-09 → 2024-04-10 (+153d) | 2023-11-16 → 2024-04-25 (+161d) | 8d → 12d | 3d → 6.24d | CONFORMACIÓN DE CUERPO DE DIQUE CON MATERIAL PROPIO, ACONDICIONAMIENTO DE DEPOSITOS DE MATERIALES EXCEDENTES (DME) → 1.06.05.08 FS+4.65d, 2.02.01.02, 2.02.03.05, 2.02.05.02, 2.03.01.02, 2.03.03.02, 2.04.02.02.07 | resources none → Camión Cisterna 4x2 400 HP Agua (5000 gal) [2342.82 h]; CAPATAZ [2306.82 h]; CUADRADOR/VIGÍA [2302.82 h]; Motoniveladora 185 HP [40 h]; OPERARIO [2302.82 h]; PEON [2462.82 h]; Retroexcavador 58 HP [1138.47 h]; Rodillo Vib. Liso Autopropulsado 135 HP 12 TM [40 h]; Tractor S/Orugas (D6T) - 180 HP [2342.82 h] |

## Version 4 (data date 2023-10-15, saved 2023-09-19, file Cronograma OHLA..xer)

Last finish 2024-05-04 → 2024-04-27 (-7d).

Added:

| ID | Task | Duration | Start | Finish | Predecessors |
| --- | --- | --- | --- | --- | --- |
| 0 | **HITOS** |  | 2023-10-15 | 2024-04-25 |  |
| A1000 | KICK OFF MEETING | 0d | 2023-10-15 | 2023-10-15 |  |
| A1010 | INICIO DEL SERVICIO | 0d | 2023-10-31 | 2023-10-31 | A1000 FS+16d |
| A1015 | INICIO DE EXCAVACIÓN | 0d | 2023-11-05 | 2023-11-05 | A1060 SS+5d |
| A1016 | INICIO DE RELLENO DE DIQUE | 0d | 2023-11-27 | 2023-11-27 | A1340 FS+1d |
| A1020 | FIN DEL SERVICIO | 0d | 2024-04-25 | 2024-04-25 | A1200, A2220, A2490, A1760, A1780, A1070, A2760, A2700, A1050, A2210, A4020, A3850, A3790, A3780, A3740, A3730, A3640, A3630, A3580, A3560, A3550, A3530, A3470, A3450, A3400, A3260, A3160, A3140, A3130, A3080, A2930, A2880, A4130, A4150, A4160, A2702, A1950 |
| A1030 | CARTEL DE IDENTIFICACIÓN OBRA 4.80 x 3.60 m. | 2d | 2023-11-02 | 2023-11-03 | A1060 SS+2d |
| A1060 | MOVILIZACION DE EQUIPOS | 31d | 2023-10-31 | 2023-11-30 | A1010 |
| A1070 | TOPOGRAFÍA Y GEOREFERENCIACIÓN | 174d | 2023-11-02 | 2024-04-23 | A1060 SS+2d |
| A1080 | DESMOVILIZACION DE EQUIPOS | 23d | 2024-04-05 | 2024-04-27 | A1020 FF+2d |
| A1100 | MEJORAMIENTO DE VIAS EXISTENTES | 17d | 2023-11-05 | 2023-11-21 | A1090 SS |
| 4 | **DESCOLMATACIÓN DE CAUCE Y OBRAS AUXILIARES** |  | 2023-11-06 | 2024-02-25 |  |
| 1 | **DESBROCE Y DESCOLMATACIÓN** |  | 2023-11-06 | 2024-01-30 |  |
| A1230 | DESCOLMATACIÓN DE CAUCE NATURAL DEL RÍO LACRAMARCA - DIQUE A3-D-01 | 10d | 2023-11-06 | 2023-11-15 | A1220 SS |
| A1880 | DESCOLMATACIÓN DE CAUCE NATURAL DEL RÍO LACRAMARCA - DIQUE A3-I-01 | 32d | 2023-11-06 | 2023-12-07 | A1230 SS |
| A1870 | DESCOLMATACIÓN DE CAUCE NATURAL DEL RÍO LACRAMARCA - DIQUE A3-D-02 | 53d | 2023-11-16 | 2024-01-07 | A1230 |
| A1890 | DESCOLMATACIÓN DE CAUCE NATURAL DEL RÍO LACRAMARCA - DIQUE A3-I-02 | 20d | 2023-12-08 | 2023-12-27 | A1880 |
| A1900 | DESCOLMATACIÓN DE CAUCE NATURAL DEL RÍO LACRAMARCA - DIQUE A3-I-03 | 34d | 2023-12-28 | 2024-01-30 | A1890 |
| 2 | **DESVIO DEL CAUCE** |  | 2023-11-07 | 2024-02-25 |  |
| 1 | **A3-D-01** |  | 2023-12-11 | 2023-12-20 |  |
| A1240 | CONFORMACIÓN DE DESVIO EN CAUCE DE RÍO - DIQUE A3-D-01 | 5d | 2023-12-11 | 2023-12-15 | A1330 SS+9d |
| A1250 | RELLENO NO ESTRUCTURAL CON MATERIAL PROPIO - DIQUE A3-D-01 | 7d | 2023-12-14 | 2023-12-20 | A1330 |
| 2 | **A3-D-02** |  | 2023-12-28 | 2024-02-25 |  |
| A1790 | CONFORMACIÓN DE DESVIO EN CAUCE DE RÍO - DIQUE A3-D-02 - TRAMO 1 | 5d | 2023-12-28 | 2024-01-01 | A1870 SS+2d, A1510 FF+2d |
| A1800 | RELLENO NO ESTRUCTURAL CON MATERIAL PROPIO - DIQUE A3-D-02 - TRAMO 1 | 7d | 2024-01-02 | 2024-01-08 | A1790 |
| A2650 | CONFORMACIÓN DE DESVIO EN CAUCE DE RÍO - DIQUE A3-D-02 - TRAMO 3 | 5d | 2024-01-09 | 2024-01-13 | A1800 |
| A2660 | RELLENO NO ESTRUCTURAL CON MATERIAL PROPIO - DIQUE A3-D-02 - TRAMO 3 | 7d | 2024-01-14 | 2024-01-20 | A2650 |
| A2670 | CONFORMACIÓN DE DESVIO EN CAUCE DE RÍO - DIQUE A3-D-02 - TRAMO 4 | 5d | 2024-01-21 | 2024-01-25 | A2660 |
| A2680 | RELLENO NO ESTRUCTURAL CON MATERIAL PROPIO - DIQUE A3-D-02 - TRAMO 4 | 7d | 2024-01-26 | 2024-02-01 | A2670 |
| A2690 | CONFORMACIÓN DE DESVIO EN CAUCE DE RÍO - DIQUE A3-D-02 - TRAMO 5 | 5d | 2024-02-02 | 2024-02-06 | A2680 |
| A2700 | RELLENO NO ESTRUCTURAL CON MATERIAL PROPIO - DIQUE A3-D-02 - TRAMO 5 | 7d | 2024-02-07 | 2024-02-13 | A2690 |
| A2701 | CONFORMACIÓN DE DESVIO EN CAUCE DE RÍO - DIQUE A3-D-02 - TRAMO 2 | 5d | 2024-02-14 | 2024-02-18 | A2700 |
| A2702 | RELLENO NO ESTRUCTURAL CON MATERIAL PROPIO - DIQUE A3-D-02 - TRAMO 2 | 7d | 2024-02-19 | 2024-02-25 | A2701 |
| 3 | **A3-I-01** |  | 2023-11-07 | 2024-01-06 |  |
| A1810 | CONFORMACIÓN DE DESVIO EN CAUCE DE RÍO - DIQUE A3-I-01 | 5d | 2023-11-07 | 2023-11-11 | A1880 SS+1d |
| A1820 | RELLENO NO ESTRUCTURAL CON MATERIAL PROPIO - DIQUE A3-I-01 | 7d | 2023-12-31 | 2024-01-06 | A1510 |
| 4 | **A3-I-02** |  | 2023-12-11 | 2024-01-30 |  |
| A1830 | CONFORMACIÓN DE DESVIO EN CAUCE DE RÍO - DIQUE A3-I-02 | 5d | 2023-12-11 | 2023-12-15 | A1890 SS+2d, A1330 FF+2d |
| A1840 | RELLENO NO ESTRUCTURAL CON MATERIAL PROPIO - DIQUE A3-I-02 | 7d | 2024-01-24 | 2024-01-30 | A1600, A1820 |
| 5 | **A3-I-03** |  | 2024-01-02 | 2024-02-18 |  |
| A1845 | CONFORMACIÓN DE DESVIO EN CAUCE DE RÍO - DIQUE A3-I-03 - TRAMO 2 | 5d | 2024-01-02 | 2024-01-06 | A1790 |
| A1846 | RELLENO NO ESTRUCTURAL CON MATERIAL PROPIO - DIQUE A3-I-03 -TRAMO 2 | 7d | 2024-01-07 | 2024-01-13 | A1845 |
| A1850 | CONFORMACIÓN DE DESVIO EN CAUCE DE RÍO - DIQUE A3-I-03 - TRAMO 1 | 5d | 2024-01-14 | 2024-01-18 | A1846 |
| A1860 | RELLENO NO ESTRUCTURAL CON MATERIAL PROPIO - DIQUE A3-I-03 -TRAMO 1 | 7d | 2024-01-19 | 2024-01-25 | A1850 |
| A2730 | CONFORMACIÓN DE DESVIO EN CAUCE DE RÍO - DIQUE A3-I-03 - TRAMO 3 | 5d | 2024-01-26 | 2024-01-30 | A1860 |
| A2740 | RELLENO NO ESTRUCTURAL CON MATERIAL PROPIO - DIQUE A3-I-03 -TRAMO 3 | 7d | 2024-01-31 | 2024-02-06 | A2730 |
| A2750 | CONFORMACIÓN DE DESVIO EN CAUCE DE RÍO - DIQUE A3-I-03 - TRAMO 4 | 5d | 2024-02-07 | 2024-02-11 | A2740 |
| A2760 | RELLENO NO ESTRUCTURAL CON MATERIAL PROPIO - DIQUE A3-I-03 -TRAMO 4 | 7d | 2024-02-12 | 2024-02-18 | A2750 |
| 1 | **TRAMO 1** |  | 2023-12-16 | 2024-01-08 |  |
| 2 | **TRAMO 2 (PROG 22+500 - 22+860)** |  | 2024-03-21 | 2024-04-13 |  |
| 3 | **TRAMO 3** |  | 2024-01-09 | 2024-02-01 |  |
| 4 | **TRAMO 4** |  | 2024-02-02 | 2024-02-25 |  |
| 5 | **TRAMO 5** |  | 2024-02-26 | 2024-03-20 |  |
| A2190 | EXCAVACIÓN DE UÑA CON EQUIPO | 11d | 2024-02-27 | 2024-03-08 | A2180 SS+1d, A2100 |
| A2200 | PERFILADO Y COMPACTACIÓN EN ZONA DE CORTE | 12d | 2024-02-27 | 2024-03-09 | A2180 SS+1d |
| A2230 | GEOTEXTIL NO TEJIDO 400 G/M2, INC. COLOCACIÓN | 12d | 2024-02-28 | 2024-03-10 | A2200 SS+1d |
| A2240 | COLOCACION Y ACOMODO DE ROCA EN UÑA DE DIQUE | 16d | 2024-03-01 | 2024-03-16 | A2230 SS+2d |
| A2250 | COLOCACION Y ACOMODO DE ROCA EN TALUD DE DIQUE | 15d | 2024-03-03 | 2024-03-17 | A2240 SS+2d |
| A2260 | PREPARACIÓN DE FUNDACIÓN DE CUERPO DE DIQUE | 5d | 2024-03-06 | 2024-03-10 | A2180 |
| A2210 | CONFORMACIÓN DE CUERPO DE DIQUE CON MATERIAL PROPIO | 5d | 2024-03-07 | 2024-03-11 | A2260 SS+1d, A2120 |
| A2220 | CONFORMACIÓN DE CORONA DE DIQUE CON MATERIAL PROPIO | 6d | 2024-03-15 | 2024-03-20 | A2250 FF+3d, A2130 |
| 1 | **Sector liberado** |  | 2023-12-16 | 2024-01-02 |  |
| A1450 | EXCAVACIÓN DE UÑA CON EQUIPO | 6d | 2023-12-17 | 2023-12-22 | A1440 SS+1d |
| A1460 | PERFILADO Y COMPACTACIÓN EN ZONA DE CORTE | 7d | 2023-12-17 | 2023-12-23 | A1440 SS+1d |
| A1520 | PREPARACIÓN DE FUNDACIÓN DE CUERPO DE DIQUE | 5d | 2023-12-17 | 2023-12-21 | A1460 SS |
| A1470 | CONFORMACIÓN DE CUERPO DE DIQUE CON MATERIAL PROPIO | 5d | 2023-12-18 | 2023-12-22 | A1520 SS+1d |
| A1490 | GEOTEXTIL NO TEJIDO 400 G/M2, INC. COLOCACIÓN | 4d | 2023-12-20 | 2023-12-23 | A1470 SS+2d |
| A1500 | COLOCACION Y ACOMODO DE ROCA EN UÑA DE DIQUE | 4d | 2023-12-22 | 2023-12-25 | A1490 SS+2d |
| A1510 | COLOCACION Y ACOMODO DE ROCA EN TALUD DE DIQUE | 7d | 2023-12-24 | 2023-12-30 | A1500 SS+2d |
| A1480 | CONFORMACIÓN DE CORONA DE DIQUE CON MATERIAL PROPIO | 3d | 2023-12-31 | 2024-01-02 | A1510 FF+3d |
| 2 | **Sector por Liberar - Km 20+980 - km 21+300** |  | 2024-01-03 | 2024-01-22 |  |
| A4040 | EXCAVACIÓN DE UÑA CON EQUIPO | 3d | 2024-01-06 | 2024-01-08 | A4030 SS+3d |
| A4050 | PERFILADO Y COMPACTACIÓN EN ZONA DE CORTE | 4d | 2024-01-07 | 2024-01-10 | A4030 |
| A4110 | PREPARACIÓN DE FUNDACIÓN DE CUERPO DE DIQUE | 3d | 2024-01-08 | 2024-01-10 | A4050 SS+1d |
| A4060 | CONFORMACIÓN DE CUERPO DE DIQUE CON MATERIAL PROPIO | 3d | 2024-01-09 | 2024-01-11 | A4110 SS+1d, A4040 |
| A4080 | GEOTEXTIL NO TEJIDO 400 G/M2, INC. COLOCACIÓN | 2d | 2024-01-11 | 2024-01-12 | A4060 SS+2d, A4050 |
| A4090 | COLOCACION Y ACOMODO DE ROCA EN UÑA DE DIQUE | 2d | 2024-01-13 | 2024-01-14 | A4080 |
| A4100 | COLOCACION Y ACOMODO DE ROCA EN TALUD DE DIQUE | 5d | 2024-01-15 | 2024-01-19 | A4090 |
| A4070 | CONFORMACIÓN DE CORONA DE DIQUE CON MATERIAL PROPIO | 2d | 2024-01-21 | 2024-01-22 | A4100 FF+3d |
| A1530 | EXCAVACIÓN EN TERRENO NATURAL CON EQUIPO | 15d | 2024-01-02 | 2024-01-16 | A1790 |
| A1540 | EXCAVACIÓN DE UÑA CON EQUIPO | 14d | 2024-01-03 | 2024-01-16 | A1530 SS+1d, A1450 |
| A1550 | PERFILADO Y COMPACTACIÓN EN ZONA DE CORTE | 11d | 2024-01-06 | 2024-01-16 | A1530 SS+4d |
| A1580 | GEOTEXTIL NO TEJIDO 400 G/M2, INC. COLOCACIÓN | 11d | 2024-01-08 | 2024-01-18 | A1550 SS+2d |
| A1590 | COLOCACION Y ACOMODO DE ROCA EN UÑA DE DIQUE | 10d | 2024-01-10 | 2024-01-19 | A1580 SS+2d |
| A1610 | PREPARACIÓN DE FUNDACIÓN DE CUERPO DE DIQUE | 3d | 2024-01-10 | 2024-01-12 | A1530 SS+8d |
| A1560 | CONFORMACIÓN DE CUERPO DE DIQUE CON MATERIAL PROPIO | 3d | 2024-01-11 | 2024-01-13 | A1610 SS+1d |
| A1600 | COLOCACION Y ACOMODO DE ROCA EN TALUD DE DIQUE | 12d | 2024-01-12 | 2024-01-23 | A1590 SS+2d |
| A1570 | CONFORMACIÓN DE CORONA DE DIQUE CON MATERIAL PROPIO | 6d | 2024-01-20 | 2024-01-25 | A1600 SS+8d |
| 1 | **TRAMO 1** |  | 2024-02-12 | 2024-03-07 |  |
| A1620 | EXCAVACIÓN EN TERRENO NATURAL CON EQUIPO | 7d | 2024-02-12 | 2024-02-18 | A2310 |
| A1630 | EXCAVACIÓN DE UÑA CON EQUIPO | 11d | 2024-02-13 | 2024-02-23 | A1620 SS+1d |
| A1640 | PERFILADO Y COMPACTACIÓN EN ZONA DE CORTE | 12d | 2024-02-13 | 2024-02-24 | A1620 SS+1d |
| A1670 | GEOTEXTIL NO TEJIDO 400 G/M2, INC. COLOCACIÓN | 12d | 2024-02-14 | 2024-02-25 | A1640 SS+1d |
| A1680 | COLOCACION Y ACOMODO DE ROCA EN UÑA DE DIQUE | 16d | 2024-02-16 | 2024-03-02 | A1670 SS+2d |
| A1690 | COLOCACION Y ACOMODO DE ROCA EN TALUD DE DIQUE | 15d | 2024-02-18 | 2024-03-03 | A1680 SS+2d |
| A1700 | PREPARACIÓN DE FUNDACIÓN DE CUERPO DE DIQUE | 5d | 2024-02-19 | 2024-02-23 | A1620 |
| A1660 | CONFORMACIÓN DE CORONA DE DIQUE CON MATERIAL PROPIO | 6d | 2024-02-29 | 2024-03-05 | A1690 SS+11d |
| A1650 | CONFORMACIÓN DE CUERPO DE DIQUE CON MATERIAL PROPIO | 5d | 2024-03-03 | 2024-03-07 | A1690 SS+14d, A1630, A1700 |
| 2 | **TRAMO 2** |  | 2024-01-26 | 2024-04-25 |  |
| 1 | **Sector liberado** |  | 2024-01-26 | 2024-02-11 |  |
| A2270 | EXCAVACIÓN EN TERRENO NATURAL CON EQUIPO | 4d | 2024-01-26 | 2024-01-29 | A1570 |
| A2280 | EXCAVACIÓN DE UÑA CON EQUIPO | 7d | 2024-01-27 | 2024-02-02 | A2270 SS+1d |
| A2290 | PERFILADO Y COMPACTACIÓN EN ZONA DE CORTE | 8d | 2024-01-27 | 2024-02-03 | A2270 SS+1d |
| A2320 | GEOTEXTIL NO TEJIDO 400 G/M2, INC. COLOCACIÓN | 7d | 2024-01-28 | 2024-02-03 | A2290 SS+1d |
| A2330 | COLOCACION Y ACOMODO DE ROCA EN UÑA DE DIQUE | 10d | 2024-01-30 | 2024-02-08 | A2320 SS+2d |
| A2350 | PREPARACIÓN DE FUNDACIÓN DE CUERPO DE DIQUE | 3d | 2024-01-30 | 2024-02-01 | A2270 |
| A2300 | CONFORMACIÓN DE CUERPO DE DIQUE CON MATERIAL PROPIO | 3d | 2024-01-31 | 2024-02-02 | A2350 SS+1d |
| A2340 | COLOCACION Y ACOMODO DE ROCA EN TALUD DE DIQUE | 9d | 2024-02-01 | 2024-02-09 | A2330 SS+2d |
| A2310 | CONFORMACIÓN DE CORONA DE DIQUE CON MATERIAL PROPIO | 3d | 2024-02-09 | 2024-02-11 | A2340 SS+8d |
| 2 | **Sector por Liberar - Km 23+760 - km 24+100** |  | 2024-04-04 | 2024-04-25 |  |
| A4120 | EXCAVACIÓN EN TERRENO NATURAL CON EQUIPO | 3d | 2024-04-04 | 2024-04-06 | A2450 SS+5d |
| A4130 | EXCAVACIÓN DE UÑA CON EQUIPO | 4d | 2024-04-06 | 2024-04-09 | A4120 SS+2d |
| A4140 | PERFILADO Y COMPACTACIÓN EN ZONA DE CORTE | 5d | 2024-04-08 | 2024-04-12 | A4120 SS+1d, A4130 SS+2d |
| A4200 | PREPARACIÓN DE FUNDACIÓN DE CUERPO DE DIQUE | 2d | 2024-04-08 | 2024-04-09 | A4140 SS |
| A4150 | CONFORMACIÓN DE CUERPO DE DIQUE CON MATERIAL PROPIO | 2d | 2024-04-09 | 2024-04-10 | A4200 SS+1d, A4140 SS |
| A4170 | GEOTEXTIL NO TEJIDO 400 G/M2, INC. COLOCACIÓN | 3d | 2024-04-10 | 2024-04-12 | A4200 |
| A4180 | COLOCACION Y ACOMODO DE ROCA EN UÑA DE DIQUE | 7d | 2024-04-13 | 2024-04-19 | A4170 |
| A4190 | COLOCACION Y ACOMODO DE ROCA EN TALUD DE DIQUE | 6d | 2024-04-18 | 2024-04-23 | A4180 SS+5d |
| A4160 | CONFORMACIÓN DE CORONA DE DIQUE CON MATERIAL PROPIO | 2d | 2024-04-24 | 2024-04-25 | A4190 |
| 3 | **TRAMO 3** |  | 2024-03-08 | 2024-03-29 |  |
| A2360 | EXCAVACIÓN EN TERRENO NATURAL CON EQUIPO | 7d | 2024-03-08 | 2024-03-14 | A2310, A1650, A1660 |
| A2370 | EXCAVACIÓN DE UÑA CON EQUIPO | 11d | 2024-03-09 | 2024-03-19 | A2360 SS+1d, A2280 |
| A2380 | PERFILADO Y COMPACTACIÓN EN ZONA DE CORTE | 12d | 2024-03-09 | 2024-03-20 | A2360 SS+1d |
| A2410 | GEOTEXTIL NO TEJIDO 400 G/M2, INC. COLOCACIÓN | 12d | 2024-03-10 | 2024-03-21 | A2380 SS+1d |
| A2420 | COLOCACION Y ACOMODO DE ROCA EN UÑA DE DIQUE | 16d | 2024-03-12 | 2024-03-27 | A2410 SS+2d |
| A2430 | COLOCACION Y ACOMODO DE ROCA EN TALUD DE DIQUE | 15d | 2024-03-14 | 2024-03-28 | A2420 SS+2d |
| A2440 | PREPARACIÓN DE FUNDACIÓN DE CUERPO DE DIQUE | 5d | 2024-03-15 | 2024-03-19 | A2360 |
| A2390 | CONFORMACIÓN DE CUERPO DE DIQUE CON MATERIAL PROPIO | 5d | 2024-03-16 | 2024-03-20 | A2440 SS+1d, A2300 |
| A2400 | CONFORMACIÓN DE CORONA DE DIQUE CON MATERIAL PROPIO | 6d | 2024-03-24 | 2024-03-29 | A2430 SS+10d |
| 4 | **TRAMO 4** |  | 2024-03-30 | 2024-04-22 |  |
| A2450 | EXCAVACIÓN EN TERRENO NATURAL CON EQUIPO | 7d | 2024-03-30 | 2024-04-05 | A2400 |
| A2460 | EXCAVACIÓN DE UÑA CON EQUIPO | 11d | 2024-03-31 | 2024-04-10 | A2450 SS+1d, A2370 |
| A2470 | PERFILADO Y COMPACTACIÓN EN ZONA DE CORTE | 12d | 2024-03-31 | 2024-04-11 | A2450 SS+1d |
| A2500 | GEOTEXTIL NO TEJIDO 400 G/M2, INC. COLOCACIÓN | 12d | 2024-04-01 | 2024-04-12 | A2470 SS+1d |
| A2510 | COLOCACION Y ACOMODO DE ROCA EN UÑA DE DIQUE | 16d | 2024-04-03 | 2024-04-18 | A2500 SS+2d |
| A2520 | COLOCACION Y ACOMODO DE ROCA EN TALUD DE DIQUE | 15d | 2024-04-05 | 2024-04-19 | A2510 SS+2d |
| A2530 | PREPARACIÓN DE FUNDACIÓN DE CUERPO DE DIQUE | 5d | 2024-04-06 | 2024-04-10 | A2450 |
| A2480 | CONFORMACIÓN DE CUERPO DE DIQUE CON MATERIAL PROPIO | 5d | 2024-04-07 | 2024-04-11 | A2530 SS+1d, A2390 |
| A2490 | CONFORMACIÓN DE CORONA DE DIQUE CON MATERIAL PROPIO | 6d | 2024-04-17 | 2024-04-22 | A2520 FF+3d, A2400 |
| 1 | **A3-RA-D-01** |  | 2024-03-09 | 2024-03-14 |  |
| A1710 | EXCAVACIÓN EN TERRENO NATURAL CON EQUIPO | 3d | 2024-03-09 | 2024-03-11 | A2190 |
| 2 | **A3-RA-I-01** |  | 2024-04-11 | 2024-04-16 |  |
| A1740 | EXCAVACIÓN EN TERRENO NATURAL CON EQUIPO | 3d | 2024-04-11 | 2024-04-13 | A2460 |
| A1750 | CONFORMACIÓN DE CUERPO DE RAMPA CON MATERIAL PROPIO | 3d | 2024-04-14 | 2024-04-16 | A1740 |
| A1760 | CONFORMACIÓN DE CORONACIÓN DE RAMPA | 3d | 2024-04-14 | 2024-04-16 | A1750 SS, A1730 |
| A3570 | EXCAVACIÓN EN TERRENO NATURAL CON EQUIPO | 36d | 2024-01-24 | 2024-02-28 | A1600 |
| A3660 | EXCAVACIÓN EN TERRENO NATURAL CON EQUIPO | 4d | 2023-12-14 | 2023-12-17 | A1330, A3650 |
| A3860 | MOVILIZACIÓN DE EQUIPOS Y HERRAMIENTAS (ARQUITECTURA Y PAISAJISMO) | 2d | 2024-01-26 | 2024-01-27 | A1570 |
| A4020 | DEMOVILIZACIÓN DE EQUIPOS Y HERRAMIENTAS (ARQUITECTURA Y PAISAJISMO) | 2d | 2024-04-07 | 2024-04-08 | A4010, A3900 |
| 5 | **INSTALACIÓN DE ALCORQUES** |  | 2024-04-05 | 2024-04-06 |  |
| A1770 | ACONDICIONAMIENTO DE DEPOSITOS DE MATERIALES EXCEDENTES (DME) | 160d | 2023-11-06 | 2024-04-13 | A1220 SS |

Removed: CONSTRUCCIÓN SUB PROYECTO A3 - RÍO LACRAMARCA; 01.02.01 MOVILIZACION Y DESMOVILIZACION DE EQUIPOS; DESCOLMATACIÓN DE CAUCE y OBRAS AUXILIARES; 1.04.02 DESCOLMATACIÓN DE CAUCE NATURAL DEL RÍO LACRAMARCA; 1.04.03 CONFORMACIÓN DE DESVIO EN CAUCE DE RÍO; 1.04.04 RELLENO NO ESTRUCTURAL CON MATERIAL PROPIO; 04.01.01 MOVILIZACIÓN Y DEMOVILIZACIÓN DE EQUIPOS Y HERRAMIENTAS (ARQUITECTURA Y PAISAJISMO); OBRAS PRELIMINARES PAISAJISMO; 04.05.01 MEJORAMIENTO DE SUELO CON TIERRA DE CHACRA; 04.05.02 UBICACIÓN Y DELIMITACIÓN DE ZONA DE PLANTACIÓN; 04.05.03 DESPEDREGADO DEL TERRENO CON MEDIOS MANUALES; 04.05.04 RASTRILLADO DEL TERRENO; 04.05.05 TRAZADO, MARCACIÓN Y ESTACADO; 04.05.06 RETIRO DE DESMONTE Y RESIDUOS SOLIDOS; INSTALACION DE PLANTONES (Incluye colocación de sustrato, tierra del lugar, tutores y excavación); 04.10.01 INST. PROSOPIS PALLIDA KUNTH ALGARROBO (0.80 a 1.50m); 04.10.02 INST. ACACIA MACRACANTHA FAIQUE (0.80 a 1.50m); 04.10.03 INST. PARKINSONIA ACULEATA AZOTE DE CRISTO (1.00 a 1.50 m); 04.10.04 INST. SENNA MULTIGLANDULOSA MUTUY (0.60 a 0.80m); 04.10.05 INST. ENCELIA CANESCEN GIRASOL SILVESTRE (0.20m a 0.30m); INTALACIÓN DE ALCORQUES; 5.022 DESMOVILIZACIÓN

Changed:

| ID | Task | Start | Finish | Duration | Total float | Predecessors | Other |
| --- | --- | --- | --- | --- | --- | --- | --- |
| 1 | **DEFENSAS RIBEREÑAS** | 2023-10-18 → 2023-10-31 (+13d) | 2024-05-03 → 2024-04-27 (-6d) |  |  |  |  |
| 1 | **OBRAS PRELIMINARES** | 2023-10-23 → 2023-11-02 (+10d) | 2023-11-04 → 2024-04-23 (+171d) |  |  |  |  |
| A1040 | INSTALACIONES PROVISIONALES PARA LA OBRA | 2023-10-23 → 2023-11-05 (+13d) | 2023-11-04 → 2024-04-21 (+169d) | 10d → 169d | 136.22d → 6d | none → A1015 | resources Camión grua [64 h]; CAPATAZ [80 h]; OPERARIO [480 h]; PEON [640 h] → none |
| A1050 | MANTENIMIENTO DE TRÁNSITO Y SEGURIDAD VIAL | 2023-10-23 → 2023-11-22 (+30d) | 2023-11-04 → 2024-04-23 (+171d) | 10d → 154d | 140.22d → 2d | A1040 SS → A1100 | resources Camión Cisterna 4x2 400 HP Agua (5000 gal) [1659.4 h]; Camión Volquete (15 m3) [737.6 h]; CAPATAZ [1860.16 h]; CUADRADOR/VIGÍA [3720.32 h]; Excavadora Sobre Oruga 260 HP [368.8 h]; Motoniveladora 185 HP [1075.5 h]; OFICIAL [368.8 h]; OPERARIO [368.8 h]; PEON [3720.32 h]; Retroexcavador 58 HP [717 h]; Rodillo Vib. Liso Autopropulsado 135 HP 12 TM [1075.5 h]; Tractor S/Orugas (D6T) - 180 HP [368.8 h] → none |
| 2 | **TRABAJOS PRELIMINARES** | 2023-10-18 → 2023-10-31 (+13d) | 2023-11-03 → 2024-04-27 (+176d) |  |  |  |  |
| 3 | **MEJORAMIENTO DE VÍAS EXISTENTES** | 2023-10-23 → 2023-11-05 (+13d) | 2023-11-09 → 2024-01-04 (+56d) |  |  |  |  |
| 1 | **MOVIMIENTO DE TIERRAS** | 2023-10-23 → 2023-11-05 (+13d) | 2023-10-28 → 2023-11-21 (+24d) |  |  |  |  |
| A1090 | ROCE Y LIMPIEZA DE MALEZA | 2023-10-23 → 2023-11-05 (+13d) | 2023-10-28 → 2023-11-21 (+24d) | 5.33d → 17d | 0d → 2d | MOVILIZACION Y DESMOVILIZACION DE EQUIPOS SS+4d → A1015 | resources AYUDANTE DE NIVELADOR [1428.96 h]; AYUDANTE DE TOPOGRAFO [2857.92 h]; Camión baranda 3 TON [14.93 h]; CAPATAZ [7.46 h]; CUADRADOR/VIGÍA [14.93 h]; PEON [29.86 h]; Retroexcavador 58 HP [7.46 h]; TOPOGRAFO [2857.92 h]; Tractor S/Orugas (D6T) - 180 HP [7.46 h]; OP. NIVELADOR [1428.96 h] → none |
| 2 | **REPOSICIÓN DE ESTRUCTURAS** | 2023-11-06 → 2023-11-25 (+19d) | 2023-11-08 → 2023-12-29 (+51d) |  |  |  |  |
| A1150 | DEMOLICIÓN DE ESTRUCTURAS EXISTENTES | 2023-11-06 → 2023-11-25 (+19d) | 2023-11-06 → 2023-11-26 (+20d) | 1d → 2d | 136.22d → 112d | A1040 → A1070 SS+23d | resources Camión Volquete (15 m3) [7.47 h]; CAPATAZ [0.75 h]; OPERARIO [14.93 h]; PEON [14.93 h]; Retroexcavador 58 HP [7.47 h] → none |
| A1160 | REPOSICIÓN DE PASE DE AGUA TUBO HDPE Ø=18" | 2023-11-07 → 2023-11-28 (+21d) | 2023-11-07 → 2023-11-29 (+22d) | 1d → 2d | 137.22d → 112d | A1150 → A1150 SS+3d | resources CAPATAZ [0.4 h]; OPERARIO [8 h]; PEON [16 h]; Retroexcavador 58 HP [4 h] → none |
| A1170 | REPOSICIÓN DE PASE DE AGUA TUBO HDPE Ø=36" | 2023-11-07 → 2023-11-28 (+21d) | 2023-11-07 → 2023-11-29 (+22d) | 1d → 2d | 137.22d → 112d |  | resources CAPATAZ [0.5 h]; OPERARIO [10 h]; PEON [20 h]; Retroexcavador 58 HP [5 h] → none |
| A1180 | SUMINISTRO Y MONTAJE DE PANELES DE C°A° 1.6mx1.0mx0.20m EN PASE DE AGUA | 2023-11-08 → 2023-11-30 (+22d) | 2023-11-08 → 2023-12-29 (+51d) | 1d → 30d | 137.22d → 112d | A1170 → A1170 SS+2d | resources CAPATAZ [0.28 h]; PEON [5.6 h] → none |
| A1190 | SUMINISTRO Y MONTAJE DE PANELES DE C°A° 2.20mx1.0mx0.20m EN PASE DE AGUA | 2023-11-08 → 2023-11-30 (+22d) | 2023-11-08 → 2023-12-29 (+51d) | 1d → 30d | 137.22d → 112d |  | resources CAPATAZ [0.2 h]; PEON [4 h] → none |
| 4 | **CABEZAL DE ENTRADA Y SALIDA** | 2023-11-07 → 2023-12-30 (+53d) | 2023-11-09 → 2024-01-04 (+56d) |  |  |  |  |
| A1210 | ENCOFRADO Y DESENCOFRADO RECTO | 2023-11-07 → 2023-12-30 (+53d) | 2023-11-08 → 2024-01-01 (+54d) | 2d → 3d | 136.22d → 112d | A1150 SS+1d → A1190 | resources CAPATAZ [7.06 h]; OPERARIO [14.12 h]; PEON [14.12 h] → none |
| A1200 | CONCRETOS | 2023-11-09 → 2024-01-02 (+54d) | 2023-11-09 → 2024-01-04 (+56d) | 1d → 3d | 136.22d → 112d |  | resources CAPATAZ [0.32 h]; OFICIAL [1.61 h]; OPERARIO [3.22 h]; PEON [16.11 h] → none |
| A1220 | DESBROCE Y LIMPIEZA EN ZONA NO BOSCOSA | 2023-10-30 → 2023-11-06 (+7d) | 2023-12-16 → 2024-01-20 (+35d) | 37d → 76d | 6.24d → 0d | A1090 → A1015 FS+1d | resources Camión Volquete (15 m3) [304.61 h]; CUADRADOR/VIGÍA [304.61 h]; Excavadora Sobre Oruga 260 HP [304.61 h]; OPERARIO [913.84 h]; PEON [1827.68 h]; Tractor S/Orugas (D6T) - 180 HP [152.31 h] → none |
| 5 | **DIQUES DE TIERRA COMPACTADA CON ENROCADO** | 2023-10-23 → 2023-11-12 (+20d) | 2024-05-03 → 2024-04-25 (-8d) |  |  |  |  |
| 1 | **DIQUE DE TIERRA COMPACTADA A3-D-01** | 2023-10-30 → 2023-11-12 (+13d) | 2024-01-04 → 2023-12-16 (-19d) |  |  |  |  |
| A1260 | EXCAVACIÓN EN TERRENO NATURAL CON EQUIPO | 2023-10-30 → 2023-11-12 (+13d) | 2023-10-31 → 2023-11-21 (+21d) | 2d → 10d | 6.24d → 0d | A1220 SS → A1810 | resources Camión Volquete (15 m3) [2976.35 h]; CAPATAZ [270.18 h]; CARGADOR SOBRE LLANTAS DE 200-250 HP [2643.39 h]; Excavadora Sobre Oruga 260 HP [225.02 h]; PEON [57.97 h]; Tractor S/Orugas (D6T) - 180 HP [28.99 h] → none |
| A1270 | EXCAVACIÓN DE UÑA CON EQUIPO | 2023-10-30 → 2023-11-13 (+14d) | 2023-10-31 → 2023-11-21 (+21d) | 2d → 9d | 94.56d → 136d | A1260 SS → A1260 SS+1d | resources CAPATAZ [26.51 h]; Excavadora Sobre Oruga 260 HP [53.24 h]; PEON [53.24 h] → none |
| A1280 | PERFILADO Y COMPACTACIÓN EN ZONA DE CORTE | 2023-11-02 → 2023-11-13 (+11d) | 2023-11-08 → 2023-12-02 (+24d) | 5.67d → 20d | 94.56d → 0d | A1260, A1270 → A1260 SS+1d | resources Camión Cisterna 4x2 400 HP Agua (5000 gal) [44.77 h]; CAPATAZ [22.38 h]; Motoniveladora 185 HP [44.77 h]; OFICIAL [44.77 h]; PEON [44.77 h]; Rodillo Vib. Liso Autopropulsado 135 HP 12 TM [44.77 h] → none |
| A1340 | PREPARACIÓN DE FUNDACIÓN DE CUERPO DE DIQUE | 2023-11-09 → 2023-11-13 (+4d) | 2023-11-10 → 2023-11-25 (+15d) | 2d → 13d | 94.56d → 0d | A1280 → A1280 SS | resources CAPATAZ [1.02 h]; Excavadora Sobre Oruga 260 HP [2.55 h]; Motoniveladora 185 HP [10.22 h]; OPERARIO [10.22 h]; PEON [20.43 h]; Rodillo Vib. Liso Autopropulsado 135 HP 12 TM [10.22 h] → none |
| A1290 | CONFORMACIÓN DE CUERPO DE DIQUE CON MATERIAL PROPIO | 2023-11-11 → 2023-11-27 (+16d) | 2023-11-17 → 2023-12-01 (+14d) | 5.67d → 5d | 94.56d → 0d | A1340 → A1016 | resources Camión Cisterna 4x2 400 HP Agua (5000 gal) [43.77 h]; CAPATAZ [43.77 h]; Excavadora Sobre Oruga 260 HP [43.77 h]; Motoniveladora 185 HP [43.77 h]; OFICIAL [43.77 h]; OPERARIO [43.77 h]; PEON [174.9 h]; Rodillo Vib. Liso Autopropulsado 135 HP 12 TM [43.77 h] → none |
| A1310 | GEOTEXTIL NO TEJIDO 400 G/M2, INC. COLOCACIÓN | 2023-11-18 → 2023-11-29 (+11d) | 2023-12-05 → 2023-12-04 (-1d) | 14d → 6d | 94.56d → 0d | A1290 → A1290 SS+2d | resources CAPATAZ [10.76 h]; OPERARIO [107.64 h]; PEON [430.54 h] → none |
| A1320 | COLOCACION Y ACOMODO DE ROCA EN UÑA DE DIQUE | 2023-12-06 → 2023-11-30 (-6d) | 2023-12-18 → 2023-12-05 (-13d) | 8.67d → 6d | 94.56d → 0d | A1310 → A1310 SS+1d | resources Camión Volquete (15 m3) [2976.35 h]; CAPATAZ [530.38 h]; CUADRADOR/VIGÍA [2643.4 h]; Excavadora Sobre Oruga 260 HP [432.79 h]; OPERARIO [265.75 h]; PEON [1594.27 h] → none |
| A1330 | COLOCACION Y ACOMODO DE ROCA EN TALUD DE DIQUE | 2023-12-11 → 2023-12-02 (-9d) | 2023-12-29 → 2023-12-13 (-16d) | 15.33d → 12d | 94.56d → 0d |  | resources Camión Volquete (15 m3) [2976.35 h]; CAPATAZ [730.3 h]; CUADRADOR/VIGÍA [2643.4 h]; Excavadora Sobre Oruga 260 HP [632.72 h]; OPERARIO [465.67 h]; PEON [4657.71 h] → none |
| A1300 | CONFORMACIÓN DE CORONA DE DIQUE CON MATERIAL PROPIO | 2023-12-30 → 2023-12-11 (-19d) | 2024-01-04 → 2023-12-16 (-19d) | 3.67d → 6d | 94.56d → 133d | A1330 → A1330 FF+3d | resources Camión Cisterna 4x2 400 HP Agua (5000 gal) [28.59 h]; CAPATAZ [28.59 h]; Excavadora Sobre Oruga 260 HP [28.59 h]; Motoniveladora 185 HP [28.59 h]; OFICIAL [28.59 h]; OPERARIO [28.59 h]; PEON [114.26 h]; Rodillo Vib. Liso Autopropulsado 135 HP 12 TM [28.59 h] → none |
| 2 | **DIQUE DE TIERRA COMPACTADA A3-D-02** | 2023-10-23 → 2023-12-16 (+54d) | 2024-05-03 → 2024-04-13 (-20d) |  |  |  |  |
| A1350 | EXCAVACIÓN EN TERRENO NATURAL CON EQUIPO | 2023-10-23 → 2023-12-16 (+54d) | 2023-11-16 → 2023-12-24 (+38d) | 19.67d → 9d | 0d → 12d | A1090 SS → A1830 | resources Camión Volquete (15 m3) [2976.35 h]; CAPATAZ [312.59 h]; CUADRADOR/VIGÍA [2643.4 h]; Excavadora Sobre Oruga 260 HP [667.94 h]; PEON [500.89 h]; Tractor S/Orugas (D6T) - 180 HP [250.44 h] → none |
| A1360 | EXCAVACIÓN DE UÑA CON EQUIPO | 2023-10-25 → 2023-12-17 (+53d) | 2023-11-17 → 2023-12-27 (+40d) | 18.67d → 11d | 0d → 111d | A1350 SS+2d → A1350 SS+1d, A1270 | resources CAPATAZ [190.6 h]; Excavadora Sobre Oruga 260 HP [382.86 h]; PEON [382.86 h] → none |
| A1370 | PERFILADO Y COMPACTACIÓN EN ZONA DE CORTE | 2023-10-28 → 2023-12-17 (+50d) | 2023-12-11 → 2023-12-28 (+17d) | 32.67d → 12d | 0d → 12d | A1360 SS+3d → A1350 SS+1d | resources Camión Cisterna 4x2 400 HP Agua (5000 gal) [278.77 h]; CAPATAZ [139.39 h]; Motoniveladora 185 HP [278.77 h]; OFICIAL [278.77 h]; PEON [278.77 h]; Rodillo Vib. Liso Autopropulsado 135 HP 12 TM [278.77 h] → none |
| A1400 | GEOTEXTIL NO TEJIDO 400 G/M2, INC. COLOCACIÓN | 2023-12-26 → 2023-12-19 (-7d) | 2024-03-06 → 2023-12-31 (-66d) | 57.33d → 13d | 0d → 12d | A1380 SS+5d → A1370 SS+2d | resources CAPATAZ [48.73 h]; OPERARIO [487.29 h]; PEON [1949.15 h] → none |
| A1410 | COLOCACION Y ACOMODO DE ROCA EN UÑA DE DIQUE | 2023-12-29 → 2023-12-21 (-8d) | 2024-03-06 → 2024-01-05 (-61d) | 54.33d → 16d | 0d → 12d | A1400 SS+3d → A1400 SS+2d | resources Camión Volquete (15 m3) [2976.35 h]; CAPATAZ [2175.61 h]; CUADRADOR/VIGÍA [2643.4 h]; Excavadora Sobre Oruga 260 HP [167.05 h]; OPERARIO [1910.98 h]; PEON [11464.2 h] → none |
| A1420 | COLOCACION Y ACOMODO DE ROCA EN TALUD DE DIQUE | 2023-12-30 → 2023-12-23 (-7d) | 2024-04-10 → 2024-01-06 (-95d) | 79.89d → 15d | 0d → 12d | A1410 SS+1d → A1410 SS+2d | resources Camión Volquete (15 m3) [2976.35 h]; CAPATAZ [2933.71 h]; CUADRADOR/VIGÍA [2643.4 h]; Excavadora Sobre Oruga 260 HP [167.05 h]; OPERARIO [2669.08 h]; PEON [2669.08 h] → none |
| A1430 | PREPARACIÓN DE FUNDACIÓN DE CUERPO DE DIQUE | 2023-12-12 → 2023-12-25 (+13d) | 2023-12-18 → 2023-12-29 (+11d) | 5.67d → 5d | 0d → 114d | A1370 → A1350 | resources CAPATAZ [4.15 h]; Excavadora Sobre Oruga 260 HP [10.38 h]; Motoniveladora 185 HP [41.53 h]; OPERARIO [41.53 h]; PEON [83.05 h]; Rodillo Vib. Liso Autopropulsado 135 HP 12 TM [41.53 h] → none |
| A1380 | CONFORMACIÓN DE CUERPO DE DIQUE CON MATERIAL PROPIO | 2023-12-19 → 2023-12-26 (+7d) | 2024-01-17 → 2023-12-30 (-18d) | 22.67d → 5d | 0d → 114d | A1430 → A1430 SS+1d | resources Camión Cisterna 4x2 400 HP Agua (5000 gal) [185.32 h]; CAPATAZ [185.32 h]; Excavadora Sobre Oruga 260 HP [185.32 h]; Motoniveladora 185 HP [185.32 h]; OFICIAL [185.32 h]; OPERARIO [185.32 h]; PEON [740.59 h]; Rodillo Vib. Liso Autopropulsado 135 HP 12 TM [185.32 h] → none |
| A1390 | CONFORMACIÓN DE CORONA DE DIQUE CON MATERIAL PROPIO | 2024-04-11 → 2024-01-03 (-99d) | 2024-05-03 → 2024-01-08 (-116d) | 18d → 6d | 0d → 12d | A1420 → A1420 SS+11d | resources Camión Cisterna 4x2 400 HP Agua (5000 gal) [144.43 h]; CAPATAZ [144.43 h]; Excavadora Sobre Oruga 260 HP [144.43 h]; Motoniveladora 185 HP [144.43 h]; OFICIAL [144.43 h]; OPERARIO [144.43 h]; PEON [577.21 h]; Rodillo Vib. Liso Autopropulsado 135 HP 12 TM [144.43 h] → none |
| A1910 | EXCAVACIÓN EN TERRENO NATURAL CON EQUIPO | 2023-11-02 → 2024-03-21 (+140d) | 2023-11-11 → 2024-03-29 (+139d) | 8.33d → 9d | 6.24d → 12d | A1260 → A2220 | resources Camión Volquete (15 m3) [2976.35 h]; CAPATAZ [312.59 h]; CUADRADOR/VIGÍA [2643.4 h]; Excavadora Sobre Oruga 260 HP [667.94 h]; PEON [500.89 h]; Tractor S/Orugas (D6T) - 180 HP [250.44 h] → none |
| A1920 | EXCAVACIÓN DE UÑA CON EQUIPO | 2023-11-02 → 2024-03-22 (+141d) | 2023-11-13 → 2024-04-01 (+140d) | 9.33d → 11d | 96.56d → 26d | A1910 SS → A1910 SS+1d, A1360 | resources CAPATAZ [190.6 h]; Excavadora Sobre Oruga 260 HP [382.86 h]; PEON [382.86 h] → none |
| A1930 | PERFILADO Y COMPACTACIÓN EN ZONA DE CORTE | 2023-11-04 → 2024-03-22 (+139d) | 2023-11-14 → 2024-04-02 (+140d) | 8.33d → 12d | 96.56d → 12d | A1920 SS+2d → A1910 SS+1d | resources Camión Cisterna 4x2 400 HP Agua (5000 gal) [278.77 h]; CAPATAZ [139.39 h]; Motoniveladora 185 HP [287.77 h]; OFICIAL [278.77 h]; PEON [278.77 h]; Rodillo Vib. Liso Autopropulsado 135 HP 12 TM [278.77 h] → none |
| A1960 | GEOTEXTIL NO TEJIDO 400 G/M2, INC. COLOCACIÓN | 2023-11-22 → 2024-03-24 (+123d) | 2023-12-07 → 2024-04-04 (+119d) | 13d → 12d | 96.56d → 12d | A1940 SS+4d → A1930 SS+2d | resources CAPATAZ [48.73 h]; OPERARIO [487.29 h]; PEON [1949.15 h] → none |
| A1970 | COLOCACION Y ACOMODO DE ROCA EN UÑA DE DIQUE | 2023-11-28 → 2024-03-26 (+119d) | 2023-12-12 → 2024-04-10 (+120d) | 10.67d → 16d | 96.56d → 12d | A1960 SS+4.33d → A1960 SS+2d | resources Camión Volquete (15 m3) [2976.35 h]; CAPATAZ [2175.61 h]; CUADRADOR/VIGÍA [2643.4 h]; Excavadora Sobre Oruga 260 HP [2078.03 h]; OPERARIO [1910.98 h]; PEON [11464.2 h] → none |
| A1980 | COLOCACION Y ACOMODO DE ROCA EN TALUD DE DIQUE | 2023-12-01 → 2024-03-28 (+118d) | 2023-12-27 → 2024-04-11 (+106d) | 19d → 15d | 96.56d → 12d | A1970 SS+3d → A1970 SS+2d | resources Camión Volquete (15 m3) [2976.35 h]; CAPATAZ [2933.71 h]; CUADRADOR/VIGÍA [2643.4 h]; Excavadora Sobre Oruga 260 HP [2836.13 h]; OPERARIO [2669.08 h]; PEON [26696.8 h] → none |
| A1990 | PREPARACIÓN DE FUNDACIÓN DE CUERPO DE DIQUE | 2023-11-15 → 2024-03-30 (+136d) | 2023-11-16 → 2024-04-03 (+139d) | 2d → 5d | 96.56d → 23d | A1930 → A1910 | resources CAPATAZ [4.15 h]; Excavadora Sobre Oruga 260 HP [10.38 h]; Motoniveladora 185 HP [41.53 h]; OPERARIO [41.53 h]; PEON [83.05 h]; Rodillo Vib. Liso Autopropulsado 135 HP 12 TM [41.53 h] → none |
| A1940 | CONFORMACIÓN DE CUERPO DE DIQUE CON MATERIAL PROPIO | 2023-11-17 → 2024-03-31 (+135d) | 2023-11-28 → 2024-04-04 (+128d) | 9.33d → 5d | 96.56d → 23d | A1990 → A1990 SS+1d, A1380 | resources Camión Cisterna 4x2 400 HP Agua (5000 gal) [185.32 h]; CAPATAZ [185.32 h]; Excavadora Sobre Oruga 260 HP [185.32 h]; Motoniveladora 185 HP [185.32 h]; OFICIAL [185.32 h]; OPERARIO [185.32 h]; PEON [740.59 h]; Rodillo Vib. Liso Autopropulsado 135 HP 12 TM [185.32 h] → none |
| A1950 | CONFORMACIÓN DE CORONA DE DIQUE CON MATERIAL PROPIO | 2023-12-28 → 2024-04-08 (+102d) | 2024-01-02 → 2024-04-13 (+102d) | 3.67d → 6d | 96.56d → 12d | A1980 → A1980 SS+11d | resources Camión Cisterna 4x2 400 HP Agua (5000 gal) [144.43 h]; CAPATAZ [144.43 h]; Excavadora Sobre Oruga 260 HP [144.43 h]; Motoniveladora 185 HP [144.43 h]; OFICIAL [144.43 h]; OPERARIO [144.43 h]; PEON [577.21 h]; Rodillo Vib. Liso Autopropulsado 135 HP 12 TM [144.43 h] → none |
| A2000 | EXCAVACIÓN EN TERRENO NATURAL CON EQUIPO | 2023-11-13 → 2024-01-09 (+57d) | 2023-12-11 → 2024-01-17 (+37d) | 22d → 9d | 6.24d → 12d | A1910 → A1390 | resources Camión Volquete (15 m3) [2976.35 h]; CAPATAZ [277.02 h]; CUADRADOR/VIGÍA [2643.4 h]; Excavadora Sobre Oruga 260 HP [296.44 h]; PEON [129.39 h]; Tractor S/Orugas (D6T) - 180 HP [64.69 h] → none |
| A2010 | EXCAVACIÓN DE UÑA CON EQUIPO | 2023-11-13 → 2024-01-10 (+58d) | 2023-12-12 → 2024-01-20 (+39d) | 23d → 11d | 59.22d → 65d | A2000 SS → A2000 SS+1d | resources CAPATAZ [25.94 h]; Excavadora Sobre Oruga 260 HP [52.11 h]; PEON [52.11 h] → none |
| A2020 | PERFILADO Y COMPACTACIÓN EN ZONA DE CORTE | 2023-12-13 → 2024-01-10 (+28d) | 2023-12-22 → 2024-01-21 (+30d) | 8d → 12d | 59.22d → 12d | A2010 → A2000 SS+1d | resources Camión Cisterna 4x2 400 HP Agua (5000 gal) [39.2 h]; CAPATAZ [19.6 h]; Motoniveladora 185 HP [39.2 h]; OFICIAL [39.2 h]; PEON [39.2 h]; Rodillo Vib. Liso Autopropulsado 135 HP 12 TM [39.2 h] → none |
| A2050 | GEOTEXTIL NO TEJIDO 400 G/M2, INC. COLOCACIÓN | 2023-12-27 → 2024-01-12 (+16d) | 2024-01-11 → 2024-01-23 (+12d) | 11.33d → 12d | 59.22d → 12d | A2030 → A2020 SS+2d | resources CAPATAZ [10.55 h]; OPERARIO [105.53 h]; PEON [422.13 h] → none |
| A2060 | COLOCACION Y ACOMODO DE ROCA EN UÑA DE DIQUE | 2024-01-02 → 2024-01-14 (+12d) |  | 21.67d → 16d | 59.22d → 12d | A2050 SS+4d → A2050 SS+2d | resources Camión Volquete (15 m3) [2976.35 h]; CAPATAZ [524.72 h]; Excavadora Sobre Oruga 260 HP [427.14 h]; OPERARIO [260.09 h]; PEON [1560.34 h] → none |
| A2070 | COLOCACION Y ACOMODO DE ROCA EN TALUD DE DIQUE | 2024-01-05 → 2024-01-16 (+11d) | 2024-02-12 → 2024-01-30 (-13d) | 30.33d → 15d | 59.22d → 12d | A2060 SS+2.67d → A2060 SS+2d | resources Camión Volquete (15 m3) [2976.35 h]; CAPATAZ [721.35 h]; CUADRADOR/VIGÍA [2643.4 h]; Excavadora Sobre Oruga 260 HP [623.77 h]; OPERARIO [456.72 h]; PEON [4568.23 h] → none |
| A2080 | PREPARACIÓN DE FUNDACIÓN DE CUERPO DE DIQUE | 2023-12-22 → 2024-01-18 (+27d) | 2023-12-23 → 2024-01-22 (+30d) | 1d → 5d | 59.22d → 83d | A2020 → A2000 | resources CAPATAZ [1.02 h]; Excavadora Sobre Oruga 260 HP [2.55 h]; Motoniveladora 185 HP [10.22 h]; OPERARIO [10.22 h]; PEON [20.43 h]; Rodillo Vib. Liso Autopropulsado 135 HP 12 TM [10.22 h] → none |
| A2030 | CONFORMACIÓN DE CUERPO DE DIQUE CON MATERIAL PROPIO | 2023-12-23 → 2024-01-19 (+27d) | 2023-12-27 → 2024-01-23 (+27d) | 1.67d → 5d | 59.22d → 83d | A2080 → A2080 SS+1d | resources Camión Cisterna 4x2 400 HP Agua (5000 gal) [74.58 h]; CAPATAZ [74.58 h]; Excavadora Sobre Oruga 260 HP [74.58 h]; Motoniveladora 185 HP [74.58 h]; OFICIAL [74.58 h]; OPERARIO [74.58 h]; PEON [298.02 h]; Rodillo Vib. Liso Autopropulsado 135 HP 12 TM [74.58 h] → none |
| A2040 | CONFORMACIÓN DE CORONA DE DIQUE CON MATERIAL PROPIO | 2024-02-12 → 2024-01-27 (-16d) | 2024-02-17 → 2024-02-01 (-16d) | 4.67d → 6d | 59.22d → 12d | A2070 → A2070 SS+11d | resources Camión Cisterna 4x2 400 HP Agua (5000 gal) [28.01 h]; CAPATAZ [28.01 h]; Excavadora Sobre Oruga 260 HP [28.01 h]; Motoniveladora 185 HP [28.01 h]; OFICIAL [28.01 h]; OPERARIO [28.01 h]; PEON [111.94 h]; Rodillo Vib. Liso Autopropulsado 135 HP 12 TM [28.01 h] → none |
| A2090 | EXCAVACIÓN EN TERRENO NATURAL CON EQUIPO | 2023-12-12 → 2024-02-02 (+52d) | 2024-01-06 → 2024-02-10 (+35d) | 19.67d → 9d | 6.24d → 12d | A2000 → A2040 | resources Camión Volquete (15 m3) [2976.35 h]; CAPATAZ [281.53 h]; CUADRADOR/VIGÍA [2643.4 h]; Excavadora Sobre Oruga 260 HP [343.59 h]; PEON [176.54 h]; Tractor S/Orugas (D6T) - 180 HP [88.27 h] → none |
| A2100 | EXCAVACIÓN DE UÑA CON EQUIPO | 2023-12-12 → 2024-02-03 (+53d) | 2024-01-06 → 2024-02-13 (+38d) | 19.67d → 11d | 6.24d → 52d | A2090 SS → A2090 SS+1d, A2010 | resources CAPATAZ [35.35 h]; Excavadora Sobre Oruga 260 HP [71.01 h]; PEON [71.01 h] → none |
| A2110 | PERFILADO Y COMPACTACIÓN EN ZONA DE CORTE | 2023-12-15 → 2024-02-03 (+50d) | 2023-12-23 → 2024-02-14 (+53d) | 7.33d → 12d | 6.24d → 12d | A2090 SS+3d, A2100 SS+3d → A2090 SS+1d | resources Camión Cisterna 4x2 400 HP Agua (5000 gal) [48.82 h]; CAPATAZ [24.41 h]; Motoniveladora 185 HP [48.82 h]; OFICIAL [48.82 h]; PEON [48.82 h]; Rodillo Vib. Liso Autopropulsado 135 HP 12 TM [48.82 h] → none |
| A2140 | GEOTEXTIL NO TEJIDO 400 G/M2, INC. COLOCACIÓN | 2024-01-24 → 2024-02-05 (+12d) | 2024-02-02 → 2024-02-16 (+14d) | 8.67d → 12d | 6.24d → 12d | A2120 → A2110 SS+2d | resources CAPATAZ [9.5 h]; OPERARIO [95.04 h]; PEON [380.16 h] → none |
| A2150 | COLOCACION Y ACOMODO DE ROCA EN UÑA DE DIQUE | 2024-02-03 → 2024-02-07 (+4d) | 2024-03-12 → 2024-02-22 (-19d) | 31d → 16d | 6.24d → 12d | A2140 → A2140 SS+2d | resources Camión Volquete (15 m3) [2976.35 h]; CAPATAZ [619.08 h]; CUADRADOR/VIGÍA [2643.4 h]; Excavadora Sobre Oruga 260 HP [521.5 h]; OPERARIO [354.45 h]; PEON [2126.4 h] → none |
| A2160 | COLOCACION Y ACOMODO DE ROCA EN TALUD DE DIQUE | 2024-02-08 → 2024-02-09 (+1d) | 2024-04-04 → 2024-02-23 (-41d) | 44d → 15d | 6.24d → 12d | A2150 SS+4d → A2150 SS+2d | resources Camión Volquete (15 m3) [2976.35 h]; CAPATAZ [776.13 h]; CUADRADOR/VIGÍA [2643.4 h]; Excavadora Sobre Oruga 260 HP [678.55 h]; OPERARIO [511.5 h]; PEON [5116.14 h] → none |
| A2170 | PREPARACIÓN DE FUNDACIÓN DE CUERPO DE DIQUE | 2023-12-26 → 2024-02-11 (+47d) | 2023-12-30 → 2024-02-15 (+47d) | 4.67d → 5d | 6.24d → 64d | A2110 → A2090 | resources CAPATAZ [0.57 h]; Excavadora Sobre Oruga 260 HP [1.42 h]; Motoniveladora 185 HP [5.66 h]; OPERARIO [5.66 h]; PEON [11.33 h]; Rodillo Vib. Liso Autopropulsado 135 HP 12 TM [5.66 h] → none |
| A2120 | CONFORMACIÓN DE CUERPO DE DIQUE CON MATERIAL PROPIO | 2024-01-02 → 2024-02-12 (+41d) | 2024-01-23 → 2024-02-16 (+24d) | 18d → 5d | 6.24d → 64d | A2170 → A2170 SS+1d, A2030 | resources Camión Cisterna 4x2 400 HP Agua (5000 gal) [15.45 h]; CAPATAZ [15.45 h]; Excavadora Sobre Oruga 260 HP [15.45 h]; Motoniveladora 185 HP [15.45 h]; OFICIAL [15.45 h]; OPERARIO [15.45 h]; PEON [61.73 h]; Rodillo Vib. Liso Autopropulsado 135 HP 12 TM [15.45 h] → none |
| A2130 | CONFORMACIÓN DE CORONA DE DIQUE CON MATERIAL PROPIO | 2024-04-05 → 2024-02-20 (-45d) | 2024-04-22 → 2024-02-25 (-57d) | 14.22d → 6d | 8.67d → 12d | A2160 → A2160 SS+11d | resources Camión Cisterna 4x2 400 HP Agua (5000 gal) [33.2 h]; CAPATAZ [33.2 h]; Excavadora Sobre Oruga 260 HP [33.2 h]; Motoniveladora 185 HP [33.2 h]; OFICIAL [33.2 h]; OPERARIO [33.2 h]; PEON [132.69 h]; Rodillo Vib. Liso Autopropulsado 135 HP 12 TM [33.2 h] → none |
| A2180 | EXCAVACIÓN EN TERRENO NATURAL CON EQUIPO | 2024-01-08 → 2024-02-26 (+49d) | 2024-01-10 → 2024-03-05 (+55d) | 3d → 9d | 86.22d → 12d | A2090 → A2130 | resources CAPATAZ [0.38 h]; Excavadora Sobre Oruga 260 HP [4.02 h]; PEON [4.02 h]; Tractor S/Orugas (D6T) - 180 HP [2.01 h] → none |
| 3 | **DIQUE DE TIERRA COMPACTADA A3-I-01** | 2023-11-02 → 2023-12-16 (+44d) | 2024-01-02 → 2024-01-22 (+20d) |  |  |  |  |
| A1440 | EXCAVACIÓN EN TERRENO NATURAL CON EQUIPO | 2024-01-05 → 2023-12-16 (-20d) | 2024-01-08 → 2023-12-22 (-17d) | 2.67d → 7d | 31.22d → 0d | A3560 → A1240 | resources CAPATAZ [2.42 h]; CUADRADOR/VIGÍA [23.12 h]; Excavadora Sobre Oruga 260 HP [23.12 h]; PEON [45.89 h]; Tractor S/Orugas (D6T) - 180 HP [23.12 h] → none |
| A4030 | EXCAVACIÓN EN TERRENO NATURAL CON EQUIPO | 2024-01-12 → 2024-01-03 (-9d) | 2024-01-12 → 2024-01-06 (-6d) | 1d → 4d | 31.56d → 96d | A3650 → A1480 | resources CAPATAZ [2.42 h]; CUADRADOR/VIGÍA [23.12 h]; Excavadora Sobre Oruga 260 HP [23.12 h]; PEON [45.89 h]; Tractor S/Orugas (D6T) - 180 HP [23.12 h] → none |

| ID | Task | Start | Finish | Duration | Total float | Predecessors | Other |
| --- | --- | --- | --- | --- | --- | --- | --- |
| 4 | **DIQUE DE TIERRA COMPACTADA A3-I-02** | 2023-11-13 → 2024-01-02 (+50d) | 2024-02-17 → 2024-01-25 (-23d) |  |  |  |  |
| 5 | **DIQUE DE TIERRA COMPACTADA A3-I-03** | 2023-12-12 → 2024-01-26 (+45d) | 2024-04-22 → 2024-04-25 (+3d) |  |  |  |  |
| 6 | **RAMPAS** | 2024-01-08 → 2024-03-09 (+61d) | 2024-01-15 → 2024-04-16 (+92d) |  |  |  |  |
| A1720 | CONFORMACIÓN DE CUERPO DE RAMPA CON MATERIAL PROPIO | 2024-01-11 → 2024-03-12 (+61d) | 2024-01-12 → 2024-03-14 (+62d) | 2.25d → 3d | 97d → 39d | A2180 → A1710 | resources Camión Cisterna 4x2 400 HP Agua (5000 gal) [6.32 h]; CAPATAZ [6.32 h]; Excavadora Sobre Oruga 260 HP [6.32 h]; Motoniveladora 185 HP [6.32 h]; OFICIAL [6.32 h]; OPERARIO [6.32 h]; PEON [25.27 h]; Rodillo Vib. Liso Autopropulsado 135 HP 12 TM [6.32 h] → none |
| A1730 | CONFORMACIÓN DE CORONACIÓN DE RAMPA | 2024-01-13 → 2024-03-12 (+59d) | 2024-01-15 → 2024-03-14 (+59d) | 1.67d → 3d | 86.22d → 39d | A1720 → A1720 SS | resources Camión Cisterna 4x2 400 HP Agua (5000 gal) [4.32 h]; CAPATAZ [4.32 h]; Excavadora Sobre Oruga 260 HP [4.32 h]; Motoniveladora 185 HP [4.32 h]; OFICIAL [4.32 h]; OPERARIO [4.32 h]; PEON [17.26 h]; Rodillo Vib. Liso Autopropulsado 135 HP 12 TM [4.32 h] → none |
| 2 | **OBRAS DE ARTE** | 2023-11-22 → 2023-11-06 (-16d) | 2024-03-23 → 2024-04-22 (+30d) |  |  |  |  |
| 1 | **CAPTACIÓN A3-CP-23-95** | 2023-11-22 → 2023-11-21 (-1d) | 2024-02-21 → 2024-03-18 (+26d) |  |  |  |  |
| 1 | **MOVIMIENTO DE TIERRAS** | 2023-11-22 → 2023-11-21 (-1d) | 2024-01-03 → 2024-01-07 (+4d) |  |  |  |  |
| A2770 | EXCAVACIÓN ESTRUCTURAL PARA OBRAS DE ARTE | 2023-11-22 → 2023-11-21 (-1d) | 2023-11-29 → 2023-11-26 (-3d) | 6.33d → 6d | 10.33d → 38d | A2000 SS+8d → A3390 | resources CAPATAZ [5.2 h]; CUADRADOR/VIGÍA [51.99 h]; PEON [207.98 h]; Retroexcavador 58 HP [51.99 h] → none |
| A2780 | RELLENO ESTRUCTURAL PARA OBRAS DE ARTE, CON MATERIAL PROPIO | 2023-12-23 → 2024-01-03 (+11d) | 2024-01-03 → 2024-01-07 (+4d) | 7.33d → 5d | 95.56d → 90d | A2810, A2820 FF+6d → A2800 FS+12d | resources CAPATAZ [4.86 h]; CUADRADOR/VIGÍA [48.57 h]; PEON [194.28 h]; Retroexcavador 58 HP [12.15 h]; Rodillo Vib. Liso Autopropulsado 135 HP 12 TM [48.57 h] → none |
| 2 | **OBRAS DE CONCRETO** | 2023-11-30 → 2023-11-27 (-3d) | 2023-12-26 → 2023-12-21 (-5d) |  |  |  |  |
| A2790 | CONCRETO f'c=100 kg/cm2 | 2023-11-30 → 2023-11-27 (-3d) | 2023-11-30 → 2023-11-29 (-1d) | 1d → 3d | 95.56d → 50d |  | resources CAPATAZ [0.25 h]; OFICIAL [1.23 h]; OPERARIO [2.45 h]; PEON [12.27 h] → none |
| A2810 | CONCRETO CICLÓPEO f'c=280 kg/cm2 + 30% P.G. | 2023-12-22 → 2023-11-30 (-22d) | 2023-12-22 → 2023-12-02 (-20d) | 1d → 3d | 95.56d → 50d | A2800 → A2790 | resources CAPATAZ [0.45 h]; OPERARIO [2.24 h]; PEON [4.48 h] → none |
| A2830 | ACERO DE REFUERZO fy=4200 kg/cm2 | 2023-12-01 → 2023-12-03 (+2d) | 2023-12-12 → 2023-12-15 (+3d) | 7.67d → 13d | 95.56d → 50d | A2790 → A2810 | resources CAPATAZ [22.75 h]; OPERARIO [229.58 h]; PEON [229.58 h] → none |
| A2820 | ENCOFRADO Y DESENCOFRADO RECTO | 2023-12-05 → 2023-12-07 (+2d) | 2023-12-26 → 2023-12-16 (-10d) | 14.33d → 10d | 95.89d → 53d | A2830 SS+2d, A2810 FF+1d → A2830 FF+1d | resources CAPATAZ [31.4 h]; OPERARIO [62.8 h]; PEON [62.8 h] → none |
| A2800 | CONCRETO f'c=280 kg/cm2 | 2023-12-13 → 2023-12-10 (-3d) |  | 7.67d → 12d | 95.56d → 55d | A2830 → A2820 SS+3d | resources OFICIAL [122.05 h]; OPERARIO [61.02 h]; PEON [610.24 h] → none |
| 3 | **ESTRUCTURAS METALICAS** | 2023-12-22 → 2024-01-03 (+12d) | 2023-12-27 → 2024-01-17 (+21d) |  |  |  |  |
| A2840 | COMPUERTA METALICA PLANA DESLIZANTE DE 1.0x1.0m | 2023-12-22 → 2024-01-03 (+12d) | 2023-12-22 → 2024-01-05 (+14d) | 1d → 3d | 100.22d → 99d | A2800 → A2800 FS+12d | resources OFICIAL [4 h]; OPERARIO [4 h]; PEON [12 h] → none |
| A2850 | REJILLA DE 1.00x1.00m CON VARILLA DE 1/2" CADA 6,25cm | 2023-12-22 → 2024-01-06 (+15d) | 2023-12-22 → 2024-01-08 (+17d) | 1d → 3d | 100.22d → 99d | A2840 SS → A2840 | resources OPERARIO [1.6 h]; PEON [3.2 h] → none |
| A2860 | BARANDA DE FIERRO GALVANIZADO 1 1/2" | 2023-12-23 → 2024-01-09 (+17d) | 2023-12-23 → 2024-01-11 (+19d) | 0.67d → 3d | 100.22d → 99d | A2850 SS+1d → A2850 | resources CAPATAZ [0.12 h]; OFICIAL [2.4 h]; OPERARIO [2.4 h]; PEON [1.2 h] → none |
| A2870 | ESCALERA TIPO GATO | 2023-12-26 → 2024-01-12 (+17d) | 2023-12-26 → 2024-01-14 (+19d) | 1d → 3d | 100.22d → 99d | A2860 SS+0.67d → A2860 | resources CAPATAZ [0.2 h]; OPERARIO [2 h]; PEON [4 h] → none |
| A2880 | TAPA METALICA CIRCULAR DN600 MM | 2023-12-27 → 2024-01-15 (+19d) | 2023-12-27 → 2024-01-17 (+21d) | 1d → 3d | 100.22d → 99d |  | resources OPERARIO [5.33 h]; PEON [5.33 h] → none |
| 4 | **TUBERIAS** | 2023-11-30 → 2023-11-27 (-3d) | 2023-12-30 → 2024-01-23 (+24d) |  |  |  |  |
| A2890 | EXCAVACIÓN ESTRUCTURAL PARA OBRAS DE ARTE (Buzones) | 2023-11-30 → 2023-11-27 (-3d) | 2023-12-02 → 2023-11-29 (-3d) | 2.67d → 3d | 55.89d → 38d |  | resources CAPATAZ [1.85 h]; CUADRADOR/VIGÍA [18.46 h]; PEON [73.86 h]; Retroexcavador 58 HP [18.46 h] → none |
| A2900 | EXCAVACIÓN DE ZANJA |  | 2023-12-14 → 2023-12-24 (+10d) | 10.67d → 25d | 55.89d → 38d | A2890 SS → A2890 | resources CAPATAZ [8.19 h]; CUADRADOR/VIGÍA [81.86 h]; PEON [327.45 h]; Retroexcavador 58 HP [81.86 h] → none |
| A2920 | CAMA DE ARENA | 2023-12-15 → 2023-12-03 (-12d) | 2023-12-15 → 2023-12-27 (+12d) | 1d → 25d | 89.89d → 93d | A2900 → A2900 SS+3d | resources CAPATAZ [2.78 h]; PEON [22.21 h] → none |
| A2940 | CONCRETO f'c=100 kg/cm2 (Buzones) | 2023-12-04 → 2023-12-03 (-1d) | 2023-12-04 → 2023-12-05 (+1d) | 1d → 3d | 55.89d → 60d | A2890 → A2900 SS+3d, A2790 | resources CAPATAZ [0.25 h]; OFICIAL [1.23 h]; OPERARIO [2.45 h]; PEON [12.27 h] → none |
| A2990 | SUMINISTRO E INSTALACIÓN DE TUBERÍA GRP DN600 mm SN2500 | 2023-12-16 → 2023-12-04 (-12d) | 2023-12-18 → 2023-12-28 (+10d) | 1.67d → 25d | 89.89d → 93d | A2920 → A2920 SS+1d | resources CAPATAZ [1.26 h]; CUADRADOR/VIGÍA [12.62 h]; OFICIAL [12.62 h]; PEON [25.24 h]; Retroexcavador 58 HP [12.62 h] → none |
| A2980 | ACERO DE REFUERZO fy=4200 kg/cm2 (Buzones) | 2023-12-05 → 2023-12-16 (+11d) | 2023-12-07 → 2023-12-19 (+12d) | 3d → 4d | 55.89d → 50d | A2940 → A2940, A2830 | resources CAPATAZ [1.88 h]; OPERARIO [18.94 h]; PEON [18.94 h] → none |
| A2960 | ENCOFRADO Y DESENCOFRADO RECTO | 2023-12-11 → 2023-12-20 (+9d) | 2023-12-12 → 2023-12-24 (+12d) | 2d → 5d | 55.89d → 50d | A2980 → A2820, A2980 | resources CAPATAZ [31.4 h]; OPERARIO [62.8 h]; PEON [62.8 h] → none |
| A2970 | ENCOFRADO Y DESENCOFRADO CURVO | 2023-12-11 → 2023-12-20 (+9d) | 2023-12-13 → 2023-12-24 (+11d) | 3d → 5d | 55.89d → 50d |  | resources CAPATAZ [8.14 h]; OPERARIO [16.29 h]; PEON [16.29 h] → none |
| A2950 | CONCRETO f'c=280 kg/cm2 (Buzones) | 2023-12-14 → 2023-12-25 (+11d) | 2023-12-14 → 2023-12-27 (+13d) | 1d → 3d | 55.89d → 52d | A2970 → A2970, A2800 | resources OFICIAL [11.39 h]; OPERARIO [5.7 h]; PEON [59.96 h] → none |
| A2930 | RELLENO COMÚN PARA ZANJAS | 2023-12-19 → 2023-12-29 (+10d) | 2023-12-30 → 2024-01-23 (+24d) | 9.33d → 26d | 89.89d → 93d |  | resources Camión Cisterna 4x2 400 HP Agua (5000 gal) [78.59 h]; CAPATAZ [7.86 h]; CUADRADOR/VIGÍA [78.59 h]; PEON [314.36 h]; Rodillo Vib. Liso Autopropulsado 135 HP 12 TM [78.59 h] → none |
| A2910 | RELLENO ESTRUCTURAL PARA OBRAS DE ARTE CON MATERIAL PROPIO (Buzones) | 2023-12-15 → 2024-01-09 (+25d) | 2023-12-18 → 2024-01-11 (+24d) | 2d → 3d | 55.89d → 89d | A2950 → A2950 FS+12d, A2780 | resources CAPATAZ [1.17 h]; CUADRADOR/VIGÍA [11.65 h]; PEON [46.6 h]; Retroexcavador 58 HP [2.91 h]; Rodillo Vib. Liso Autopropulsado 135 HP 12 TM [11.65 h] → none |
| 5 | **CANAL** | 2023-12-15 → 2023-12-25 (+10d) | 2024-02-10 → 2024-02-29 (+19d) |  |  |  |  |
| A3000 | EXCAVACIÓN ESTRUCTURAL PARA OBRAS DE ARTE | 2023-12-15 → 2023-12-25 (+10d) | 2023-12-22 → 2023-12-30 (+8d) | 6.67d → 6d | 55.89d → 38d | A2900, A2910 SS → A2900 | resources CAPATAZ [5.2 h]; CUADRADOR/VIGÍA [51.99 h]; PEON [207.98 h] → none |
| A3020 | COLOCACIÓN DE CONCRETO f'c=100 kg/cm2 | 2023-12-23 → 2023-12-31 (+8d) | 2023-12-27 → 2024-01-03 (+7d) | 2.67d → 4d | 55.89d → 38d | A3000 → A2940, A3000 | resources CAPATAZ [3.98 h]; OFICIAL [19.9 h]; OPERARIO [39.8 h]; PEON [198.99 h] → none |
| A3050 | ACERO DE REFUERZO fy=4200 kg/cm2 | 2023-12-28 → 2024-01-04 (+7d) | 2024-01-09 → 2024-01-31 (+22d) | 9.33d → 28d | 55.89d → 38d | A3020 → A2980, A3020 | resources CAPATAZ [22.75 h]; OPERARIO [229.58 h]; PEON [229.58 h] → none |
| A3040 | ENCOFRADO Y DESENCOFRADO RECTO | 2024-01-02 → 2024-01-06 (+4d) | 2024-02-03 → 2024-02-26 (+23d) | 27.33d → 52d | 55.89d → 38d | A3050 SS+2.67d → A2970, A3050 SS+2d | resources CAPATAZ [21.4 h]; OPERARIO [62.8 h]; PEON [62.8 h] → none |
| A3030 | COLOCACIÓN DE CONCRETO f'c=280 kg/cm2 | 2024-01-05 → 2024-01-08 (+3d) | 2024-01-27 → 2024-02-29 (+33d) | 18.67d → 53d | 55.89d → 38d | A3040 SS+3d → A2950 SS, A3040 SS+2d | resources OFICIAL [174.63 h]; OPERARIO [87.31 h]; PEON [873.11 h] → none |
| A3060 | JUNTA WATER STOP SIN BULBO 150 mm | 2024-01-29 → 2024-01-08 (-21d) | 2024-01-31 → 2024-02-29 (+29d) | 3d → 53d | 55.89d → 53d | A3030 → A3030 SS | resources OPERARIO [16.08 h]; PEON [16.08 h] → none |
| A3010 | RELLENO ESTRUCTURAL PARA CANALES, CON MATERIAL PROPIO | 2024-02-01 → 2024-01-12 (-20d) | 2024-02-10 → 2024-01-24 (-17d) | 8.33d → 13d | 55.89d → 89d | A3060, A2930 SS → A2910 | resources CAPATAZ [13.06 h]; CUADRADOR/VIGÍA [130.48 h]; PEON [521.87 h] → none |
| 6 | **OBRAS DE DESCARGA** | 2024-02-12 → 2023-12-31 (-43d) | 2024-02-21 → 2024-03-18 (+26d) |  |  |  |  |
| A3070 | EXCAVACIÓN ESTRUCTURAL PARA OBRAS DE ARTE | 2024-02-12 → 2023-12-31 (-43d) | 2024-02-12 → 2024-01-02 (-41d) | 1d → 3d | 55.89d → 87d | A3010 → A3000 | resources CAPATAZ [5.2 h]; CUADRADOR/VIGÍA [51.99 h]; PEON [207.98 h] → none |
| A3090 | CONCRETO f'c=100 kg/cm2 | 2024-02-13 → 2024-01-04 (-40d) | 2024-02-13 → 2024-01-06 (-38d) | 1d → 3d | 55.89d → 86d | A3070 → A3070, A3020 | resources CAPATAZ [0.25 h]; OFICIAL [1.23 h]; OPERARIO [2.45 h]; PEON [12.27 h] → none |
| A3120 | ACERO DE REFUERZO fy=4200 kg/cm2 | 2024-02-14 → 2024-02-01 (-13d) | 2024-02-14 → 2024-02-03 (-11d) | 1d → 3d | 55.89d → 61d | A3090 → A3090, A3050 | resources CAPATAZ [22.75 h]; OPERARIO [229.58 h]; PEON [229.58 h] → none |
| A3110 | ENCOFRADO Y DESENCOFRADO RECTO | 2024-02-15 → 2024-02-27 (+12d) | 2024-02-17 → 2024-02-29 (+12d) | 2.67d → 3d | 55.89d → 38d | A3120 → A3120, A3040 | resources CAPATAZ [31.4 h]; OPERARIO [62.8 h]; PEON [62.8 h] → none |
| A3100 | CONCRETO f'c=280 kg/cm2 | 2024-02-15 → 2024-03-01 (+15d) | 2024-02-15 → 2024-03-03 (+17d) | 1d → 3d | 55.89d → 38d | A3110 SS → A3110, A3030 | resources OFICIAL [122.05 h]; OPERARIO [61.02 h]; PEON [610.24 h] → none |
| A3130 | JUNTA WATER STOP SIN BULBO 150 mm | 2024-02-16 → 2024-03-04 (+17d) | 2024-02-19 → 2024-03-06 (+16d) | 2.67d → 3d | 55.89d → 50d | A3100 → A3100, A3060 | resources OPERARIO [16.08 h]; PEON [16.08 h] → none |
| A3080 | RELLENO ESTRUCTURAL PARA OBRAS DE ARTE CON MATERIAL PROPIO | 2024-02-20 → 2024-03-16 (+25d) | 2024-02-20 → 2024-03-18 (+27d) | 1d → 3d | 55.89d → 38d | A3130 → A3100 FS+12d, A3010 | resources CAPATAZ [0.47 h]; CUADRADOR/VIGÍA [4.66 h]; PEON [18.62 h] → none |
| A3140 | COMPUERTA METALICA PLANA DESLIZANTE | 2024-02-21 → 2024-03-16 (+24d) | 2024-02-21 → 2024-03-18 (+26d) | 1d → 3d | 55.89d → 38d | A3080 → A3100 FS+12d | resources OFICIAL [8 h]; OPERARIO [8 h]; PEON [24 h] → none |
| 2 | **CAPTACIÓN A3-CP-21-05** | 2023-11-22 → 2023-11-09 (-13d) | 2024-01-26 → 2024-02-06 (+11d) |  |  |  |  |
| 1 | **MOVIMIENTO DE TIERRAS** | 2023-11-22 → 2023-11-09 (-13d) | 2024-01-26 → 2023-12-28 (-29d) |  |  |  |  |
| A3150 | EXCAVACIÓN ESTRUCTURAL PARA OBRAS DE ARTE | 2023-11-22 → 2023-11-09 (-13d) | 2023-11-27 → 2023-11-12 (-15d) | 4.23d → 4d | 10.33d → 38d | A2770 SS+0.1d → A1070 SS+7d | resources CAPATAZ [5.2 h]; CUADRADOR/VIGÍA [51.99 h]; PEON [207.98 h]; Retroexcavador 58 HP [51.99 h] → none |
| A3160 | RELLENO ESTRUCTURAL PARA OBRAS DE ARTE, CON MATERIAL PROPIO | 2024-01-18 → 2023-12-24 (-25d) | 2024-01-26 → 2023-12-28 (-29d) | 7.67d → 5d | 64.56d → 119d | A3190 → A3180 FS+12d | resources CAPATAZ [4.86 h]; CUADRADOR/VIGÍA [48.57 h]; PEON [194.28 h]; Retroexcavador 58 HP [12.15 h]; Rodillo Vib. Liso Autopropulsado 135 HP 12 TM [48.57 h] → none |
| 2 | **OBRAS DE CONCRETO** | 2023-11-28 → 2023-11-13 (-15d) | 2024-01-22 → 2023-12-11 (-42d) |  |  |  |  |
| A3170 | CONCRETO f'c=100 kg/cm2 | 2023-11-28 → 2023-11-13 (-15d) | 2023-11-28 → 2023-11-15 (-13d) | 1d → 3d | 64.56d → 79d |  | resources CAPATAZ [0.25 h]; OFICIAL [1.23 h]; OPERARIO [2.45 h]; PEON [12.27 h] → none |
| A3190 | CONCRETO CICLÓPEO f'c=280 kg/cm2 + 30% P.G. | 2024-01-17 → 2023-11-16 (-62d) | 2024-01-17 → 2023-11-18 (-60d) | 1d → 3d | 64.56d → 79d | A3180 → A3170 | resources CAPATAZ [0.45 h]; OPERARIO [2.24 h]; PEON [4.48 h] → none |
| A3210 | ACERO DE REFUERZO fy=4200 kg/cm2 | 2023-11-29 → 2023-11-19 (-10d) | 2024-01-06 → 2023-12-09 (-28d) | 28.33d → 21d | 64.56d → 79d | A3170 → A3190 | resources CAPATAZ [22.75 h]; OPERARIO [229.58 h]; PEON [229.58 h] → none |
| A3200 | ENCOFRADO Y DESENCOFRADO RECTO | 2023-12-02 → 2023-11-25 (-7d) | 2024-01-22 → 2023-12-09 (-44d) | 37.67d → 15d | 67.56d → 82d | A3210 SS+3d → A3210 SS+6d | resources CAPATAZ [31.4 h]; OPERARIO [62.8 h]; PEON [62.8 h] → none |
| A3180 | CONCRETO f'c=280 kg/cm2 | 2024-01-08 → 2023-12-01 (-38d) | 2024-01-16 → 2023-12-11 (-36d) | 7.67d → 11d | 64.56d → 109d | A3210 → A3200 SS+6d | resources OFICIAL [122.05 h]; OPERARIO [61.02 h]; PEON [610.24 h] → none |
| 3 | **ESTRUCTURAS METALICAS** | 2024-01-17 → 2023-12-24 (-24d) | 2024-01-23 → 2024-01-07 (-16d) |  |  |  |  |
| A3220 | COMPUERTA METALICA PLANA DESLIZANTE DE 1.0x1.0m | 2024-01-17 → 2023-12-24 (-24d) | 2024-01-17 → 2023-12-26 (-22d) | 1d → 3d | 67.56d → 109d | A3180 → A3180 FS+12d | resources OFICIAL [4 h]; OPERARIO [4 h]; PEON [12 h] → none |
| A3230 | REJILLA DE 1.00x1.00m CON VARILLA DE 1/2 CADA 6,25cm | 2024-01-17 → 2023-12-27 (-21d) | 2024-01-17 → 2023-12-29 (-19d) | 1d → 3d | 67.56d → 109d | A3220 SS → A3220 | resources OPERARIO [1.6 h]; PEON [3.2 h] → none |
| A3240 | BARANDA DE FIERRO GALVANIZADO 1 1/2" | 2024-01-18 → 2023-12-30 (-19d) | 2024-01-18 → 2024-01-01 (-17d) | 1d → 3d | 67.56d → 109d | A3230 SS+1d → A3230 | resources CAPATAZ [0.12 h]; OFICIAL [2.4 h]; OPERARIO [2.4 h]; PEON [1.2 h] → none |
| A3250 | ESCALERA TIPO GATO | 2024-01-22 → 2024-01-02 (-20d) | 2024-01-22 → 2024-01-04 (-18d) | 0.67d → 3d | 67.56d → 109d | A3240 FS+2d → A3240 | resources CAPATAZ [0.2 h]; OPERARIO [2 h]; PEON [4 h] → none |
| A3260 | TAPA METALICA CIRCULAR DN600 MM | 2024-01-23 → 2024-01-05 (-18d) | 2024-01-23 → 2024-01-07 (-16d) | 1d → 3d | 67.56d → 109d | A3250, A3200 → A3250 | resources OPERARIO [5.33 h]; PEON [5.33 h] → none |
| 4 | **TUBERIA** | 2023-11-28 → 2023-11-13 (-15d) | 2023-12-06 → 2024-01-02 (+27d) |  |  |  |  |
| A3270 | EXCAVACIÓN ESTRUCTURAL PARA OBRAS DE ARTE (Buzones) | 2023-11-28 → 2023-11-13 (-15d) | 2023-11-28 → 2023-11-15 (-13d) | 1d → 3d | 10.33d → 38d |  | resources CAPATAZ [1.85 h]; CUADRADOR/VIGÍA [18.46 h]; PEON [73.86 h]; Retroexcavador 58 HP [18.46 h] → none |
| A3280 | EXCAVACIÓN DE ZANJA | 2023-11-28 → 2023-11-16 (-12d) | 2023-11-28 → 2023-11-18 (-10d) | 1d → 3d | 71.22d → 143d | A3270 SS → A3270 | resources CAPATAZ [8.19 h]; CUADRADOR/VIGÍA [81.86 h]; PEON [327.45 h]; Retroexcavador 58 HP [81.86 h] → none |

| ID | Task | Start | Finish | Duration | Total float | Predecessors | Other |
| --- | --- | --- | --- | --- | --- | --- | --- |
| A3330 | CONCRETO f'c=100 kg/cm2 (Buzones) | 2023-11-29 → 2023-11-16 (-13d) | 2023-11-29 → 2023-11-18 (-11d) | 1d → 3d | 32.22d → 100d | A3270 → A3270, A3170 | resources CAPATAZ [0.25 h]; OFICIAL [1.23 h]; OPERARIO [2.45 h]; PEON [12.27 h] → none |
| A3300 | CAMA DE ARENA | 2023-11-29 → 2023-11-19 (-10d) | 2023-11-29 → 2023-11-21 (-8d) | 1d → 3d | 71.22d → 143d |  | resources CAPATAZ [2.78 h]; PEON [22.21 h] → none |
| A3380 | SUMINISTRO E INSTALACIÓN DE TUBERÍA GRP DN600 mm SN2500 | 2023-11-30 → 2023-11-22 (-8d) | 2023-11-30 → 2023-11-24 (-6d) | 1d → 3d | 71.22d → 143d |  | resources CAPATAZ [0.09 h]; Excavadora Sobre Oruga 260 HP [0.91 h]; OFICIAL [0.91 h]; PEON [1.81 h] → none |
| A3310 | RELLENO SELECCIONADO PARA ZANJAS CON MATERIAL PROPIO | 2023-12-01 → 2023-11-25 (-6d) | 2023-12-04 → 2023-11-27 (-7d) | 2.67d → 3d | 71.22d → 143d | A3380 → A3320 SS | resources CAPATAZ [0.96 h]; CUADRADOR/VIGÍA [9.63 h]; PEON [38.53 h]; Retroexcavador 58 HP [2.41 h]; Rodillo Vib. Liso Autopropulsado 135 HP 12 TM [9.63 h] → none |
| A3320 | RELLENO COMÚN PARA ZANJAS | 2023-12-05 → 2023-11-25 (-10d) | 2023-12-05 → 2023-11-27 (-8d) | 1d → 3d | 71.22d → 143d | A3310, A3340 → A3380 | resources Camión Cisterna 4x2 400 HP Agua (5000 gal) [78.59 h]; CAPATAZ [7.86 h]; CUADRADOR/VIGÍA [78.59 h]; PEON [314.36 h]; Rodillo Vib. Liso Autopropulsado 135 HP 12 TM [78.59 h] → none |
| A3370 | ACERO DE REFUERZO fy=4200 kg/cm2 | 2023-11-30 → 2023-12-10 (+10d) | 2023-11-30 → 2023-12-12 (+12d) | 1d → 3d | 32.22d → 79d | A3330 → A3330, A3210 | resources CAPATAZ [1.88 h]; OPERARIO [18.94 h]; PEON [18.94 h] → none |
| A3350 | ENCOFRADO Y DESENCOFRADO RECTO | 2023-12-01 → 2023-12-13 (+12d) | 2023-12-01 → 2023-12-15 (+14d) | 1d → 3d | 32.22d → 79d | A3370 → A3370, A3200 | resources CAPATAZ [31.4 h]; OPERARIO [62.8 h]; PEON [62.8 h] → none |
| A3360 | ENCOFRADO Y DESENCOFRADO CURVO | 2023-12-02 → 2023-12-13 (+11d) | 2023-12-05 → 2023-12-15 (+10d) | 2.67d → 3d | 32.22d → 79d | A3350 → A3350 SS | resources CAPATAZ [8.14 h]; OPERARIO [16.29 h]; PEON [16.29 h] → none |
| A3340 | CONCRETO f'c=280 kg/cm2 (Buzones) | 2023-12-04 → 2023-12-16 (+12d) | 2023-12-04 → 2023-12-18 (+14d) | 1d → 3d | 71.22d → 105d | A3360 SS+0.67d → A3360, A3180 | resources OFICIAL [11.39 h]; OPERARIO [5.7 h]; PEON [56.96 h] → none |
| A3290 | RELLENO ESTRUCTURAL PARA OBRAS DE ARTE CON MATERIAL PROPIO | 2023-12-06 → 2023-12-31 (+25d) | 2023-12-06 → 2024-01-02 (+27d) | 1d → 3d | 32.22d → 107d | A3360 → A3340 FS+12d | resources CAPATAZ [1.17 h]; CUADRADOR/VIGÍA [11.65 h]; PEON [46.6 h]; Retroexcavador 58 HP [2.91 h]; Rodillo Vib. Liso Autopropulsado 135 HP 12 TM [11.65 h] → none |
| 5 | **CANALES** | 2023-11-28 → 2023-11-16 (-12d) | 2024-01-18 → 2024-02-06 (+19d) |  |  |  |  |
| A3390 | EXCAVACIÓN ESTRUCTURAL PARA OBRAS DE ARTE | 2023-11-28 → 2023-11-16 (-12d) | 2023-12-04 → 2023-11-20 (-14d) | 5.67d → 5d | 10.33d → 38d | A3270 SS → A3270 | resources CAPATAZ [5.2 h]; CUADRADOR/VIGÍA [51.99 h]; PEON [207.98 h] → none |
| A3410 | COLOCACIÓN DE CONCRETO f'c=100 kg/cm2 | 2023-12-05 → 2023-11-21 (-14d) | 2023-12-05 → 2023-11-23 (-12d) | 1d → 3d | 71.22d → 98d | A3390 → A3390, A3330 | resources CAPATAZ [3.98 h]; OFICIAL [19.9 h]; OPERARIO [39.8 h]; PEON [198.99 h] → none |
| A3440 | ACERO DE REFUERZO fy=4200 kg/cm2 | 2023-12-06 → 2023-12-13 (+7d) | 2023-12-20 → 2023-12-24 (+4d) | 10d → 12d | 71.22d → 79d | A3410, A3320 → A3410, A3370 | resources CAPATAZ [22.75 h]; OPERARIO [229.58 h]; PEON [229.58 h] → none |
| A3430 | ENCOFRADO Y DESENCOFRADO | 2023-12-11 → 2023-12-16 (+5d) | 2024-01-09 → 2024-01-13 (+4d) | 22.67d → 29d | 71.22d → 79d | A3440 SS+2d → A3440 SS+3d, A3360 | resources CAPATAZ [31.4 h]; OPERARIO [62.8 h]; PEON [62.8 h] → none |
| A3420 | COLOCACIÓN DE CONCRETO f'c=280 kg/cm2 | 2023-12-15 → 2024-01-14 (+30d) | 2023-12-18 → 2024-01-18 (+31d) | 2.67d → 5d | 87.22d → 79d | A3450 → A3430, A3340 | resources OFICIAL [174.63 h]; OPERARIO [87.31 h]; PEON [873.11 h] → none |
| A3450 | JUNTA WATER STOP SIN BULBO 150 mm | 2023-12-14 → 2024-01-14 (+31d) | 2023-12-14 → 2024-01-16 (+33d) | 1d → 3d | 87.22d → 100d | A3430 SS+3d → A3420 SS | resources OPERARIO [16.08 h]; PEON [16.08 h] → none |
| A3400 | RELLENO ESTRUCTURAL PARA CANALES, CON MATERIAL PROPIO | 2024-01-10 → 2024-01-31 (+21d) | 2024-01-18 → 2024-02-06 (+19d) | 7.67d → 7d | 71.22d → 79d | A3430, A3420 → A3420 FS+12d, A3290, A3310 | resources CAPATAZ [13.06 h]; CUADRADOR/VIGÍA [130.48 h]; PEON [521.87 h]; Retroexcavador 58 HP [32.63 h]; Rodillo Vib. Liso Autopropulsado 135 HP 12 TM [130.48 h] → none |
| 3 | **RETORNO A3-OA-RE-D-21-55** | 2023-11-28 → 2023-11-06 (-22d) | 2024-01-06 → 2023-12-29 (-8d) |  |  |  |  |
| 1 | **MOVIMIENTO DE TIERRAS** | 2023-11-28 → 2023-11-06 (-22d) | 2024-01-05 → 2023-12-25 (-11d) |  |  |  |  |
| A3460 | EXCAVACIÓN ESTRUCTURAL PARA OBRAS DE ARTE | 2023-11-28 → 2023-11-06 (-22d) | 2023-11-28 → 2023-11-08 (-20d) | 1d → 3d | 10.33d → 118d | A3390 SS → A1070 SS+4d | resources CAPATAZ [5.2 h]; CUADRADOR/VIGÍA [51.99 h]; PEON [207.98 h]; Retroexcavador 58 HP [51.99 h] → none |
| A3470 | RELLENO ESTRUCTURAL PARA OBRAS DE ARTE, CON MATERIAL PROPIO | 2024-01-05 → 2023-12-23 (-13d) | 2024-01-05 → 2023-12-25 (-11d) | 1d → 3d | 81.56d → 122d | A3500 → A3490 FS+12d | resources CAPATAZ [4.86 h]; CUADRADOR/VIGÍA [48.57 h]; PEON [194.28 h]; Retroexcavador 58 HP [12.15 h]; Rodillo Vib. Liso Autopropulsado 135 HP 12 TM [48.57 h] → none |
| 2 | **OBRAS DE CONCRETO** | 2023-11-29 → 2023-11-09 (-20d) | 2024-01-06 → 2023-12-10 (-27d) |  |  |  |  |
| A3480 | CONCRETO f'c=100 kg/cm2 | 2023-11-29 → 2023-11-09 (-20d) | 2023-11-29 → 2023-11-11 (-18d) | 1d → 3d | 10.33d → 118d |  | resources CAPATAZ [0.25 h]; OFICIAL [1.23 h]; OPERARIO [2.45 h]; PEON [12.27 h] → none |
| A3500 | CONCRETO CICLÓPEO f'c=280 kg/cm2 + 30% P.G. | 2024-01-03 → 2023-11-12 (-52d) | 2024-01-04 → 2023-11-16 (-49d) | 2d → 5d | 81.56d → 118d | A3490 → A3480 | resources CAPATAZ [0.45 h]; OPERARIO [2.24 h]; PEON [4.48 h] → none |
| A3520 | ACERO DE REFUERZO fy=4200 kg/cm2 | 2023-11-30 → 2023-11-12 (-18d) | 2023-12-23 → 2023-12-05 (-18d) | 18d → 24d | 10.33d → 118d | A3480 → A3500 SS | resources CAPATAZ [22.75 h]; OPERARIO [229.58 h]; PEON [229.58 h] → none |
| A3510 | ENCOFRADO Y DESENCOFRADO | 2023-12-07 → 2023-11-18 (-19d) | 2024-01-06 → 2023-12-05 (-32d) | 21.67d → 18d | 32.22d → 118d | A3520 SS+5.67d, A3290 → A3520 SS+6d | resources CAPATAZ [31.4 h]; OPERARIO [62.8 h]; PEON [62.8 h] → none |
| A3490 | CONCRETO f'c=280 kg/cm2 | 2023-12-29 → 2023-12-06 (-23d) | 2024-01-02 → 2023-12-10 (-23d) | 2.67d → 5d | 81.56d → 118d | A3530 → A3510 | resources OFICIAL [122.05 h]; OPERARIO [61.02 h]; PEON [610.24 h] → none |
| A3530 | JUNTA WATER STOP SIN BULBO 150 mm | 2023-12-26 → 2023-12-06 (-20d) | 2023-12-28 → 2023-12-10 (-18d) | 3d → 5d | 81.56d → 137d | A3520 → A3490 SS | resources OPERARIO [16.08 h]; PEON [16.08 h] → none |
| 3 | **ESTRUCTURAS METALICAS** | 2024-01-03 → 2023-12-23 (-11d) | 2024-01-04 → 2023-12-29 (-6d) |  |  |  |  |
| A3540 | COMPUERTA METALICA PLANA DESLIZANTE DE 1.0x1.6 m | 2024-01-03 → 2023-12-23 (-11d) | 2024-01-04 → 2023-12-26 (-9d) | 2d → 4d | 83.56d → 118d | A3490 → A3490 FS+12d | resources OFICIAL [4 h]; OPERARIO [4 h]; PEON [12 h] → none |
| A3550 | BARANDA DE FIERRO GALVANIZADO 1 1/2" | 2024-01-03 → 2023-12-27 (-7d) | 2024-01-03 → 2023-12-29 (-5d) | 1d → 3d | 83.56d → 118d | A3540 SS → A3540 | resources CAPATAZ [0.12 h]; OFICIAL [2.4 h]; OPERARIO [2.4 h]; PEON [1.2 h] → none |
| 4 | **REPOSICIÓN DE CANALES** | 2023-12-23 → 2023-11-22 (-31d) | 2024-03-23 → 2024-04-22 (+30d) |  |  |  |  |
| 1 | **REPOSICIÓN DE CANAL 1** | 2023-12-23 → 2024-01-17 (+25d) | 2024-03-23 → 2024-04-22 (+30d) |  |  |  |  |
| 1 | **MOVIMIENTO DE TIERRAS** | 2023-12-23 → 2024-01-17 (+25d) | 2024-03-02 → 2024-04-22 (+51d) |  |  |  |  |
| A3560 | DEMOLICIÓN DE ESTRUCTURAS EXISTENTES | 2023-12-23 → 2024-01-17 (+25d) | 2024-01-04 → 2024-02-02 (+29d) | 8.33d → 17d | 10.33d → 83d | A3520 SS+17.33d → A1530 | resources CAPATAZ [6.98 h]; CUADRADOR/VIGÍA [69.68 h]; Excavadora Sobre Oruga 260 HP [69.68 h]; OPERARIO [139.32 h]; PEON [139.32 h] → none |
| A3580 | RELLENO ESTRUCTURAL PARA OBRAS DE ARTE CON MATERIAL PROPIO | 2024-02-15 → 2024-03-15 (+29d) | 2024-03-02 → 2024-04-22 (+51d) | 14d → 39d | 33.56d → 3d | A3620 → A3620 SS+20d, A3670 | resources CAPATAZ [0.47 h]; CUADRADOR/VIGÍA [4.66 h]; PEON [18.62 h]; Retroexcavador 58 HP [1.16 h]; Rodillo Vib. Liso Autopropulsado 135 HP 12 TM [4.66 h] → none |
| 2 | **OBRAS DE CONCRETO** | 2024-01-09 → 2024-01-31 (+22d) | 2024-03-23 → 2024-04-20 (+28d) |  |  |  |  |
| A3610 | CONCRETO f'c=100 kg/cm2 | 2024-01-09 → 2024-01-31 (+22d) | 2024-01-18 → 2024-03-06 (+48d) | 8.67d → 36d | 31.22d → 3d | A1440, A3510 → A3570 SS+7d | resources CAPATAZ [0.25 h]; OFICIAL [1.23 h]; OPERARIO [2.45 h]; PEON [12.27 h] → none |
| A3600 | ACERO DE REFUERZO fy=4200 kg/cm2 | 2024-01-19 → 2024-02-03 (+15d) | 2024-02-19 → 2024-04-12 (+53d) | 25.33d → 70d | 31.22d → 3d | A3610 → A3610 SS+3d | resources CAPATAZ [22.75 h]; OPERARIO [229.58 h]; PEON [229.58 h] → none |
| A3590 | ENCOFRADO Y DESENCOFRADO RECTO | 2024-01-24 → 2024-02-10 (+17d) | 2024-03-23 → 2024-04-12 (+20d) | 49d → 63d | 31.22d → 3d | A3600 SS+3.67d → A3600 SS+7d | resources CAPATAZ [31.4 h]; OPERARIO [62.8 h]; PEON [62.8 h] → none |
| A3620 | CONCRETO f'c=280 kg/cm2 | 2024-01-29 → 2024-02-24 (+26d) | 2024-02-14 → 2024-04-17 (+63d) | 14.33d → 54d | 33.56d → 3d | A3630 SS+1.67d → A3590 SS+14d | resources OFICIAL [122.05 h]; OPERARIO [61.02 h]; PEON [610.24 h] → none |
| A3630 | JUNTA WATER STOP 6" | 2024-01-26 → 2024-02-24 (+29d) | 2024-01-29 → 2024-04-17 (+79d) | 2.67d → 54d | 33.56d → 8d | A3590 SS+2d → A3620 SS | resources OPERARIO [47.42 h]; PEON [47.42 h] → none |
| A3640 | MAMPOSTERIA DE PIEDRA, e=20cm, ACABADO CARA VISTA | 2024-02-15 → 2024-04-18 (+63d) | 2024-02-15 → 2024-04-20 (+65d) | 1d → 3d | 47.56d → 5d |  | resources CAPATAZ [0.24 h]; OFICIAL [2.4 h]; OPERARIO [2.4 h]; PEON [12 h] → none |
| 2 | **REPOSICIÓN DE CANAL 3** | 2024-01-05 → 2023-11-22 (-44d) | 2024-03-07 → 2024-01-19 (-48d) |  |  |  |  |
| 1 | **MOVIMIENTO DE TIERRAS** | 2024-01-05 → 2023-11-22 (-44d) | 2024-03-06 → 2024-01-19 (-47d) |  |  |  |  |
| A3650 | DEMOLICIÓN DE ESTRUCTURAS EXISTENTES | 2024-01-05 → 2023-11-22 (-44d) | 2024-01-11 → 2023-12-01 (-41d) | 5.67d → 10d | 10.33d → 70d | A3560 → A1260 | resources CAPATAZ [6.98 h]; CUADRADOR/VIGÍA [69.68 h]; Excavadora Sobre Oruga 260 HP [69.68 h]; OPERARIO [139.32 h]; PEON [139.32 h] → none |
| A3670 | RELLENO ESTRUCTURAL PARA OBRAS DE ARTE CON MATERIAL PROPIO | 2024-03-06 → 2024-01-17 (-49d) | 2024-03-06 → 2024-01-19 (-47d) | 1d → 3d | 31.56d → 58d | A3680, A3580 → A3720 FS+6d | resources CAPATAZ [0.47 h]; CUADRADOR/VIGÍA [4.66 h]; PEON [18.62 h]; Retroexcavador 58 HP [1.16 h]; Rodillo Vib. Liso Autopropulsado 135 HP 12 TM [4.66 h] → none |
| 2 | **OBRAS DE CONCRETO** | 2024-01-13 → 2023-12-18 (-26d) | 2024-03-07 → 2024-01-13 (-54d) |  |  |  |  |
| A3710 | CONCRETO f'c=100 kg/cm2 | 2024-01-13 → 2023-12-18 (-26d) | 2024-01-16 → 2023-12-21 (-26d) | 2.67d → 4d | 31.56d → 58d | A4030 → A3660 | resources CAPATAZ [0.25 h]; OFICIAL [1.23 h]; OPERARIO [2.45 h]; PEON [12.27 h] → none |
| A3700 | MALLA ELECTROSOLDADA DE DN6mm EN CUADRICULA 15x15 cm | 2024-01-17 → 2023-12-22 (-26d) | 2024-02-21 → 2024-01-05 (-47d) | 29.33d → 15d | 31.56d → 58d |  | resources CAPATAZ [74.09 h]; OPERARIO [740.91 h]; PEON [1481.82 h] → none |
| A3680 | ENCOFRADO Y DESENCOFRADO PARA REVESTIMIENTO DE CANALES (CERCHAS) | 2024-03-04 → 2023-12-25 (-70d) | 2024-03-05 → 2024-01-05 (-60d) | 2d → 12d | 31.56d → 58d | A3690 → A3700 SS+3d | resources CAPATAZ [7.21 h]; OPERARIO [14.41 h]; PEON [14.41 h] → none |
| A3690 | ENCOFRADO Y DESENCOFRADO RECTO | 2024-02-01 → 2023-12-25 (-38d) | 2024-03-02 → 2024-01-05 (-57d) | 25.33d → 12d | 31.56d → 58d | A3700 SS+12.33d → A3680 SS | resources CAPATAZ [31.4 h]; OPERARIO [62.8 h]; PEON [62.8 h] → none |
| A3730 | SELLO DE JUNTA CONSTRUCCIÓN CON MATERIAL ELASTOMÉRICO | 2024-02-27 → 2023-12-25 (-64d) | 2024-03-06 → 2024-01-03 (-63d) | 7.67d → 10d | 31.56d → 113d | A3720 → A3680 SS | resources CAPATAZ [12.36 h]; OFICIAL [123.55 h]; PEON [123.55 h] → none |
| A3720 | CONCRETO f'c=280 kg/cm2 | 2024-02-22 → 2024-01-06 (-47d) | 2024-02-26 → 2024-01-10 (-47d) | 3.67d → 5d | 31.56d → 58d | A3700 → A3690 | resources OFICIAL [122.05 h]; OPERARIO [61.02 h]; PEON [610.24 h] → none |
| A3740 | MAMPOSTERIA DE PIEDRA, e=20cm, ACABADO CARA VISTA | 2024-03-07 → 2024-01-11 (-56d) | 2024-03-07 → 2024-01-13 (-54d) | 1d → 3d | 31.56d → 103d | A3730, A3640, A3670 → A3720 | resources CAPATAZ [0.24 h]; OFICIAL [2.4 h]; OPERARIO [2.4 h]; PEON [12 h] → none |
| 5 | **REPOSICIÓN SIFON INOPERATIVO** | 2024-01-12 → 2023-12-08 (-35d) | 2024-02-14 → 2024-01-16 (-29d) |  |  |  |  |
| A3750 | DEMOLICIÓN DE ESTRUCTURAS EXISTENTES | 2024-01-12 → 2023-12-08 (-35d) | 2024-01-12 → 2023-12-10 (-33d) | 1d → 3d | 10.33d → 100d | A3650 → A1230, A1880 | resources CAPATAZ [6.98 h]; CUADRADOR/VIGÍA [69.68 h]; Excavadora Sobre Oruga 260 HP [69.68 h]; OPERARIO [139.32 h]; PEON [139.32 h] → none |
| A3760 | EXCAVACIÓN ESTRUCTURAL PARA OBRAS DE ARTE | 2024-01-13 → 2023-12-11 (-33d) | 2024-01-26 → 2023-12-20 (-37d) | 11.33d → 10d | 10.33d → 100d |  | resources CAPATAZ [5.2 h]; CUADRADOR/VIGÍA [51.99 h]; PEON [207.98 h]; Retroexcavador 58 HP [51.99 h] → none |
| A3770 | COLOCACIÓN CAMA DE ARENA | 2024-01-27 → 2023-12-21 (-37d) | 2024-01-27 → 2023-12-23 (-35d) | 0.67d → 3d | 10.33d → 109d |  | resources CAPATAZ [1.47 h]; PEON [11.79 h] → none |
| A3810 | CONCRETO f'c=100 kg/cm2 | 2024-02-09 → 2023-12-21 (-50d) | 2024-02-09 → 2023-12-23 (-48d) | 1d → 3d | 10.33d → 100d | A3850 → A3760 | resources CAPATAZ [0.25 h]; OFICIAL [1.23 h]; OPERARIO [2.45 h]; PEON [12.27 h] → none |
| A3800 | TUBERÍAS DE 14" HDPE SDR21 DN 355mm | 2024-01-29 → 2023-12-24 (-36d) | 2024-02-07 → 2023-12-29 (-40d) | 8.67d → 6d | 10.33d → 109d |  | resources CAPATAZ [7 h]; OPERARIO [70.06 h]; PEON [210.21 h]; Retroexcavador 58 HP [70.06 h] → none |
| A3840 | ACERO DE REFUERZO fy=4200 kg/cm2 | 2024-02-10 → 2023-12-24 (-48d) | 2024-02-10 → 2023-12-26 (-46d) | 0.67d → 3d | 10.33d → 100d |  | resources CAPATAZ [22.75 h]; OPERARIO [229.58 h]; PEON [229.58 h] → none |
| A3850 | CODOS HDPE DE 14" DN 355mm | 2024-02-08 → 2023-12-24 (-46d) | 2024-02-08 → 2023-12-29 (-41d) | 1d → 6d | 10.33d → 118d | A3800 → A3800 SS | resources CAPATAZ [0.32 h]; OPERARIO [3.2 h]; PEON [9.6 h] → none |
| A3830 | ENCOFRADO Y DESENCOFRADO RECTO | 2024-02-12 → 2023-12-27 (-47d) | 2024-02-12 → 2023-12-29 (-45d) | 1d → 3d | 10.33d → 100d |  | resources CAPATAZ [31.4 h]; OPERARIO [62.8 h]; PEON [62.8 h] → none |
| A3790 | RELLENO COMÚN | 2024-02-08 → 2023-12-30 (-40d) | 2024-02-13 → 2024-01-07 (-37d) | 4.44d → 9d | 11.56d → 109d |  | resources Camión Cisterna 4x2 400 HP Agua (5000 gal) [28.57 h]; CAPATAZ [2.86 h]; CUADRADOR/VIGÍA [28.57 h]; PEON [114.27 h]; Rodillo Vib. Liso Autopropulsado 135 HP 12 TM [28.57 h] → none |
| A3820 | CONCRETO f'c=280 kg/cm2 | 2024-02-13 → 2023-12-30 (-45d) | 2024-02-13 → 2024-01-01 (-43d) | 1d → 3d | 10.33d → 100d |  | resources OFICIAL [122.05 h]; OPERARIO [61.02 h]; PEON [610.24 h] → none |
| A3780 | RELLENO ESTRUCTURAL PARA OBRAS DE ARTE CON MATERIAL PROPIO | 2024-02-14 → 2024-01-14 (-31d) | 2024-02-14 → 2024-01-16 (-29d) | 1d → 3d | 10.33d → 100d | A3820, A3790 FF → A3820 FS+12d | resources CAPATAZ [0.47 h]; CUADRADOR/VIGÍA [4.66 h]; PEON [18.62 h] → none |
| 3 | **ARQUITECTURA Y PAISAJISMO** | 2024-02-20 → 2024-01-26 (-25d) | 2024-04-19 → 2024-04-08 (-11d) |  |  |  |  |
| 1 | **OBRAS PRELIMINARES** | 2024-02-20 → 2024-01-26 (-25d) | 2024-02-28 → 2024-04-08 (+40d) |  |  |  |  |

| ID | Task | Start | Finish | Duration | Total float | Predecessors | Other |
| --- | --- | --- | --- | --- | --- | --- | --- |
| A3870 | TRAZO Y REPLANTEO PRELIMINAR | 2024-02-21 → 2024-01-28 (-24d) | 2024-02-28 → 2024-01-29 (-30d) | 6.67d → 2d | 10.33d → 17d | MOVILIZACIÓN Y DEMOVILIZACIÓN DE EQUIPOS Y HERRAMIENTAS (ARQUITECTURA Y PAISAJISMO) → A3860 | resources OPERARIO [55.06 h]; PEON [110.12 h]; TOPOGRAFO [55.06 h] → none |
| 2 | **MOVIMIENTO DE TIERRAS** | 2024-02-29 → 2024-01-30 (-30d) | 2024-03-12 → 2024-02-15 (-26d) |  |  |  |  |
| A3880 | EXCAVACIÓN MANUAL PARA INSTALACIÓN DE BORDILLOS Y CIMENTACIONES | 2024-02-29 → 2024-01-30 (-30d) | 2024-02-29 → 2024-01-31 (-29d) | 1d → 2d | 10.33d → 17d |  | resources CAPATAZ [0.76 h]; PEON [7.57 h] → none |
| A3900 | ELIMINACION DE MATERIAL EXCEDENTE (DME´S) | 2024-03-12 → 2024-01-30 (-42d) | 2024-03-12 → 2024-02-15 (-26d) | 1d → 17d | 10.33d → 68d | A3890 → A3880 SS | resources Camión Volquete (15 m3) [0.74 h]; CAPATAZ [0.12 h]; Excavadora Sobre Oruga 260 HP [0.25 h]; OPERARIO [0.25 h]; PEON [1.49 h]; Tractor S/Orugas (D6T) - 180 HP [0.25 h] → none |
| A3890 | EXCAVACIÓN PARA MEJORAMIENTO DE SUELO CON TIERRA VEGETAL | 2024-02-29 → 2024-02-01 (-28d) | 2024-03-11 → 2024-02-15 (-25d) | 9.33d → 15d | 10.33d → 17d | A3880 SS → A3880 | resources CAPATAZ [7.86 h]; PEON [78.63 h] → none |
| 3 | **PAVIMENTOS, RECUBRIMIENTOS Y BORDILLOS** | 2024-03-13 → 2024-02-16 (-26d) | 2024-04-03 → 2024-02-26 (-37d) |  |  |  |  |
| A3910 | PISO DE GRAVILLA | 2024-03-13 → 2024-02-16 (-26d) | 2024-03-13 → 2024-02-17 (-25d) | 1d → 2d | 10.33d → 17d | A3900 → A3890 | resources CAPATAZ [0.2 h]; OPERARIO [2 h]; PEON [3.99 h] → none |
| A3920 | RECUBRIMIENTO DE PIEDRA DEL LUGAR e=0.05cm | 2024-03-14 → 2024-02-18 (-25d) | 2024-03-23 → 2024-02-21 (-31d) | 8.33d → 4d | 10.33d → 17d |  | resources CAPATAZ [6.52 h]; OFICIAL [130.46 h]; PEON [130.46 h] → none |
| A3930 | BORDILLOS DE PIEDRA DEL LUGAR | 2024-03-25 → 2024-02-22 (-32d) | 2024-04-03 → 2024-02-26 (-37d) | 6.67d → 5d | 10.33d → 17d |  | resources CAPATAZ [4.96 h]; OFICIAL [99.2 h]; PEON [99.2 h] → none |
| 4 | **MOBILIARIOS, BARANDAS Y ESCALERAS** | 2024-04-04 → 2024-02-27 (-37d) | 2024-04-11 → 2024-04-04 (-7d) |  |  |  |  |
| A3940 | ESCALERA DE CONCRETO SOBRE ENROCADO, CIMENTACION Y ANCLAJE | 2024-04-04 → 2024-02-27 (-37d) | 2024-04-04 → 2024-03-07 (-28d) | 1d → 10d | 10.33d → 17d |  |  |
| A3950 | BARANDA DE MADERA EUCALIPTO CON SOGA, INCLUYE CIMENTACIÓN | 2024-04-04 → 2024-03-08 (-27d) | 2024-04-04 → 2024-03-11 (-24d) | 1d → 4d | 10.33d → 17d | A3940 SS → A3940 | resources CAPATAZ [0.36 h]; PEON [14.4 h] → none |
| A3960 | TACHOS DE BASURA, INCLUYE CIMENTACIÓN | 2024-04-04 → 2024-03-12 (-23d) | 2024-04-04 → 2024-03-14 (-21d) | 1d → 3d | 10.33d → 17d | A3940 SS, A3950 SS → A3950 |  |
| A3970 | BANCAS DE CONCRETO, INCLUYE CIMENTACIÓN | 2024-04-05 → 2024-03-15 (-21d) | 2024-04-05 → 2024-03-24 (-12d) | 1d → 10d | 10.33d → 17d |  |  |
| A3980 | POSTES DE ILUMINACIÓN, INCLUYE LUMINARIA Y CIMENTACIÓN | 2024-04-06 → 2024-03-25 (-12d) | 2024-04-10 → 2024-03-29 (-12d) | 3.89d → 5d | 10.33d → 17d |  | resources CAPATAZ [3.2 h]; OPERARIO [3.2 h]; PEON [64 h] → none |
| A3990 | SEÑALETICA INFORMATIVA | 2024-04-11 → 2024-03-30 (-12d) | 2024-04-11 → 2024-04-01 (-10d) | 1d → 3d | 17.67d → 17d |  |  |
| A4000 | BOLARDOS DE PIEDRA | 2024-04-08 → 2024-04-02 (-6d) | 2024-04-10 → 2024-04-04 (-6d) |  | 10.33d → 17d | A3980 SS+0.89d → A3990 | resources CAPATAZ [2.4 h]; PEON [6 h] → none |
| A4010 | ALCORQUES DE PIEDRA DE CANTO RODADO PARA ARBOLES | 2024-04-19 → 2024-04-05 (-14d) | 2024-04-19 → 2024-04-06 (-13d) | 1d → 2d | 10.33d → 17d | INST. ENCELIA CANESCEN GIRASOL SILVESTRE (0.20m a 0.30m) → A4000 | resources CAPATAZ [0.02 h]; OFICIAL [0.2 h]; PEON [0.4 h] → none |
| 4 | **PROGRAMA DE CIERRE DE OBRA** | 2024-04-10 → 2023-11-06 (-156d) | 2024-05-04 → 2024-04-21 (-13d) |  |  |  |  |
| A1780 | RESTAURACIÓN DE ÁREAS DE INSTALACIONES PROVISIONALES | 2024-04-10 → 2024-04-14 (+4d) | 2024-04-25 → 2024-04-21 (-4d) | 12d → 8d | 6.24d → 4d | A2160 FS+4.65d, A3160, A3260, A3400, A3470, A3550, A3740 → A2480, A1770 | resources Camión Cisterna 4x2 400 HP Agua (5000 gal) [2342.82 h]; CAPATAZ [2306.82 h]; CUADRADOR/VIGÍA [2302.82 h]; Motoniveladora 185 HP [40 h]; OPERARIO [2302.82 h]; PEON [2462.82 h]; Retroexcavador 58 HP [1138.47 h]; Rodillo Vib. Liso Autopropulsado 135 HP 12 TM [40 h]; Tractor S/Orugas (D6T) - 180 HP [2342.82 h] → none |

## Version 5 (data date 2023-11-01, saved 2024-03-18, file CRONOGRAMA_LACRAMARCA.REV02.xer)

Last finish 2024-04-27 → 2024-11-08 (+195d).

Added:

| ID | Task | Duration | Start | Finish | Predecessors | Constraint |
| --- | --- | --- | --- | --- | --- | --- |
| 000002 | INICIO | 0d | 2024-05-01 | 2024-05-01 |  | start on or after 2024-05-01 |
| 000003 | KOM | 0d | 2024-05-03 | 2024-05-03 | 000002 FS+2d | start on or after 2022-10-04 |
| 000004 | ENTREGA DE TERRENO | 0d | 2024-05-04 | 2024-05-04 | 000003 FS+1d | start on or after 2022-10-06 |
| 000005 | NOTIFICACION DE OS | 0d | 2024-05-04 | 2024-05-04 | 000004 | start on or after 2022-10-07 |
| 000006 | Inicio OS | 0d | 2024-05-04 | 2024-05-04 | 000005 | start on or after 2022-10-07 |
| 000007 | Inicio del Proyecto | 0d | 2024-05-04 | 2024-05-04 | 000006 | start on or after 2017-07-01 |
| 000008 | Fin de la Construccion | 0d | 2024-11-08 | 2024-11-08 | 000263 |  |
| 4 | **DESCOLMATACIÓN DE CAUCE y OBRAS AUXILIARES** |  | 2024-05-22 | 2024-09-11 |  |  |
| 000033 | DESCOLMATACIÓN DE CAUCE NATURAL DEL RÍO LACRAMARCA | 113d | 2024-05-22 | 2024-09-11 | 000032 FS-113d |  |
| 000034 | CONFORMACIÓN DE DESVIO EN CAUCE DE RÍO | 113d | 2024-05-22 | 2024-09-11 | 000033 FS-113d |  |
| 000035 | RELLENO NO ESTRUCTURAL CON MATERIAL PROPIO | 113d | 2024-05-22 | 2024-09-11 | 000034 FS-113d |  |
| 3 | **TRANSPORTE DE MATERIAL** |  | 2024-05-15 | 2024-11-06 |  |  |
| 000229 | TRANSPORTE DE ROCA PARA DISTANCIAS <1KM | 172d | 2024-05-15 | 2024-11-02 | 000228 FS-174d |  |
| 000228 | TRANSPORTE DE MATERIAL GRANULAR PARA DISTANCIAS >1KM | 172d | 2024-05-17 | 2024-11-04 | 000227 FS-174d |  |
| 000227 | TRANSPORTE DE MATERIAL GRANULAR PARA DISTANCIAS <1KM | 172d | 2024-05-19 | 2024-11-06 | 000023 SS |  |
| 000230 | TRANSPORTE DE ROCA PARA DISTANCIAS >1KM | 172d | 2024-05-19 | 2024-11-06 | 000227 SS |  |
| 000231 | TRANSPORTE DE MATERIAL EXCEDENTE PARA DISTANCIAS <1KM | 172d | 2024-05-19 | 2024-11-06 | 000227 SS |  |
| 000232 | TRANSPORTE DE MATERIAL EXCEDENTE PARA DISTANCIAS >1KM | 172d | 2024-05-19 | 2024-11-06 | 000227 SS |  |
| 000235 | MOVILIZACIÓN Y DEMOVILIZACIÓN DE EQUIPOS Y HERRAMIENTAS (ARQUITECTURA Y PAISAJISMO) | 18d | 2024-05-19 | 2024-06-05 | 000227 SS |  |
| 5 | **INSTALACION DE ALCORQUES** |  | 2024-05-19 | 2024-05-20 |  |  |
| 6 | **SEGURIDAD Y SALUD OCUPACIONAL** |  | 2024-05-19 | 2024-11-06 |  |  |
| 000259 | SEGURIDAD Y SALUD OCUPACIONAL | 172d | 2024-05-19 | 2024-11-06 | 000256 SS |  |
| 7 | **LIMPIEZA Y ENTREGA** |  | 2024-10-30 | 2024-11-08 |  |  |
| 000262 | LIMPIEZA DEL SITIO | 10d | 2024-10-30 | 2024-11-08 | 000261 FS-10d |  |
| 000261 | TERMINO DE LOS TRABAJOS | 0d | 2024-11-08 | 2024-11-08 | 000259, 000257, 000256, 000240, 000236, 000157, 000156, 000086, 000085, 000075, 000066, 000065, 000013, 000016, 000017, 000229, 000230, 000231, 000232, 000205, 000213, 000225, 000244, 000252, 000254, 000165, 000146, 000140, 000136, 000127, 000119, 000107, 000101, 000090, 000076, 000072, 000062, 000055, 000052, 000035 |  |
| 000263 | ENTREGA | 0d | 2024-11-08 | 2024-11-08 | 000262 |  |

Removed: A1000 KICK OFF MEETING; A1010 INICIO DEL SERVICIO; A1015 INICIO DE EXCAVACIÓN; A1016 INICIO DE RELLENO DE DIQUE; A1020 FIN DEL SERVICIO; A1030 CARTEL DE IDENTIFICACIÓN OBRA 4.80 x 3.60 m.; DESCOLMATACIÓN DE CAUCE Y OBRAS AUXILIARES; DESBROCE Y DESCOLMATACIÓN; A1230 DESCOLMATACIÓN DE CAUCE NATURAL DEL RÍO LACRAMARCA - DIQUE A3-D-01; A1880 DESCOLMATACIÓN DE CAUCE NATURAL DEL RÍO LACRAMARCA - DIQUE A3-I-01; A1870 DESCOLMATACIÓN DE CAUCE NATURAL DEL RÍO LACRAMARCA - DIQUE A3-D-02; A1890 DESCOLMATACIÓN DE CAUCE NATURAL DEL RÍO LACRAMARCA - DIQUE A3-I-02; A1900 DESCOLMATACIÓN DE CAUCE NATURAL DEL RÍO LACRAMARCA - DIQUE A3-I-03; DESVIO DEL CAUCE; A3-D-01; A1240 CONFORMACIÓN DE DESVIO EN CAUCE DE RÍO - DIQUE A3-D-01; A1250 RELLENO NO ESTRUCTURAL CON MATERIAL PROPIO - DIQUE A3-D-01; A3-D-02; A1790 CONFORMACIÓN DE DESVIO EN CAUCE DE RÍO - DIQUE A3-D-02 - TRAMO 1; A1800 RELLENO NO ESTRUCTURAL CON MATERIAL PROPIO - DIQUE A3-D-02 - TRAMO 1; A2650 CONFORMACIÓN DE DESVIO EN CAUCE DE RÍO - DIQUE A3-D-02 - TRAMO 3; A2660 RELLENO NO ESTRUCTURAL CON MATERIAL PROPIO - DIQUE A3-D-02 - TRAMO 3; A2670 CONFORMACIÓN DE DESVIO EN CAUCE DE RÍO - DIQUE A3-D-02 - TRAMO 4; A2680 RELLENO NO ESTRUCTURAL CON MATERIAL PROPIO - DIQUE A3-D-02 - TRAMO 4; A2690 CONFORMACIÓN DE DESVIO EN CAUCE DE RÍO - DIQUE A3-D-02 - TRAMO 5; A2700 RELLENO NO ESTRUCTURAL CON MATERIAL PROPIO - DIQUE A3-D-02 - TRAMO 5; A2701 CONFORMACIÓN DE DESVIO EN CAUCE DE RÍO - DIQUE A3-D-02 - TRAMO 2; A2702 RELLENO NO ESTRUCTURAL CON MATERIAL PROPIO - DIQUE A3-D-02 - TRAMO 2; A3-I-01; A1810 CONFORMACIÓN DE DESVIO EN CAUCE DE RÍO - DIQUE A3-I-01; A1820 RELLENO NO ESTRUCTURAL CON MATERIAL PROPIO - DIQUE A3-I-01; A3-I-02; A1830 CONFORMACIÓN DE DESVIO EN CAUCE DE RÍO - DIQUE A3-I-02; A1840 RELLENO NO ESTRUCTURAL CON MATERIAL PROPIO - DIQUE A3-I-02; A3-I-03; A1845 CONFORMACIÓN DE DESVIO EN CAUCE DE RÍO - DIQUE A3-I-03 - TRAMO 2; A1846 RELLENO NO ESTRUCTURAL CON MATERIAL PROPIO - DIQUE A3-I-03 -TRAMO 2; A1850 CONFORMACIÓN DE DESVIO EN CAUCE DE RÍO - DIQUE A3-I-03 - TRAMO 1; A1860 RELLENO NO ESTRUCTURAL CON MATERIAL PROPIO - DIQUE A3-I-03 -TRAMO 1; A2730 CONFORMACIÓN DE DESVIO EN CAUCE DE RÍO - DIQUE A3-I-03 - TRAMO 3; A2740 RELLENO NO ESTRUCTURAL CON MATERIAL PROPIO - DIQUE A3-I-03 -TRAMO 3; A2750 CONFORMACIÓN DE DESVIO EN CAUCE DE RÍO - DIQUE A3-I-03 - TRAMO 4; A2760 RELLENO NO ESTRUCTURAL CON MATERIAL PROPIO - DIQUE A3-I-03 -TRAMO 4; TRAMO 1; TRAMO 2 (PROG 22+500 - 22+860); TRAMO 3; TRAMO 4; TRAMO 5; A2190 EXCAVACIÓN DE UÑA CON EQUIPO; A2200 PERFILADO Y COMPACTACIÓN EN ZONA DE CORTE; A2230 GEOTEXTIL NO TEJIDO 400 G/M2, INC. COLOCACIÓN; A2240 COLOCACION Y ACOMODO DE ROCA EN UÑA DE DIQUE; A2250 COLOCACION Y ACOMODO DE ROCA EN TALUD DE DIQUE; A2260 PREPARACIÓN DE FUNDACIÓN DE CUERPO DE DIQUE; A2210 CONFORMACIÓN DE CUERPO DE DIQUE CON MATERIAL PROPIO; A2220 CONFORMACIÓN DE CORONA DE DIQUE CON MATERIAL PROPIO; Sector liberado; A1450 EXCAVACIÓN DE UÑA CON EQUIPO; A1460 PERFILADO Y COMPACTACIÓN EN ZONA DE CORTE; A1520 PREPARACIÓN DE FUNDACIÓN DE CUERPO DE DIQUE; A1470 CONFORMACIÓN DE CUERPO DE DIQUE CON MATERIAL PROPIO; A1490 GEOTEXTIL NO TEJIDO 400 G/M2, INC. COLOCACIÓN; A1500 COLOCACION Y ACOMODO DE ROCA EN UÑA DE DIQUE; A1510 COLOCACION Y ACOMODO DE ROCA EN TALUD DE DIQUE; A1480 CONFORMACIÓN DE CORONA DE DIQUE CON MATERIAL PROPIO; Sector por Liberar - Km 20+980 - km 21+300; A4040 EXCAVACIÓN DE UÑA CON EQUIPO; A4050 PERFILADO Y COMPACTACIÓN EN ZONA DE CORTE; A4110 PREPARACIÓN DE FUNDACIÓN DE CUERPO DE DIQUE; A4060 CONFORMACIÓN DE CUERPO DE DIQUE CON MATERIAL PROPIO; A4080 GEOTEXTIL NO TEJIDO 400 G/M2, INC. COLOCACIÓN; A4090 COLOCACION Y ACOMODO DE ROCA EN UÑA DE DIQUE; A4100 COLOCACION Y ACOMODO DE ROCA EN TALUD DE DIQUE; A4070 CONFORMACIÓN DE CORONA DE DIQUE CON MATERIAL PROPIO; A1530 EXCAVACIÓN EN TERRENO NATURAL CON EQUIPO; A1540 EXCAVACIÓN DE UÑA CON EQUIPO; A1550 PERFILADO Y COMPACTACIÓN EN ZONA DE CORTE; A1580 GEOTEXTIL NO TEJIDO 400 G/M2, INC. COLOCACIÓN; A1590 COLOCACION Y ACOMODO DE ROCA EN UÑA DE DIQUE; A1610 PREPARACIÓN DE FUNDACIÓN DE CUERPO DE DIQUE; A1560 CONFORMACIÓN DE CUERPO DE DIQUE CON MATERIAL PROPIO; A1600 COLOCACION Y ACOMODO DE ROCA EN TALUD DE DIQUE; A1570 CONFORMACIÓN DE CORONA DE DIQUE CON MATERIAL PROPIO; TRAMO 1; A1620 EXCAVACIÓN EN TERRENO NATURAL CON EQUIPO; A1630 EXCAVACIÓN DE UÑA CON EQUIPO; A1640 PERFILADO Y COMPACTACIÓN EN ZONA DE CORTE; A1670 GEOTEXTIL NO TEJIDO 400 G/M2, INC. COLOCACIÓN; A1680 COLOCACION Y ACOMODO DE ROCA EN UÑA DE DIQUE; A1690 COLOCACION Y ACOMODO DE ROCA EN TALUD DE DIQUE; A1700 PREPARACIÓN DE FUNDACIÓN DE CUERPO DE DIQUE; A1660 CONFORMACIÓN DE CORONA DE DIQUE CON MATERIAL PROPIO; A1650 CONFORMACIÓN DE CUERPO DE DIQUE CON MATERIAL PROPIO; TRAMO 2; Sector liberado; A2270 EXCAVACIÓN EN TERRENO NATURAL CON EQUIPO; A2280 EXCAVACIÓN DE UÑA CON EQUIPO; A2290 PERFILADO Y COMPACTACIÓN EN ZONA DE CORTE; A2320 GEOTEXTIL NO TEJIDO 400 G/M2, INC. COLOCACIÓN; A2330 COLOCACION Y ACOMODO DE ROCA EN UÑA DE DIQUE; A2350 PREPARACIÓN DE FUNDACIÓN DE CUERPO DE DIQUE; A2300 CONFORMACIÓN DE CUERPO DE DIQUE CON MATERIAL PROPIO; A2340 COLOCACION Y ACOMODO DE ROCA EN TALUD DE DIQUE; A2310 CONFORMACIÓN DE CORONA DE DIQUE CON MATERIAL PROPIO; Sector por Liberar - Km 23+760 - km 24+100; A4120 EXCAVACIÓN EN TERRENO NATURAL CON EQUIPO; A4130 EXCAVACIÓN DE UÑA CON EQUIPO; A4140 PERFILADO Y COMPACTACIÓN EN ZONA DE CORTE; A4200 PREPARACIÓN DE FUNDACIÓN DE CUERPO DE DIQUE; A4150 CONFORMACIÓN DE CUERPO DE DIQUE CON MATERIAL PROPIO; A4170 GEOTEXTIL NO TEJIDO 400 G/M2, INC. COLOCACIÓN; A4180 COLOCACION Y ACOMODO DE ROCA EN UÑA DE DIQUE; A4190 COLOCACION Y ACOMODO DE ROCA EN TALUD DE DIQUE; A4160 CONFORMACIÓN DE CORONA DE DIQUE CON MATERIAL PROPIO; TRAMO 3; A2360 EXCAVACIÓN EN TERRENO NATURAL CON EQUIPO; A2370 EXCAVACIÓN DE UÑA CON EQUIPO; A2380 PERFILADO Y COMPACTACIÓN EN ZONA DE CORTE; A2410 GEOTEXTIL NO TEJIDO 400 G/M2, INC. COLOCACIÓN; A2420 COLOCACION Y ACOMODO DE ROCA EN UÑA DE DIQUE; A2430 COLOCACION Y ACOMODO DE ROCA EN TALUD DE DIQUE; A2440 PREPARACIÓN DE FUNDACIÓN DE CUERPO DE DIQUE; A2390 CONFORMACIÓN DE CUERPO DE DIQUE CON MATERIAL PROPIO; A2400 CONFORMACIÓN DE CORONA DE DIQUE CON MATERIAL PROPIO; TRAMO 4; A2450 EXCAVACIÓN EN TERRENO NATURAL CON EQUIPO; A2460 EXCAVACIÓN DE UÑA CON EQUIPO; A2470 PERFILADO Y COMPACTACIÓN EN ZONA DE CORTE; A2500 GEOTEXTIL NO TEJIDO 400 G/M2, INC. COLOCACIÓN; A2510 COLOCACION Y ACOMODO DE ROCA EN UÑA DE DIQUE; A2520 COLOCACION Y ACOMODO DE ROCA EN TALUD DE DIQUE; A2530 PREPARACIÓN DE FUNDACIÓN DE CUERPO DE DIQUE; A2480 CONFORMACIÓN DE CUERPO DE DIQUE CON MATERIAL PROPIO; A2490 CONFORMACIÓN DE CORONA DE DIQUE CON MATERIAL PROPIO; A3-RA-D-01; A1710 EXCAVACIÓN EN TERRENO NATURAL CON EQUIPO; A3-RA-I-01; A1740 EXCAVACIÓN EN TERRENO NATURAL CON EQUIPO; A1750 CONFORMACIÓN DE CUERPO DE RAMPA CON MATERIAL PROPIO; A1760 CONFORMACIÓN DE CORONACIÓN DE RAMPA; A3570 EXCAVACIÓN EN TERRENO NATURAL CON EQUIPO; A3660 EXCAVACIÓN EN TERRENO NATURAL CON EQUIPO; A3860 MOVILIZACIÓN DE EQUIPOS Y HERRAMIENTAS (ARQUITECTURA Y PAISAJISMO); A4020 DEMOVILIZACIÓN DE EQUIPOS Y HERRAMIENTAS (ARQUITECTURA Y PAISAJISMO); INSTALACIÓN DE ALCORQUES

Changed:

| ID | Task | Start | Finish | Duration | Total float | Predecessors |
| --- | --- | --- | --- | --- | --- | --- |
| 0 | **HITOS** | 2023-10-15 → 2024-05-01 (+199d) | 2024-04-25 → 2024-11-08 (+197d) |  |  |  |
| 1 | **DEFENSAS RIBEREÑAS** | 2023-10-31 → 2024-05-04 (+186d) | 2024-04-27 → 2024-11-08 (+195d) |  |  |  |
| 1 | **OBRAS PRELIMINARES** | 2023-11-02 → 2024-05-14 (+194d) | 2024-04-23 → 2024-11-06 (+197d) |  |  |  |
| 000012 | INSTALACIONES PROVISIONALES PARA LA OBRA | 2023-11-05 → 2024-05-14 (+191d) | 2024-04-21 → 2024-05-28 (+37d) | 169d → 15d | 6d → 2d | INICIO DE EXCAVACIÓN → 000015 SS+10d |
| 000013 | MANTENIMIENTO DE TRÁNSITO Y SEGURIDAD VIAL | 2023-11-22 → 2024-05-29 (+189d) | 2024-04-23 → 2024-11-06 (+197d) | 154d → 162d |  | 000021 → 000012 |
| 2 | **TRABAJOS PRELIMINARES** | 2023-10-31 → 2024-05-04 (+186d) | 2024-04-27 → 2024-11-08 (+195d) |  |  |  |
| 000015 | MOVILIZACION DE EQUIPOS | 2023-10-31 → 2024-05-04 (+186d) | 2023-11-30 → 2024-05-23 (+175d) | 31d → 20d |  | INICIO DEL SERVICIO → 000007 |
| 000017 | TOPOGRAFÍA Y GEOREFERENCIACIÓN | 2023-11-02 → 2024-05-14 (+194d) | 2024-04-23 → 2024-11-06 (+197d) | 174d → 177d |  | 000015 SS+2d → 000015 FS-10d |
| 000016 | DESMOVILIZACION DE EQUIPOS | 2024-04-05 → 2024-10-30 (+208d) | 2024-04-27 → 2024-11-08 (+195d) | 23d → 10d |  | FIN DEL SERVICIO FF+2d → 000085 FS-10d |
| 3 | **MEJORAMIENTO DE VÍAS EXISTENTES** | 2023-11-05 → 2024-05-19 (+196d) | 2024-01-04 → 2024-06-02 (+150d) |  |  |  |
| 1 | **MOVIMIENTO DE TIERRAS** | 2023-11-05 → 2024-05-19 (+196d) | 2023-11-21 → 2024-06-02 (+194d) |  |  |  |
| 000020 | ROCE Y LIMPIEZA DE MALEZA | 2023-11-05 → 2024-05-19 (+196d) | 2023-11-21 → 2024-06-02 (+194d) | 17d → 15d | 2d → 0d | INICIO DE EXCAVACIÓN → 000015 FS-5d |
| 000021 | MEJORAMIENTO DE VIAS EXISTENTES | 2023-11-05 → 2024-05-19 (+196d) | 2023-11-21 → 2024-06-02 (+194d) | 17d → 15d | 2d → 0d | 000020 SS → 000020 FS-15d |
| 2 | **REPOSICIÓN DE ESTRUCTURAS** | 2023-11-25 → 2024-05-19 (+176d) | 2023-12-29 → 2024-06-02 (+156d) |  |  |  |
| 000023 | DEMOLICIÓN DE ESTRUCTURAS EXISTENTES | 2023-11-25 → 2024-05-19 (+176d) | 2023-11-26 → 2024-06-02 (+189d) | 2d → 15d | 112d → 2d | 000017 SS+23d → 000020 FS-15d |
| 000024 | REPOSICIÓN DE PASE DE AGUA TUBO HDPE Ø=18" | 2023-11-28 → 2024-05-19 (+173d) | 2023-11-29 → 2024-06-02 (+186d) | 2d → 15d | 112d → 40d | 000023 SS+3d → 000023 FS-15d |
| 000025 | REPOSICIÓN DE PASE DE AGUA TUBO HDPE Ø=36" | 2023-11-28 → 2024-05-19 (+173d) | 2023-11-29 → 2024-06-02 (+186d) | 2d → 15d | 112d → 40d | 000024 SS → 000024 FS-15d |
| 000026 | SUMINISTRO Y MONTAJE DE PANELES DE C°A° 1.6mx1.0mx0.20m EN PASE DE AGUA | 2023-11-30 → 2024-05-19 (+171d) | 2023-12-29 → 2024-06-02 (+156d) | 30d → 15d | 112d → 40d | 000025 SS+2d → 000025 FS-15d |
| 000027 | SUMINISTRO Y MONTAJE DE PANELES DE C°A° 2.20mx1.0mx0.20m EN PASE DE AGUA | 2023-11-30 → 2024-05-19 (+171d) | 2023-12-29 → 2024-06-02 (+156d) | 30d → 15d | 112d → 40d | 000026 SS → 000026 FS-15d |
| 3 | **CABEZAL DE ENTRADA Y SALIDA** | 2023-12-30 → 2024-05-19 (+141d) | 2024-01-04 → 2024-06-02 (+150d) |  |  |  |
| 000029 | CONCRETOS | 2024-01-02 → 2024-05-19 (+138d) | 2024-01-04 → 2024-06-02 (+150d) | 3d → 15d | 112d → 40d | 000030 → 000027 FS-15d |
| 000030 | ENCOFRADO Y DESENCOFRADO RECTO | 2023-12-30 → 2024-05-19 (+141d) | 2024-01-01 → 2024-06-02 (+153d) | 3d → 15d | 112d → 122d | 000027 → 000029 FS-15d |
| 000032 | DESBROCE Y LIMPIEZA EN ZONA NO BOSCOSA | 2023-11-06 → 2024-05-22 (+198d) | 2024-01-20 → 2024-09-11 (+235d) | 76d → 113d |  | INICIO DE EXCAVACIÓN FS+1d → 000021 FS-12d |
| 5 | **DIQUES DE TIERRA COMPACTADA CON ENROCADO** | 2023-11-12 → 2024-05-27 (+197d) | 2024-04-25 → 2024-11-08 (+197d) |  |  |  |
| 1 | **DIQUE DE TIERRA COMPACTADA A3-D-01** | 2023-11-12 → 2024-05-27 (+197d) | 2023-12-16 → 2024-07-02 (+199d) |  |  |  |
| 000038 | EXCAVACIÓN EN TERRENO NATURAL CON EQUIPO | 2023-11-12 → 2024-05-27 (+197d) | 2023-11-21 → 2024-06-05 (+197d) |  | 0d → 36d | CONFORMACIÓN DE DESVIO EN CAUCE DE RÍO - DIQUE A3-I-01 → 000032 SS+5d |
| 000039 | EXCAVACIÓN DE UÑA CON EQUIPO | 2023-11-13 → 2024-05-30 (+199d) | 2023-11-21 → 2024-06-08 (+200d) | 9d → 10d | 136d → 36d | 000038 SS+1d → 000038 FS-7d |
| 000040 | PERFILADO Y COMPACTACIÓN EN ZONA DE CORTE | 2023-11-13 → 2024-06-02 (+202d) | 2023-12-02 → 2024-06-11 (+192d) | 20d → 10d | 0d → 59d | 000038 SS+1d → 000039 FS-7d |
| 000046 | PREPARACIÓN DE FUNDACIÓN DE CUERPO DE DIQUE | 2023-11-13 → 2024-06-03 (+203d) | 2023-11-25 → 2024-06-12 (+200d) | 13d → 10d | 0d → 59d | 000040 SS → 000040 FS-9d |
| 000041 | CONFORMACIÓN DE CUERPO DE DIQUE CON MATERIAL PROPIO | 2023-11-27 → 2024-06-05 (+191d) | 2023-12-01 → 2024-06-14 (+196d) | 5d → 10d | 0d → 64d | INICIO DE RELLENO DE DIQUE → 000040 FS-7d |
| 000042 | CONFORMACIÓN DE CORONA DE DIQUE CON MATERIAL PROPIO | 2023-12-11 → 2024-06-07 (+179d) | 2023-12-16 → 2024-06-16 (+183d) | 6d → 10d | 133d → 66d | 000045 FF+3d → 000041 FS-8d |
| 000043 | GEOTEXTIL NO TEJIDO 400 G/M2, INC. COLOCACIÓN | 2023-11-29 → 2024-06-13 (+197d) | 2023-12-04 → 2024-06-25 (+204d) | 6d → 13d | 0d → 59d | 000041 SS+2d → 000041 FS-7d, 000046 |
| 000044 | COLOCACION Y ACOMODO DE ROCA EN UÑA DE DIQUE | 2023-11-30 → 2024-06-18 (+201d) | 2023-12-05 → 2024-06-30 (+208d) | 6d → 13d | 0d → 59d | 000043 SS+1d → 000043 FS-8d |
| 000045 | COLOCACION Y ACOMODO DE ROCA EN TALUD DE DIQUE | 2023-12-02 → 2024-06-20 (+201d) | 2023-12-13 → 2024-07-02 (+202d) | 12d → 13d | 0d → 59d | 000044 SS+2d → 000044 FS-11d |
| 2 | **DIQUE DE TIERRA COMPACTADA A3-D-02** | 2023-12-16 → 2024-06-09 (+176d) | 2024-04-13 → 2024-10-03 (+173d) |  |  |  |
| 000048 | EXCAVACIÓN EN TERRENO NATURAL CON EQUIPO | 2023-12-16 → 2024-06-09 (+176d) | 2023-12-24 → 2024-08-16 (+236d) | 9d → 69d | 12d → 36d | CONFORMACIÓN DE DESVIO EN CAUCE DE RÍO - DIQUE A3-I-02 → 000059, 000039 |
| 000056 | PREPARACIÓN DE FUNDACIÓN DE CUERPO DE DIQUE | 2023-12-25 → 2024-06-09 (+167d) | 2023-12-29 → 2024-06-18 (+172d) | 5d → 10d | 114d → 51d | 000048 → 000048 SS |
| 000049 | EXCAVACIÓN DE UÑA CON EQUIPO | 2023-12-17 → 2024-06-18 (+184d) | 2023-12-27 → 2024-08-25 (+242d) | 11d → 69d | 111d → 36d | 000048 SS+1d, 000039 → 000048 FS-60d |
| 000050 | PERFILADO Y COMPACTACIÓN EN ZONA DE CORTE | 2023-12-17 → 2024-07-04 (+200d) | 2023-12-28 → 2024-08-27 (+243d) | 12d → 55d | 12d → 36d | 000048 SS+1d → 000049 FS-53d, 000056 |
| 000051 | CONFORMACIÓN DE CUERPO DE DIQUE CON MATERIAL PROPIO | 2023-12-26 → 2024-07-17 (+204d) | 2023-12-30 → 2024-08-30 (+244d) | 5d → 45d | 114d → 36d | 000056 SS+1d → 000050 FS-42d, 000042 |
| 000053 | GEOTEXTIL NO TEJIDO 400 G/M2, INC. COLOCACIÓN | 2023-12-19 → 2024-07-19 (+213d) | 2023-12-31 → 2024-09-13 (+257d) | 13d → 57d | 12d → 36d | 000050 SS+2d → 000051 FS-43d |
| 000052 | CONFORMACIÓN DE CORONA DE DIQUE CON MATERIAL PROPIO | 2024-01-03 → 2024-07-20 (+199d) | 2024-01-08 → 2024-09-02 (+238d) | 6d → 45d | 12d → 67d | 000055 SS+11d → 000051 FS-42d |
| 000054 | COLOCACION Y ACOMODO DE ROCA EN UÑA DE DIQUE | 2023-12-21 → 2024-07-26 (+218d) | 2024-01-05 → 2024-09-23 (+262d) | 16d → 60d | 12d → 36d | 000053 SS+2d → 000053 FS-50d, 000045 |
| 000055 | COLOCACION Y ACOMODO DE ROCA EN TALUD DE DIQUE | 2023-12-23 → 2024-08-05 (+226d) | 2024-01-06 → 2024-10-03 (+271d) | 15d → 60d | 12d → 36d | 000054 SS+2d → 000054 FS-50d |
| 3 | **DIQUE DE TIERRA COMPACTADA A3-I-01** | 2023-12-16 → 2024-05-27 (+163d) | 2024-01-22 → 2024-06-27 (+157d) |  |  |  |
| 000058 | EXCAVACIÓN EN TERRENO NATURAL CON EQUIPO | 2024-03-21 → 2024-05-27 (+67d) | 2024-03-29 → 2024-06-05 (+68d) | 9d → 10d | 12d → 36d | CONFORMACIÓN DE CORONA DE DIQUE CON MATERIAL PROPIO → 000032 SS+5d |
| 000059 | EXCAVACIÓN DE UÑA CON EQUIPO | 2024-03-22 → 2024-05-30 (+69d) | 2024-04-01 → 2024-06-08 (+68d) | 11d → 10d | 26d → 36d | 000058 SS+1d, 000049 → 000058 FS-7d |
| 000060 | PERFILADO Y COMPACTACIÓN EN ZONA DE CORTE | 2024-03-22 → 2024-06-02 (+72d) | 2024-04-02 → 2024-06-11 (+70d) | 12d → 10d | 12d → 134d | 000058 SS+1d → 000059 FS-7d |
| 000066 | PREPARACIÓN DE FUNDACIÓN DE CUERPO DE DIQUE | 2024-03-30 → 2024-06-03 (+65d) | 2024-04-03 → 2024-06-12 (+70d) | 5d → 10d | 23d → 149d | 000058 → 000060 FS-9d |
| 000061 | CONFORMACIÓN DE CUERPO DE DIQUE CON MATERIAL PROPIO | 2024-03-31 → 2024-06-05 (+66d) | 2024-04-04 → 2024-06-14 (+71d) | 5d → 10d | 23d → 134d | 000066 SS+1d, 000051 → 000060 FS-7d |
| 000062 | CONFORMACIÓN DE CORONA DE DIQUE CON MATERIAL PROPIO | 2024-04-08 → 2024-06-07 (+60d) | 2024-04-13 → 2024-06-16 (+64d) | 6d → 10d | 12d → 145d | 000065 SS+11d → 000061 FS-8d |
| 000063 | GEOTEXTIL NO TEJIDO 400 G/M2, INC. COLOCACIÓN | 2024-03-24 → 2024-06-08 (+76d) | 2024-04-04 → 2024-06-20 (+77d) | 12d → 13d | 12d → 134d | 000060 SS+2d → 000061 FS-7d |
| 000064 | COLOCACION Y ACOMODO DE ROCA EN UÑA DE DIQUE | 2024-03-26 → 2024-06-13 (+79d) | 2024-04-10 → 2024-06-25 (+76d) | 16d → 13d | 12d → 134d | 000063 SS+2d → 000063 FS-8d |
| 000065 | COLOCACION Y ACOMODO DE ROCA EN TALUD DE DIQUE | 2024-03-28 → 2024-06-15 (+79d) | 2024-04-11 → 2024-06-27 (+77d) | 15d → 13d | 12d → 134d | 000064 SS+2d → 000064 FS-11d |
| 4 | **DIQUE DE TIERRA COMPACTADA A3-I-02** | 2024-01-02 → 2024-05-27 (+146d) | 2024-01-25 → 2024-07-04 (+161d) |  |  |  |
| 000068 | EXCAVACIÓN EN TERRENO NATURAL CON EQUIPO | 2024-01-09 → 2024-05-27 (+139d) | 2024-01-17 → 2024-06-18 (+153d) | 9d → 23d | 12d → 0d | 000052 → 000032 SS+5d |
| 000069 | EXCAVACIÓN DE UÑA CON EQUIPO | 2024-01-10 → 2024-05-30 (+141d) | 2024-01-20 → 2024-06-21 (+153d) | 11d → 23d | 65d → 0d | 000068 SS+1d → 000068 FS-20d |
| 000074 | COLOCACION Y ACOMODO DE ROCA EN UÑA DE DIQUE | 2024-01-14 → 2024-06-08 (+146d) | 2024-01-29 → 2024-06-30 (+153d) | 16d → 23d | 12d → 128d | 000073 SS+2d → 000071 FS-19d |
| 000075 | COLOCACION Y ACOMODO DE ROCA EN TALUD DE DIQUE | 2024-01-16 → 2024-06-11 (+147d) | 2024-01-30 → 2024-07-03 (+155d) | 15d → 23d | 12d → 128d | 000074 SS+2d → 000074 FS-20d |
| 000070 | PERFILADO Y COMPACTACIÓN EN ZONA DE CORTE | 2024-01-10 → 2024-06-12 (+154d) | 2024-01-21 → 2024-06-24 (+155d) | 12d → 13d | 12d → 127d | 000068 SS+1d → 000069 FS-10d |
| 000071 | CONFORMACIÓN DE CUERPO DE DIQUE CON MATERIAL PROPIO | 2024-01-19 → 2024-06-17 (+150d) | 2024-01-23 → 2024-06-26 (+155d) | 5d → 10d | 83d → 127d | 000076 SS+1d → 000070 FS-8d |
| 000073 | GEOTEXTIL NO TEJIDO 400 G/M2, INC. COLOCACIÓN | 2024-01-12 → 2024-06-18 (+158d) | 2024-01-23 → 2024-06-29 (+158d) |  | 12d → 127d | 000070 SS+2d → 000071 FS-9d |
| 000072 | CONFORMACIÓN DE CORONA DE DIQUE CON MATERIAL PROPIO | 2024-01-27 → 2024-06-19 (+144d) | 2024-02-01 → 2024-06-28 (+148d) | 6d → 10d | 12d → 133d | 000075 SS+11d → 000071 FS-8d |
| 000076 | PREPARACIÓN DE FUNDACIÓN DE CUERPO DE DIQUE | 2024-01-18 → 2024-06-20 (+154d) | 2024-01-22 → 2024-07-04 (+164d) | 5d → 15d | 83d → 127d | 000068 → 000073 FS-10d |
| 5 | **DIQUE DE TIERRA COMPACTADA A3-I-03** | 2024-01-26 → 2024-06-22 (+148d) | 2024-04-25 → 2024-11-08 (+197d) |  |  |  |
| 000078 | EXCAVACIÓN EN TERRENO NATURAL CON EQUIPO | 2024-02-02 → 2024-06-22 (+141d) | 2024-02-10 → 2024-08-08 (+180d) | 9d → 48d | 12d → 0d | 000072 → 000069 |
| 000079 | EXCAVACIÓN DE UÑA CON EQUIPO | 2024-02-03 → 2024-06-26 (+144d) | 2024-02-13 → 2024-08-12 (+181d) | 11d → 48d | 52d → 0d | 000078 SS+1d, 000069 → 000078 FS-44d |
| 000080 | PERFILADO Y COMPACTACIÓN EN ZONA DE CORTE | 2024-02-03 → 2024-07-04 (+152d) | 2024-02-14 → 2024-08-16 (+184d) | 12d → 44d | 12d → 0d | 000078 SS+1d → 000079 FS-40d |
| 000081 | CONFORMACIÓN DE CUERPO DE DIQUE CON MATERIAL PROPIO | 2024-02-12 → 2024-07-10 (+149d) | 2024-02-16 → 2024-08-18 (+184d) | 5d → 40d | 64d → 0d | 000086 SS+1d, 000071 → 000080 FS-38d |
| 000082 | CONFORMACIÓN DE CORONA DE DIQUE CON MATERIAL PROPIO | 2024-02-20 → 2024-07-12 (+143d) | 2024-02-25 → 2024-08-20 (+177d) | 6d → 40d | 12d → 0d | 000085 SS+11d → 000081 FS-38d |

| ID | Task | Start | Finish | Duration | Total float | Predecessors |
| --- | --- | --- | --- | --- | --- | --- |
| 000083 | GEOTEXTIL NO TEJIDO 400 G/M2, INC. COLOCACIÓN | 2024-02-05 → 2024-07-26 (+172d) | 2024-02-16 → 2024-09-10 (+207d) | 12d → 47d | 12d → 0d | 000080 SS+2d → 000082 FS-26d |
| 000086 | PREPARACIÓN DE FUNDACIÓN DE CUERPO DE DIQUE | 2024-02-11 → 2024-07-28 (+168d) | 2024-02-15 → 2024-08-21 (+188d) | 5d → 25d | 64d → 79d | 000078 → 000080 FS-20d |
| 000084 | COLOCACION Y ACOMODO DE ROCA EN UÑA DE DIQUE | 2024-02-07 → 2024-07-31 (+175d) | 2024-02-22 → 2024-11-05 (+257d) | 16d → 98d | 12d → 0d | 000083 SS+2d → 000083 FS-42d |
| 000085 | COLOCACION Y ACOMODO DE ROCA EN TALUD DE DIQUE | 2024-02-09 → 2024-08-03 (+176d) | 2024-02-23 → 2024-11-08 (+259d) | 15d → 98d | 12d → 0d | 000084 SS+2d → 000084 FS-95d |
| 6 | **RAMPAS** | 2024-03-09 → 2024-06-22 (+105d) | 2024-04-16 → 2024-06-24 (+69d) |  |  |  |
| 000088 | EXCAVACIÓN EN TERRENO NATURAL CON EQUIPO | 2024-02-26 → 2024-06-22 (+117d) | 2024-03-05 → 2024-06-24 (+111d) | 9d → 3d | 12d → 137d | 000082 → 000078 SS |
| 000089 | CONFORMACIÓN DE CUERPO DE RAMPA CON MATERIAL PROPIO | 2024-03-12 → 2024-06-22 (+102d) | 2024-03-14 → 2024-06-24 (+102d) |  | 39d → 137d | EXCAVACIÓN EN TERRENO NATURAL CON EQUIPO → 000088 FS-3d |
| 000090 | CONFORMACIÓN DE CORONACIÓN DE RAMPA | 2024-03-12 → 2024-06-22 (+102d) | 2024-03-14 → 2024-06-24 (+102d) |  | 39d → 137d | 000089 SS → 000089 FS-3d |
| 2 | **OBRAS DE ARTE** | 2023-11-06 → 2024-06-03 (+210d) | 2024-04-22 → 2024-09-29 (+160d) |  |  |  |
| 1 | **CAPTACIÓN A3-CP-23-95** | 2023-11-21 → 2024-06-03 (+195d) | 2024-03-18 → 2024-07-15 (+119d) |  |  |  |
| 1 | **MOVIMIENTO DE TIERRAS** | 2023-11-21 → 2024-06-03 (+195d) | 2024-01-07 → 2024-07-09 (+184d) |  |  |  |
| 000094 | EXCAVACIÓN ESTRUCTURAL PARA OBRAS DE ARTE | 2023-11-21 → 2024-06-03 (+195d) | 2023-11-26 → 2024-07-09 (+226d) | 6d → 37d | 38d → 116d | 000167 → 000029 |
| 000095 | RELLENO ESTRUCTURAL PARA OBRAS DE ARTE, CON MATERIAL PROPIO | 2024-01-03 → 2024-06-03 (+152d) | 2024-01-07 → 2024-07-09 (+184d) | 5d → 37d | 90d → 116d | 000098 FS+12d → 000094 FS-37d |
| 2 | **OBRAS DE CONCRETO** | 2023-11-27 → 2024-06-05 (+191d) | 2023-12-21 → 2024-07-15 (+207d) |  |  |  |
| 000097 | CONCRETO f'c=100 kg/cm2 | 2023-11-27 → 2024-06-05 (+191d) | 2023-11-29 → 2024-07-11 (+225d) | 3d → 37d | 50d → 116d | 000094 → 000095 FS-35d |
| 000098 | CONCRETO f'c=280 kg/cm2 | 2023-12-10 → 2024-06-07 (+180d) | 2023-12-21 → 2024-07-13 (+205d) | 12d → 37d | 55d → 116d | 000100 SS+3d → 000097 FS-35d |
| 000099 | CONCRETO CICLÓPEO f'c=280 kg/cm2 + 30% P.G. | 2023-11-30 → 2024-06-09 (+192d) | 2023-12-02 → 2024-07-15 (+226d) | 3d → 37d | 50d → 116d | 000097 → 000098 FS-35d |
| 000100 | ENCOFRADO Y DESENCOFRADO RECTO | 2023-12-07 → 2024-06-09 (+185d) | 2023-12-16 → 2024-07-15 (+212d) | 10d → 37d | 53d → 116d | 000101 FF+1d → 000099 FS-37d, 000030 |
| 000101 | ACERO DE REFUERZO fy=4200 kg/cm2 | 2023-12-03 → 2024-06-09 (+189d) | 2023-12-15 → 2024-07-15 (+213d) | 13d → 37d | 50d → 116d | 000099 → 000100 FS-37d |
| 3 | **ESTRUCTURAS METALICAS** | 2024-01-03 → 2024-06-03 (+152d) | 2024-01-17 → 2024-07-09 (+174d) |  |  |  |
| 000103 | COMPUERTA METALICA PLANA DESLIZANTE DE 1.0x1.0m | 2024-01-03 → 2024-06-03 (+152d) | 2024-01-05 → 2024-07-09 (+186d) | 3d → 37d | 99d → 122d | 000098 FS+12d → 000029 |
| 000104 | REJILLA DE 1.00x1.00m CON VARILLA DE 1/2" CADA 6,25cm | 2024-01-06 → 2024-06-03 (+149d) | 2024-01-08 → 2024-07-09 (+183d) | 3d → 37d | 99d → 122d | 000103 → 000103 FS-37d |
| 000105 | BARANDA DE FIERRO GALVANIZADO 1 1/2" | 2024-01-09 → 2024-06-03 (+146d) | 2024-01-11 → 2024-07-09 (+180d) | 3d → 37d | 99d → 122d | 000104 → 000104 FS-37d |
| 000106 | ESCALERA TIPO GATO | 2024-01-12 → 2024-06-03 (+143d) | 2024-01-14 → 2024-07-09 (+177d) | 3d → 37d | 99d → 122d | 000105 → 000105 FS-37d |
| 000107 | TAPA METALICA CIRCULAR DN600 MM | 2024-01-15 → 2024-06-03 (+140d) | 2024-01-17 → 2024-07-09 (+174d) | 3d → 37d | 99d → 122d | 000106 → 000106 FS-37d |
| 4 | **TUBERIAS** | 2023-11-27 → 2024-06-03 (+189d) | 2024-01-23 → 2024-07-09 (+168d) |  |  |  |
| 000109 | EXCAVACIÓN ESTRUCTURAL PARA OBRAS DE ARTE (Buzones) | 2023-11-27 → 2024-06-03 (+189d) | 2023-11-29 → 2024-07-09 (+223d) | 3d → 37d | 38d → 122d | 000094 → 000029 |
| 000110 | EXCAVACIÓN DE ZANJA | 2023-11-30 → 2024-06-03 (+186d) | 2023-12-24 → 2024-07-09 (+198d) | 25d → 37d | 38d → 122d | 000109 → 000109 FS-37d |
| 000111 | RELLENO ESTRUCTURAL PARA OBRAS DE ARTE CON MATERIAL PROPIO (Buzones) | 2024-01-09 → 2024-06-03 (+146d) | 2024-01-11 → 2024-07-09 (+180d) | 3d → 37d | 89d → 122d | 000115 FS+12d, 000095 → 000110 FS-37d |
| 000112 | CAMA DE ARENA | 2023-12-03 → 2024-06-03 (+183d) | 2023-12-27 → 2024-07-09 (+195d) | 25d → 37d | 93d → 122d | 000110 SS+3d → 000111 FS-37d |
| 000113 | RELLENO COMÚN PARA ZANJAS | 2023-12-29 → 2024-06-03 (+157d) | 2024-01-23 → 2024-07-09 (+168d) | 26d → 37d | 93d → 122d | 000119 → 000112 FS-37d |
| 000114 | CONCRETO f'c=100 kg/cm2 (Buzones) | 2023-12-03 → 2024-06-03 (+183d) | 2023-12-05 → 2024-07-09 (+217d) | 3d → 37d | 60d → 122d | 000110 SS+3d, 000097 → 000113 FS-37d |
| 000115 | CONCRETO f'c=280 kg/cm2 (Buzones) | 2023-12-25 → 2024-06-03 (+161d) | 2023-12-27 → 2024-07-09 (+195d) | 3d → 37d | 52d → 122d | 000117, 000098 → 000114 FS-37d |
| 000116 | ENCOFRADO Y DESENCOFRADO RECTO | 2023-12-20 → 2024-06-03 (+166d) | 2023-12-24 → 2024-07-09 (+198d) | 5d → 37d | 50d → 122d | 000100, 000118 → 000115 FS-37d |
| 000117 | ENCOFRADO Y DESENCOFRADO CURVO | 2023-12-20 → 2024-06-03 (+166d) | 2023-12-24 → 2024-07-09 (+198d) | 5d → 37d | 50d → 122d | 000116 SS → 000116 FS-37d |
| 000118 | ACERO DE REFUERZO fy=4200 kg/cm2 (Buzones) | 2023-12-16 → 2024-06-03 (+170d) | 2023-12-19 → 2024-07-09 (+203d) | 4d → 37d | 50d → 122d | 000114, 000101 → 000117 FS-37d |
| 000119 | SUMINISTRO E INSTALACIÓN DE TUBERÍA GRP DN600 mm SN2500 | 2023-12-04 → 2024-06-03 (+182d) | 2023-12-28 → 2024-07-09 (+194d) | 25d → 37d | 93d → 122d | 000112 SS+1d → 000118 FS-37d |
| 5 | **CANAL** | 2023-12-25 → 2024-06-03 (+161d) | 2024-02-29 → 2024-07-09 (+131d) |  |  |  |
| 000121 | EXCAVACIÓN ESTRUCTURAL PARA OBRAS DE ARTE | 2023-12-25 → 2024-06-03 (+161d) | 2023-12-30 → 2024-07-09 (+192d) | 6d → 37d | 38d → 122d | 000110 → 000109 FS-37d |
| 000122 | RELLENO ESTRUCTURAL PARA CANALES, CON MATERIAL PROPIO | 2024-01-12 → 2024-06-03 (+143d) | 2024-01-24 → 2024-07-09 (+167d) | 13d → 37d | 89d → 122d | 000111 → 000121 FS-37d |
| 000123 | COLOCACIÓN DE CONCRETO f'c=100 kg/cm2 | 2023-12-31 → 2024-06-03 (+155d) | 2024-01-03 → 2024-07-09 (+188d) | 4d → 37d | 38d → 122d | 000114, 000121 → 000122 FS-37d |
| 000124 | COLOCACIÓN DE CONCRETO f'c=280 kg/cm2 | 2024-01-08 → 2024-06-03 (+147d) | 2024-02-29 → 2024-07-09 (+131d) | 53d → 37d | 38d → 122d | 000115 SS, 000125 SS+2d → 000123 FS-37d |
| 000125 | ENCOFRADO Y DESENCOFRADO RECTO | 2024-01-06 → 2024-06-03 (+149d) | 2024-02-26 → 2024-07-09 (+134d) | 52d → 37d | 38d → 122d | 000117, 000126 SS+2d → 000124 FS-37d |
| 000126 | ACERO DE REFUERZO fy=4200 kg/cm2 | 2024-01-04 → 2024-06-03 (+151d) | 2024-01-31 → 2024-07-09 (+160d) | 28d → 37d | 38d → 122d | 000118, 000123 → 000125 FS-37d |
| 000127 | JUNTA WATER STOP SIN BULBO 150 mm | 2024-01-08 → 2024-06-03 (+147d) | 2024-02-29 → 2024-07-09 (+131d) | 53d → 37d | 53d → 122d | 000124 SS → 000126 FS-37d |
| 6 | **OBRAS DE DESCARGA** | 2023-12-31 → 2024-06-03 (+155d) | 2024-03-18 → 2024-07-09 (+113d) |  |  |  |
| 000129 | EXCAVACIÓN ESTRUCTURAL PARA OBRAS DE ARTE | 2023-12-31 → 2024-06-03 (+155d) | 2024-01-02 → 2024-07-09 (+189d) | 3d → 37d | 87d → 40d | 000121 → 000029 |
| 000130 | RELLENO ESTRUCTURAL PARA OBRAS DE ARTE CON MATERIAL PROPIO | 2024-03-16 → 2024-06-03 (+79d) | 2024-03-18 → 2024-07-09 (+113d) | 3d → 37d | 38d → 40d | 000132 FS+12d, 000122 → 000129 FS-37d |
| 000131 | CONCRETO f'c=100 kg/cm2 | 2024-01-04 → 2024-06-03 (+151d) | 2024-01-06 → 2024-07-09 (+185d) | 3d → 37d | 86d → 122d | 000129, 000123 → 000130 FS-37d |
| 000132 | CONCRETO f'c=280 kg/cm2 | 2024-03-01 → 2024-06-03 (+94d) | 2024-03-03 → 2024-07-09 (+128d) | 3d → 37d | 38d → 122d | 000133, 000124 → 000131 FS-37d |
| 000133 | ENCOFRADO Y DESENCOFRADO RECTO | 2024-02-27 → 2024-06-03 (+97d) | 2024-02-29 → 2024-07-09 (+131d) | 3d → 37d | 38d → 122d | 000134, 000125 → 000132 FS-37d |
| 000134 | ACERO DE REFUERZO fy=4200 kg/cm2 | 2024-02-01 → 2024-06-03 (+123d) | 2024-02-03 → 2024-07-09 (+157d) | 3d → 37d | 61d → 122d | 000131, 000126 → 000133 FS-37d |
| 000135 | JUNTA WATER STOP SIN BULBO 150 mm | 2024-03-04 → 2024-06-03 (+91d) | 2024-03-06 → 2024-07-09 (+125d) | 3d → 37d | 50d → 122d | 000132, 000127 → 000134 FS-37d |
| 000136 | COMPUERTA METALICA PLANA DESLIZANTE | 2024-03-16 → 2024-06-03 (+79d) | 2024-03-18 → 2024-07-09 (+113d) | 3d → 37d | 38d → 122d | 000132 FS+12d → 000135 FS-37d |
| 2 | **CAPTACIÓN A3-CP-21-05** | 2023-11-09 → 2024-07-10 (+244d) | 2024-02-06 → 2024-08-01 (+177d) |  |  |  |
| 1 | **MOVIMIENTO DE TIERRAS** | 2023-11-09 → 2024-07-10 (+244d) | 2023-12-28 → 2024-08-01 (+217d) |  |  |  |
| 000139 | EXCAVACIÓN ESTRUCTURAL PARA OBRAS DE ARTE | 2023-11-09 → 2024-07-10 (+244d) | 2023-11-12 → 2024-08-01 (+263d) | 4d → 23d | 38d → 40d | 000017 SS+7d → 000130 |
| 000140 | RELLENO ESTRUCTURAL PARA OBRAS DE ARTE, CON MATERIAL PROPIO | 2023-12-24 → 2024-07-10 (+199d) | 2023-12-28 → 2024-08-01 (+217d) | 5d → 23d | 119d → 99d | 000143 FS+12d → 000139 FS-23d |
| 2 | **OBRAS DE CONCRETO** | 2023-11-13 → 2024-07-10 (+240d) | 2023-12-11 → 2024-08-01 (+234d) |  |  |  |
| 000142 | CONCRETO f'c=100 kg/cm2 | 2023-11-13 → 2024-07-10 (+240d) | 2023-11-15 → 2024-08-01 (+260d) | 3d → 23d | 79d → 40d | 000139 → 000139 FS-23d |
| 000143 | CONCRETO f'c=280 kg/cm2 | 2023-12-01 → 2024-07-10 (+222d) | 2023-12-11 → 2024-08-01 (+234d) | 11d → 23d | 109d → 40d | 000145 SS+6d → 000142 FS-23d |
| 000144 | CONCRETO CICLÓPEO f'c=280 kg/cm2 + 30% P.G. | 2023-11-16 → 2024-07-10 (+237d) | 2023-11-18 → 2024-08-01 (+257d) | 3d → 23d | 79d → 40d | 000142 → 000143 FS-23d |
| 000145 | ENCOFRADO Y DESENCOFRADO RECTO | 2023-11-25 → 2024-07-10 (+228d) | 2023-12-09 → 2024-08-01 (+236d) | 15d → 23d | 82d → 99d | 000146 SS+6d → 000144 FS-23d |
| 000146 | ACERO DE REFUERZO fy=4200 kg/cm2 | 2023-11-19 → 2024-07-10 (+234d) | 2023-12-09 → 2024-08-01 (+236d) | 21d → 23d | 79d → 99d | 000144 → 000145 FS-23d |
| 3 | **ESTRUCTURAS METALICAS** | 2023-12-24 → 2024-07-10 (+199d) | 2024-01-07 → 2024-08-01 (+207d) |  |  |  |
| 000148 | COMPUERTA METALICA PLANA DESLIZANTE DE 1.0x1.0m | 2023-12-24 → 2024-07-10 (+199d) | 2023-12-26 → 2024-08-01 (+219d) | 3d → 23d | 109d → 40d | 000143 FS+12d → 000144 FS-23d |
| 000149 | REJILLA DE 1.00x1.00m CON VARILLA DE 1/2 CADA 6,25cm | 2023-12-27 → 2024-07-10 (+196d) | 2023-12-29 → 2024-08-01 (+216d) | 3d → 23d | 109d → 40d | 000148 → 000148 FS-23d |
| 000150 | BARANDA DE FIERRO GALVANIZADO 1 1/2" | 2023-12-30 → 2024-07-10 (+193d) | 2024-01-01 → 2024-08-01 (+213d) | 3d → 23d | 109d → 40d | 000149 → 000149 FS-23d |
| 000151 | ESCALERA TIPO GATO | 2024-01-02 → 2024-07-10 (+190d) | 2024-01-04 → 2024-08-01 (+210d) | 3d → 23d | 109d → 40d | 000150 → 000150 FS-23d |
| 000152 | TAPA METALICA CIRCULAR DN600 MM | 2024-01-05 → 2024-07-10 (+187d) | 2024-01-07 → 2024-08-01 (+207d) | 3d → 23d | 109d → 40d | 000151 → 000151 FS-23d |

| ID | Task | Start | Finish | Duration | Total float | Predecessors |
| --- | --- | --- | --- | --- | --- | --- |
| 4 | **TUBERIA** | 2023-11-13 → 2024-07-10 (+240d) | 2024-01-02 → 2024-08-01 (+212d) |  |  |  |
| 000154 | EXCAVACIÓN ESTRUCTURAL PARA OBRAS DE ARTE (Buzones) | 2023-11-13 → 2024-07-10 (+240d) | 2023-11-15 → 2024-08-01 (+260d) | 3d → 23d | 38d → 40d | 000139 → 000152 FS-23d |
| 000155 | EXCAVACIÓN DE ZANJA | 2023-11-16 → 2024-07-10 (+237d) | 2023-11-18 → 2024-08-01 (+257d) | 3d → 23d | 143d → 99d | 000154 → 000154 FS-23d |
| 000156 | RELLENO ESTRUCTURAL PARA OBRAS DE ARTE CON MATERIAL PROPIO | 2023-12-31 → 2024-07-10 (+192d) | 2024-01-02 → 2024-08-01 (+212d) | 3d → 23d | 107d → 99d | 000161 FS+12d → 000155 FS-23d |
| 000157 | CAMA DE ARENA | 2023-11-19 → 2024-07-10 (+234d) | 2023-11-21 → 2024-08-01 (+254d) | 3d → 23d | 143d → 99d | 000155 → 000156 FS-23d |
| 000158 | RELLENO SELECCIONADO PARA ZANJAS CON MATERIAL PROPIO | 2023-11-25 → 2024-07-10 (+228d) | 2023-11-27 → 2024-08-01 (+248d) | 3d → 23d | 143d → 99d | 000159 SS → 000157 FS-23d |
| 000159 | RELLENO COMÚN PARA ZANJAS | 2023-11-25 → 2024-07-10 (+228d) | 2023-11-27 → 2024-08-01 (+248d) | 3d → 23d | 143d → 99d | 000165 → 000158 FS-23d |
| 000160 | CONCRETO f'c=100 kg/cm2 (Buzones) | 2023-11-16 → 2024-07-10 (+237d) | 2023-11-18 → 2024-08-01 (+257d) | 3d → 23d | 100d → 99d | 000154, 000142 → 000159 FS-23d |
| 000161 | CONCRETO f'c=280 kg/cm2 (Buzones) | 2023-12-16 → 2024-07-10 (+207d) | 2023-12-18 → 2024-08-01 (+227d) | 3d → 23d | 105d → 99d | 000163, 000143 → 000160 FS-23d |
| 000162 | ENCOFRADO Y DESENCOFRADO RECTO | 2023-12-13 → 2024-07-10 (+210d) | 2023-12-15 → 2024-08-01 (+230d) | 3d → 23d | 79d → 99d | 000164, 000145 → 000161 FS-23d |
| 000163 | ENCOFRADO Y DESENCOFRADO CURVO | 2023-12-13 → 2024-07-10 (+210d) | 2023-12-15 → 2024-08-01 (+230d) | 3d → 23d | 79d → 99d | 000162 SS → 000162 FS-23d |
| 000164 | ACERO DE REFUERZO fy=4200 kg/cm2 | 2023-12-10 → 2024-07-10 (+213d) | 2023-12-12 → 2024-08-01 (+233d) | 3d → 23d | 79d → 99d | 000160, 000146 → 000163 FS-23d |
| 000165 | SUMINISTRO E INSTALACIÓN DE TUBERÍA GRP DN600 mm SN2500 | 2023-11-22 → 2024-07-10 (+231d) | 2023-11-24 → 2024-08-01 (+251d) | 3d → 23d | 143d → 99d | 000157 → 000164 FS-23d |
| 5 | **CANALES** | 2023-11-16 → 2024-07-10 (+237d) | 2024-02-06 → 2024-08-01 (+177d) |  |  |  |
| 000167 | EXCAVACIÓN ESTRUCTURAL PARA OBRAS DE ARTE | 2023-11-16 → 2024-07-10 (+237d) | 2023-11-20 → 2024-08-01 (+255d) | 5d → 23d | 38d → 40d | 000154 → 000154 FS-23d |
| 000168 | RELLENO ESTRUCTURAL PARA CANALES, CON MATERIAL PROPIO | 2024-01-31 → 2024-07-10 (+161d) | 2024-02-06 → 2024-08-01 (+177d) | 7d → 23d | 79d → 40d | 000170 FS+12d, 000156, 000158 → 000167 FS-23d |
| 000169 | COLOCACIÓN DE CONCRETO f'c=100 kg/cm2 | 2023-11-21 → 2024-07-10 (+232d) | 2023-11-23 → 2024-08-01 (+252d) | 3d → 23d | 98d → 40d | 000167, 000160 → 000168 FS-23d |
| 000170 | COLOCACIÓN DE CONCRETO f'c=280 kg/cm2 | 2024-01-14 → 2024-07-10 (+178d) | 2024-01-18 → 2024-08-01 (+196d) | 5d → 23d | 79d → 40d | 000171, 000161 → 000169 FS-23d |
| 000171 | ENCOFRADO Y DESENCOFRADO | 2023-12-16 → 2024-07-10 (+207d) | 2024-01-13 → 2024-08-01 (+201d) | 29d → 23d | 79d → 40d | 000172 SS+3d, 000163 → 000170 FS-23d |
| 000172 | ACERO DE REFUERZO fy=4200 kg/cm2 | 2023-12-13 → 2024-07-10 (+210d) | 2023-12-24 → 2024-08-01 (+221d) | 12d → 23d | 79d → 40d | 000169, 000164 → 000171 FS-23d |
| 000173 | JUNTA WATER STOP SIN BULBO 150 mm | 2024-01-14 → 2024-07-10 (+178d) | 2024-01-16 → 2024-08-01 (+198d) | 3d → 23d | 100d → 40d | 000170 SS → 000172 FS-23d |
| 3 | **RETORNO A3-OA-RE-D-21-55** | 2023-11-06 → 2024-08-02 (+270d) | 2023-12-29 → 2024-08-20 (+235d) |  |  |  |
| 1 | **MOVIMIENTO DE TIERRAS** | 2023-11-06 → 2024-08-02 (+270d) | 2023-12-25 → 2024-08-20 (+239d) |  |  |  |
| 000176 | EXCAVACIÓN ESTRUCTURAL PARA OBRAS DE ARTE | 2023-11-06 → 2024-08-02 (+270d) | 2023-11-08 → 2024-08-20 (+286d) | 3d → 19d | 118d → 40d | 000017 SS+4d → 000170, 000173 |
| 000177 | RELLENO ESTRUCTURAL PARA OBRAS DE ARTE, CON MATERIAL PROPIO | 2023-12-23 → 2024-08-02 (+223d) | 2023-12-25 → 2024-08-20 (+239d) | 3d → 19d | 122d → 40d | 000180 FS+12d → 000176 FS-19d |
| 2 | **OBRAS DE CONCRETO** | 2023-11-09 → 2024-08-02 (+267d) | 2023-12-10 → 2024-08-20 (+254d) |  |  |  |
| 000179 | CONCRETO f'c=100 kg/cm2 | 2023-11-09 → 2024-08-02 (+267d) | 2023-11-11 → 2024-08-20 (+283d) | 3d → 19d | 118d → 40d | 000176 → 000176 FS-19d |
| 000180 | CONCRETO f'c=280 kg/cm2 | 2023-12-06 → 2024-08-02 (+240d) | 2023-12-10 → 2024-08-20 (+254d) | 5d → 19d | 118d → 40d | 000182 → 000179 FS-19d |
| 000181 | CONCRETO CICLÓPEO f'c=280 kg/cm2 + 30% P.G. | 2023-11-12 → 2024-08-02 (+264d) | 2023-11-16 → 2024-08-20 (+278d) | 5d → 19d | 118d → 40d | 000179 → 000180 FS-19d |
| 000182 | ENCOFRADO Y DESENCOFRADO | 2023-11-18 → 2024-08-02 (+258d) | 2023-12-05 → 2024-08-20 (+259d) | 18d → 19d | 118d → 40d | 000183 SS+6d → 000181 FS-19d |
| 000183 | ACERO DE REFUERZO fy=4200 kg/cm2 | 2023-11-12 → 2024-08-02 (+264d) | 2023-12-05 → 2024-08-20 (+259d) | 24d → 19d | 118d → 40d | 000181 SS → 000182 FS-19d |
| 000184 | JUNTA WATER STOP SIN BULBO 150 mm | 2023-12-06 → 2024-08-02 (+240d) | 2023-12-10 → 2024-08-20 (+254d) | 5d → 19d | 137d → 40d | 000180 SS → 000183 FS-19d |
| 3 | **ESTRUCTURAS METALICAS** | 2023-12-23 → 2024-08-02 (+223d) | 2023-12-29 → 2024-08-20 (+235d) |  |  |  |
| 000186 | COMPUERTA METALICA PLANA DESLIZANTE DE 1.0x1.6 m | 2023-12-23 → 2024-08-02 (+223d) | 2023-12-26 → 2024-08-20 (+238d) | 4d → 19d | 118d → 40d | 000180 FS+12d → 000180 FS-19d |
| 000187 | BARANDA DE FIERRO GALVANIZADO 1 1/2" | 2023-12-27 → 2024-08-02 (+219d) | 2023-12-29 → 2024-08-20 (+235d) | 3d → 19d | 118d → 40d | 000186 → 000186 FS-19d |
| 4 | **REPOSICIÓN DE CANALES** | 2023-11-22 → 2024-08-21 (+273d) | 2024-04-22 → 2024-09-29 (+160d) |  |  |  |
| 1 | **REPOSICIÓN DE CANAL 1** | 2024-01-17 → 2024-08-21 (+217d) | 2024-04-22 → 2024-09-10 (+141d) |  |  |  |
| 1 | **MOVIMIENTO DE TIERRAS** | 2024-01-17 → 2024-08-21 (+217d) | 2024-04-22 → 2024-09-10 (+141d) |  |  |  |
| 000191 | DEMOLICIÓN DE ESTRUCTURAS EXISTENTES | 2024-01-17 → 2024-08-21 (+217d) | 2024-02-02 → 2024-09-10 (+221d) | 17d → 21d | 83d → 40d | EXCAVACIÓN EN TERRENO NATURAL CON EQUIPO → 000180, 000187, 000184, 000177 |
| 000192 | EXCAVACIÓN EN TERRENO NATURAL CON EQUIPO | 2023-12-16 → 2024-08-21 (+249d) | 2023-12-22 → 2024-09-10 (+263d) | 7d → 21d | 0d → 40d | CONFORMACIÓN DE DESVIO EN CAUCE DE RÍO - DIQUE A3-D-01 → 000191 FS-21d |
| 000193 | RELLENO ESTRUCTURAL PARA OBRAS DE ARTE CON MATERIAL PROPIO | 2024-03-15 → 2024-08-21 (+159d) | 2024-04-22 → 2024-09-10 (+141d) | 39d → 21d | 3d → 40d | 000198 SS+20d, 000205 → 000192 FS-21d |
| 2 | **OBRAS DE CONCRETO** | 2024-01-31 → 2024-08-21 (+203d) | 2024-04-20 → 2024-09-10 (+143d) |  |  |  |
| 000195 | ENCOFRADO Y DESENCOFRADO RECTO | 2024-02-10 → 2024-08-21 (+193d) | 2024-04-12 → 2024-09-10 (+151d) | 63d → 21d | 3d → 40d | 000196 SS+7d → 000192 FS-21d |
| 000196 | ACERO DE REFUERZO fy=4200 kg/cm2 | 2024-02-03 → 2024-08-21 (+200d) | 2024-04-12 → 2024-09-10 (+151d) | 70d → 21d | 3d → 40d | 000197 SS+3d → 000195 FS-21d |
| 000197 | CONCRETO f'c=100 kg/cm2 | 2024-01-31 → 2024-08-21 (+203d) | 2024-03-06 → 2024-09-10 (+188d) | 36d → 21d | 3d → 40d | EXCAVACIÓN EN TERRENO NATURAL CON EQUIPO SS+7d → 000196 FS-21d |
| 000198 | CONCRETO f'c=280 kg/cm2 | 2024-02-24 → 2024-08-21 (+179d) | 2024-04-17 → 2024-09-10 (+146d) | 54d → 21d | 3d → 40d | 000195 SS+14d → 000197 FS-21d |
| 000199 | JUNTA WATER STOP 6" | 2024-02-24 → 2024-08-21 (+179d) | 2024-04-17 → 2024-09-10 (+146d) | 54d → 21d | 8d → 40d | 000198 SS → 000198 FS-21d |
| 000200 | MAMPOSTERIA DE PIEDRA, e=20cm, ACABADO CARA VISTA | 2024-04-18 → 2024-08-21 (+125d) | 2024-04-20 → 2024-09-10 (+143d) | 3d → 21d | 5d → 40d | 000198 → 000199 FS-21d |
| 2 | **REPOSICIÓN DE CANAL 3** | 2023-11-22 → 2024-09-11 (+294d) | 2024-01-19 → 2024-09-29 (+254d) |  |  |  |
| 1 | **MOVIMIENTO DE TIERRAS** | 2023-11-22 → 2024-09-11 (+294d) | 2024-01-19 → 2024-09-29 (+254d) |  |  |  |
| 000203 | DEMOLICIÓN DE ESTRUCTURAS EXISTENTES | 2023-11-22 → 2024-09-11 (+294d) | 2023-12-01 → 2024-09-29 (+303d) | 10d → 19d | 70d → 40d | 000038 → 000197, 000193, 000200 |
| 000204 | EXCAVACIÓN EN TERRENO NATURAL CON EQUIPO | 2024-01-03 → 2024-09-11 (+252d) | 2024-01-06 → 2024-09-29 (+267d) | 4d → 19d | 96d → 40d | CONFORMACIÓN DE CORONA DE DIQUE CON MATERIAL PROPIO → 000203 FS-19d |
| 000205 | RELLENO ESTRUCTURAL PARA OBRAS DE ARTE CON MATERIAL PROPIO | 2024-01-17 → 2024-09-11 (+238d) | 2024-01-19 → 2024-09-29 (+254d) | 3d → 19d | 58d → 40d | 000211 FS+6d → 000204 FS-19d |
| 2 | **OBRAS DE CONCRETO** | 2023-12-18 → 2024-09-11 (+268d) | 2024-01-13 → 2024-09-29 (+260d) |  |  |  |
| 000207 | ENCOFRADO Y DESENCOFRADO PARA REVESTIMIENTO DE CANALES (CERCHAS) | 2023-12-25 → 2024-09-11 (+261d) | 2024-01-05 → 2024-09-29 (+268d) | 12d → 19d | 58d → 40d | 000209 SS+3d → 000204 FS-19d |
| 000208 | ENCOFRADO Y DESENCOFRADO RECTO | 2023-12-25 → 2024-09-11 (+261d) | 2024-01-05 → 2024-09-29 (+268d) | 12d → 19d | 58d → 40d | 000207 SS → 000207 FS-19d |
| 000209 | MALLA ELECTROSOLDADA DE DN6mm EN CUADRICULA 15x15 cm | 2023-12-22 → 2024-09-11 (+264d) | 2024-01-05 → 2024-09-29 (+268d) | 15d → 19d | 58d → 40d | 000210 → 000208 FS-19d |
| 000210 | CONCRETO f'c=100 kg/cm2 | 2023-12-18 → 2024-09-11 (+268d) | 2023-12-21 → 2024-09-29 (+283d) | 4d → 19d | 58d → 40d | EXCAVACIÓN EN TERRENO NATURAL CON EQUIPO → 000209 FS-19d |
| 000211 | CONCRETO f'c=280 kg/cm2 | 2024-01-06 → 2024-09-11 (+249d) | 2024-01-10 → 2024-09-29 (+263d) | 5d → 19d | 58d → 40d | 000208 → 000210 FS-19d |
| 000212 | SELLO DE JUNTA CONSTRUCCIÓN CON MATERIAL ELASTOMÉRICO | 2023-12-25 → 2024-09-11 (+261d) | 2024-01-03 → 2024-09-29 (+270d) | 10d → 19d | 113d → 40d | 000207 SS → 000211 FS-19d |
| 000213 | MAMPOSTERIA DE PIEDRA, e=20cm, ACABADO CARA VISTA | 2024-01-11 → 2024-09-11 (+244d) | 2024-01-13 → 2024-09-29 (+260d) | 3d → 19d | 103d → 40d | 000211 → 000212 FS-19d |
| 5 | **REPOSICIÓN SIFON INOPERATIVO** | 2023-12-08 → 2024-07-11 (+216d) | 2024-01-16 → 2024-08-08 (+205d) |  |  |  |
| 000225 | CODOS HDPE DE 14" DN 355mm | 2023-12-24 → 2024-07-11 (+200d) | 2023-12-29 → 2024-07-23 (+207d) | 6d → 13d | 118d → 108d | 000220 SS → 000224 FS-15d |
| 000224 | ACERO DE REFUERZO fy=4200 kg/cm2 | 2023-12-24 → 2024-07-13 (+202d) | 2023-12-26 → 2024-07-25 (+212d) | 3d → 13d | 100d → 106d | 000221 → 000223 FS-15d |
| 000223 | ENCOFRADO Y DESENCOFRADO RECTO | 2023-12-27 → 2024-07-15 (+201d) | 2023-12-29 → 2024-07-27 (+211d) | 3d → 13d | 100d → 104d | 000224 → 000222 FS-15d |
| 000222 | CONCRETO f'c=280 kg/cm2 | 2023-12-30 → 2024-07-17 (+200d) | 2024-01-01 → 2024-07-29 (+210d) | 3d → 13d | 100d → 102d | 000223 → 000221 FS-15d |
| 000221 | CONCRETO f'c=100 kg/cm2 | 2023-12-21 → 2024-07-19 (+211d) | 2023-12-23 → 2024-07-31 (+221d) | 3d → 13d |  | 000216 → 000220 FS-15d |
| 000220 | TUBERÍAS DE 14" HDPE SDR21 DN 355mm | 2023-12-24 → 2024-07-21 (+210d) | 2023-12-29 → 2024-08-02 (+217d) | 6d → 13d | 109d → 98d | 000217 → 000219 FS-15d |
| 000219 | RELLENO COMÚN | 2023-12-30 → 2024-07-23 (+206d) | 2024-01-07 → 2024-08-04 (+210d) | 9d → 13d | 109d → 96d | 000220 → 000218 FS-15d |
| 000218 | RELLENO ESTRUCTURAL PARA OBRAS DE ARTE CON MATERIAL PROPIO | 2024-01-14 → 2024-07-25 (+193d) | 2024-01-16 → 2024-08-06 (+203d) | 3d → 13d | 100d → 94d | 000222 FS+12d → 000217 FS-15d |

| ID | Task | Start | Finish | Duration | Total float | Predecessors |
| --- | --- | --- | --- | --- | --- | --- |
| 000215 | DEMOLICIÓN DE ESTRUCTURAS EXISTENTES | 2023-12-08 → 2024-07-27 (+232d) | 2023-12-10 → 2024-08-08 (+242d) | 3d → 13d | 100d → 92d | DESCOLMATACIÓN DE CAUCE NATURAL DEL RÍO LACRAMARCA - DIQUE A3-D-01, DESCOLMATACIÓN DE CAUCE NATURAL DEL RÍO LACRAMARCA - DIQUE A3-I-01 → 000051 SS+10d |
| 000216 | EXCAVACIÓN ESTRUCTURAL PARA OBRAS DE ARTE | 2023-12-11 → 2024-07-27 (+229d) | 2023-12-20 → 2024-08-08 (+232d) | 10d → 13d | 100d → 92d | 000215 → 000215 FS-13d |
| 000217 | COLOCACIÓN CAMA DE ARENA | 2023-12-21 → 2024-07-27 (+219d) | 2023-12-23 → 2024-08-08 (+229d) | 3d → 13d | 109d → 92d | 000216 → 000216 FS-13d |
| 4 | **ARQUITECTURA Y PAISAJISMO** | 2024-01-26 → 2024-05-19 (+114d) | 2024-04-08 → 2024-06-05 (+58d) |  |  |  |
| 1 | **OBRAS PRELIMINARES** | 2024-01-26 → 2024-05-19 (+114d) | 2024-04-08 → 2024-06-05 (+58d) |  |  |  |
| 000236 | TRAZO Y REPLANTEO PRELIMINAR | 2024-01-28 → 2024-05-19 (+112d) | 2024-01-29 → 2024-06-05 (+128d) | 2d → 18d | 17d → 156d | MOVILIZACIÓN DE EQUIPOS Y HERRAMIENTAS (ARQUITECTURA Y PAISAJISMO) → 000235 FS-18d |
| 2 | **MOVIMIENTO DE TIERRAS** | 2024-01-30 → 2024-05-19 (+110d) | 2024-02-15 → 2024-06-05 (+111d) |  |  |  |
| 000238 | EXCAVACIÓN MANUAL PARA INSTALACIÓN DE BORDILLOS Y CIMENTACIONES | 2024-01-30 → 2024-05-19 (+110d) | 2024-01-31 → 2024-06-05 (+126d) | 2d → 18d | 17d → 156d | 000236 → 000235 FS-18d |
| 000239 | EXCAVACIÓN PARA MEJORAMIENTO DE SUELO CON TIERRA VEGETAL | 2024-02-01 → 2024-05-19 (+108d) | 2024-02-15 → 2024-06-05 (+111d) | 15d → 18d | 17d → 156d | 000238 → 000238 FS-18d |
| 000240 | ELIMINACION DE MATERIAL EXCEDENTE (DME´S) | 2024-01-30 → 2024-05-19 (+110d) | 2024-02-15 → 2024-06-05 (+111d) | 17d → 18d | 68d → 156d | 000238 SS → 000239 FS-18d |
| 3 | **PAVIMENTOS, RECUBRIMIENTOS Y BORDILLOS** | 2024-02-16 → 2024-05-19 (+93d) | 2024-02-26 → 2024-06-05 (+100d) |  |  |  |
| 000242 | PISO DE GRAVILLA | 2024-02-16 → 2024-05-19 (+93d) | 2024-02-17 → 2024-06-05 (+109d) | 2d → 18d | 17d → 156d | 000239 → 000239 FS-18d |
| 000243 | RECUBRIMIENTO DE PIEDRA DEL LUGAR e=0.05cm | 2024-02-18 → 2024-05-19 (+91d) | 2024-02-21 → 2024-06-05 (+105d) | 4d → 18d | 17d → 156d | 000242 → 000242 FS-18d |
| 000244 | BORDILLOS DE PIEDRA DEL LUGAR | 2024-02-22 → 2024-05-19 (+87d) | 2024-02-26 → 2024-06-05 (+100d) | 5d → 18d | 17d → 156d | 000243 → 000243 FS-18d |
| 4 | **MOBILIARIOS, BARANDAS Y ESCALERAS** | 2024-02-27 → 2024-05-19 (+82d) | 2024-04-04 → 2024-06-05 (+62d) |  |  |  |
| 000246 | ESCALERA DE CONCRETO SOBRE ENROCADO, CIMENTACION Y ANCLAJE | 2024-02-27 → 2024-05-19 (+82d) | 2024-03-07 → 2024-06-05 (+90d) | 10d → 18d | 17d → 156d | 000244 → 000243 FS-18d |
| 000247 | BARANDA DE MADERA EUCALIPTO CON SOGA, INCLUYE CIMENTACIÓN | 2024-03-08 → 2024-05-19 (+72d) | 2024-03-11 → 2024-06-05 (+86d) | 4d → 18d | 17d → 156d | 000246 → 000246 FS-18d |
| 000248 | TACHOS DE BASURA, INCLUYE CIMENTACIÓN | 2024-03-12 → 2024-05-19 (+68d) | 2024-03-14 → 2024-06-05 (+83d) | 3d → 18d | 17d → 156d | 000247 → 000247 FS-18d |
| 000249 | BANCAS DE CONCRETO, INCLUYE CIMENTACIÓN | 2024-03-15 → 2024-05-19 (+65d) | 2024-03-24 → 2024-06-05 (+73d) | 10d → 18d | 17d → 156d | 000248 → 000248 FS-18d |
| 000250 | POSTES DE ILUMINACIÓN, INCLUYE LUMINARIA Y CIMENTACIÓN | 2024-03-25 → 2024-05-19 (+55d) | 2024-03-29 → 2024-06-05 (+68d) | 5d → 18d | 17d → 156d | 000249 → 000249 FS-18d |
| 000251 | SEÑALETICA INFORMATIVA | 2024-03-30 → 2024-05-19 (+50d) | 2024-04-01 → 2024-06-05 (+65d) | 3d → 18d | 17d → 156d | 000250 → 000250 FS-18d |
| 000252 | BOLARDOS DE PIEDRA | 2024-04-02 → 2024-05-19 (+47d) | 2024-04-04 → 2024-06-05 (+62d) | 3d → 18d | 17d → 156d | 000251 → 000251 FS-18d |
| 000254 | ALCORQUES DE PIEDRA DE CANTO RODADO PARA ARBOLES | 2024-04-05 → 2024-05-19 (+44d) | 2024-04-06 → 2024-05-20 (+44d) |  | 17d → 172d | 000252 → 000235 SS |
| 5 | **PROGRAMA DE CIERRE DE OBRA** | 2023-11-06 → 2024-05-19 (+195d) | 2024-04-21 → 2024-11-06 (+199d) |  |  |  |
| 000256 | ACONDICIONAMIENTO DE DEPOSITOS DE MATERIALES EXCEDENTES (DME) | 2023-11-06 → 2024-05-19 (+195d) | 2024-04-13 → 2024-11-06 (+207d) | 160d → 172d | 4d → 2d | 000032 SS → 000023 SS |
| 000257 | RESTAURACIÓN DE ÁREAS DE INSTALACIONES PROVISIONALES | 2024-04-14 → 2024-05-19 (+35d) | 2024-04-21 → 2024-11-06 (+199d) | 8d → 172d | 4d → 2d | CONFORMACIÓN DE CUERPO DE DIQUE CON MATERIAL PROPIO, 000256 → 000256 SS |

## Version 6 (data date 2024-10-16, saved 2024-09-27, file 4.1.1 Cronograma del Proyecto.xer)

Last finish 2024-11-08 → 2025-04-29 (+172d).

Added:

| ID | Task | Duration | Start | Finish | Predecessors |
| --- | --- | --- | --- | --- | --- |
| A1000 | KICK OFF MEETING | 0d | 2024-10-16 | 2024-10-16 |  |
| A1010 | INICIO DE PLAZO CONTRACTUAL - ACCESO AL SITIO | 0d | 2024-11-01 | 2024-11-01 | A1000 FS+16d |
| A1015 | INICIO DE EXCAVACIÓN | 0d | 2024-11-06 | 2024-11-06 | A1060 SS+5d, A1010 SS+5d |
| A1016 | INICIO DE RELLENO DE DIQUE | 0d | 2024-11-28 | 2024-11-28 | A1015 SS+22d |
| A1020 | FIN DE PLAZO CONTRACTUAL - CULMINACION DE OBRAS | 0d | 2025-04-29 | 2025-04-29 | A1780, A1070, A1050, A4020, A3850, A3790, A3780, A3740, A3730, A3470, A3450, A3140, A2930, A1900, A5010 FF, A5010 SF, A1890 FF, A1016 SF, A4430 FF, A5210 FF, A4960 FF, A4990 FF, A5610 FF, A5620 FF, A5740 FF, A4740 FF, A1080 FF |
| A1030 | CARTEL DE IDENTIFICACIÓN OBRA 4.80 x 3.60 m. | 2d | 2024-11-01 | 2024-11-02 | A1060 SS+2d, A1010 SS |
| 4 | **DESCOLMATACIÓN DE CAUCE Y OBRAS AUXILIARES** |  | 2024-11-01 | 2025-04-13 |  |
| 1 | **DESBROCE Y DESCOLMATACIÓN** |  | 2024-11-01 | 2025-02-05 |  |
| A5250 | DESBROCE Y LIMPIEZA INICIAL EN ZONA NO BOSCOSA | 4d | 2024-11-01 | 2024-11-04 | A1060 |
| A5260 | DESCOLMATACIÓN DE CAUCE NATURAL DEL RÍO LACRAMARCA - DIQUE A3-D-02 - INICIAL | 3d | 2024-11-05 | 2024-11-07 | A5250 |
| A1230 | DESCOLMATACIÓN DE CAUCE NATURAL DEL RÍO LACRAMARCA - DIQUE A3-D-01 | 10d | 2024-11-08 | 2024-11-17 | A1220 SS+2d |
| A1880 | DESCOLMATACIÓN DE CAUCE NATURAL DEL RÍO LACRAMARCA - DIQUE A3-I-01 | 32d | 2024-11-12 | 2024-12-13 | A1220 SS+6d |
| A1870 | DESCOLMATACIÓN DE CAUCE NATURAL DEL RÍO LACRAMARCA - DIQUE A3-D-02 | 53d | 2024-11-18 | 2025-01-09 | A1230 |
| A1890 | DESCOLMATACIÓN DE CAUCE NATURAL DEL RÍO LACRAMARCA - DIQUE A3-I-02 | 20d | 2024-12-14 | 2025-01-02 | A1880 |
| A1900 | DESCOLMATACIÓN DE CAUCE NATURAL DEL RÍO LACRAMARCA - DIQUE A3-I-03 | 34d | 2025-01-03 | 2025-02-05 | A1890 |
| 2 | **DESVIO DEL CAUCE** |  | 2024-11-08 | 2025-04-13 |  |
| 1 | **CONSTRUCCION DIQUE A3-D-01** |  | 2024-11-08 | 2024-12-07 |  |
| 1 | **CONSTRUCCION DIQUE A3-D-02 TRAMO 1** |  | 2024-11-26 | 2025-01-10 |  |
| 4 | **CONSTRUCCION DIQUE A3-D-02 TRAMO 2** |  | 2025-01-09 | 2025-02-13 |  |
| 3 | **CONSTRUCCION DIQUE A3-D-02 TRAMO 3** |  | 2025-02-12 | 2025-03-20 |  |
| 2 | **CONSTRUCCION DIQUE A3-D-02 TRAMO 4** |  | 2025-03-19 | 2025-04-24 |  |
| 1 | **CONSTRUCCION DIQUE A3-I-01** |  | 2024-11-08 | 2024-12-16 |  |
| A1450 | EXCAVACIÓN DE UÑA CON EQUIPO | 5d | 2024-11-22 | 2024-11-26 | A1440 FS+3d |
| A1460 | PERFILADO Y COMPACTACIÓN EN ZONA DE CORTE | 8d | 2024-11-22 | 2024-11-29 | A1440 SS+1d, A1450 SS |
| A1520 | PREPARACIÓN DE FUNDACIÓN DE CUERPO DE DIQUE | 2d | 2024-11-25 | 2024-11-26 | A1460 SS+3d |
| A1470 | CONFORMACIÓN DE CUERPO DE DIQUE CON MATERIAL PROPIO | 8d | 2024-11-28 | 2024-12-05 | A1520 SS+1d, A1016 SS |
| A1490 | GEOTEXTIL NO TEJIDO 400 G/M2, INC. COLOCACIÓN | 5d | 2024-11-30 | 2024-12-04 | A1470 SS+2d |
| A1500 | COLOCACION Y ACOMODO DE ROCA EN UÑA DE DIQUE | 6d | 2024-12-01 | 2024-12-06 | A1490 SS+1d, A1450 |
| A1510 | COLOCACION Y ACOMODO DE ROCA EN TALUD DE DIQUE | 12d | 2024-12-03 | 2024-12-14 | A1500 SS+2d, A1440 |
| 2 | **CONSTRUCCION DIQUE A3-I-02** |  | 2024-12-17 | 2025-01-16 |  |
| A4400 | EXCAVACIÓN DE UÑA CON EQUIPO | 7d | 2024-12-18 | 2024-12-24 | A4390 SS+1d |
| A4410 | PERFILADO Y COMPACTACIÓN EN ZONA DE CORTE | 11d | 2024-12-20 | 2024-12-30 | A4390 SS+3d |
| A4470 | PREPARACIÓN DE FUNDACIÓN DE CUERPO DE DIQUE | 1d | 2024-12-31 | 2024-12-31 | A4410 FF+1d |
| A4420 | CONFORMACIÓN DE CUERPO DE DIQUE CON MATERIAL PROPIO | 2d | 2025-01-01 | 2025-01-02 | A4470 SS+1d, A4400 |
| A4440 | GEOTEXTIL NO TEJIDO 400 G/M2, INC. COLOCACIÓN | 5d | 2025-01-01 | 2025-01-05 | A4420 SS, A4410 |
| A4450 | COLOCACION Y ACOMODO DE ROCA EN UÑA DE DIQUE | 16d | 2025-01-01 | 2025-01-16 | A4440 SS |
| A4460 | COLOCACION Y ACOMODO DE ROCA EN TALUD DE DIQUE | 14d | 2025-01-01 | 2025-01-14 | A4450 SS |
| 1 | **CONSTRUCCION DIQUE A3-I-03 TRAMO 1** |  | 2025-01-15 | 2025-02-16 |  |
| A4950 | PERFILADO Y COMPACTACIÓN EN ZONA DE CORTE | 16d | 2025-01-16 | 2025-01-31 | A4930 SS+1d, A4430 |
| A4940 | EXCAVACIÓN DE UÑA CON EQUIPO | 10d | 2025-01-17 | 2025-01-26 | A4450 |
| A4970 | CONFORMACIÓN DE CUERPO DE DIQUE CON MATERIAL PROPIO | 8d | 2025-01-19 | 2025-01-26 | A4940 SS+2d |
| A4980 | GEOTEXTIL NO TEJIDO 400 G/M2, INC. COLOCACIÓN | 7d | 2025-01-21 | 2025-01-27 | A4970 SS+2d |
| A4990 | COLOCACION Y ACOMODO DE ROCA EN UÑA DE DIQUE | 23d | 2025-01-24 | 2025-02-15 | A4980 SS, A4930 |
| A5000 | COLOCACION Y ACOMODO DE ROCA EN TALUD DE DIQUE | 21d | 2025-01-27 | 2025-02-16 | A4990 SS+1d, A4940 |
| A4960 | PREPARACIÓN DE FUNDACIÓN DE CUERPO DE DIQUE | 5d | 2025-02-01 | 2025-02-05 | A4950 SS+16d |
| 3 | **CONSTRUCCION DIQUE A3-I-03 TRAMO 2** |  | 2025-02-16 | 2025-03-19 |  |
| A5630 | EXCAVACIÓN EN TERRENO NATURAL CON EQUIPO | 9d | 2025-02-16 | 2025-02-24 | A4990 |
| A5650 | PERFILADO Y COMPACTACIÓN EN ZONA DE CORTE | 16d | 2025-02-16 | 2025-03-03 | A5630 SS |
| A5640 | EXCAVACIÓN DE UÑA CON EQUIPO | 10d | 2025-02-17 | 2025-02-26 | A5000 |
| A5660 | CONFORMACIÓN DE CUERPO DE DIQUE CON MATERIAL PROPIO | 5d | 2025-02-18 | 2025-02-22 | A5640 SS+1d, A4960 |
| A5680 | GEOTEXTIL NO TEJIDO 400 G/M2, INC. COLOCACIÓN | 7d | 2025-02-20 | 2025-02-26 | A5660 SS+2d |
| A5710 | PREPARACIÓN DE FUNDACIÓN DE CUERPO DE DIQUE | 2d | 2025-02-21 | 2025-02-22 | A5650 SS+5d |
| A5690 | COLOCACION Y ACOMODO DE ROCA EN UÑA DE DIQUE | 23d | 2025-02-25 | 2025-03-19 | A5680 SS, A5630 |
| A5700 | COLOCACION Y ACOMODO DE ROCA EN TALUD DE DIQUE | 21d | 2025-02-27 | 2025-03-19 | A5690 SS+1d, A5640 |
| 2 | **CONSTRUCCION DIQUE A3-I-03 TRAMO 3** |  | 2025-03-20 | 2025-04-20 |  |
| A5540 | EXCAVACIÓN EN TERRENO NATURAL CON EQUIPO | 9d | 2025-03-20 | 2025-03-28 | A5690 |
| A5550 | EXCAVACIÓN DE UÑA CON EQUIPO | 10d | 2025-03-20 | 2025-03-29 | A5540 SS, A5700, A5710 |
| A5560 | PERFILADO Y COMPACTACIÓN EN ZONA DE CORTE | 16d | 2025-03-20 | 2025-04-04 | A5540 SS |
| A5570 | CONFORMACIÓN DE CUERPO DE DIQUE CON MATERIAL PROPIO | 5d | 2025-03-21 | 2025-03-25 | A5550 SS+1d |
| A5590 | GEOTEXTIL NO TEJIDO 400 G/M2, INC. COLOCACIÓN | 7d | 2025-03-23 | 2025-03-29 | A5570 SS+2d |
| A5600 | COLOCACION Y ACOMODO DE ROCA EN UÑA DE DIQUE | 23d | 2025-03-29 | 2025-04-20 | A5590 SS, A5540 |
| A5610 | COLOCACION Y ACOMODO DE ROCA EN TALUD DE DIQUE | 21d | 2025-03-30 | 2025-04-19 | A5600 SS+1d, A5550 |
| A5620 | PREPARACIÓN DE FUNDACIÓN DE CUERPO DE DIQUE | 2d | 2025-04-05 | 2025-04-06 | A5560 SS+16d |
| 2 | **A3-RA-I-01** |  | 2025-01-27 | 2025-02-13 |  |
| A1740 | EXCAVACIÓN EN TERRENO NATURAL CON EQUIPO | 9d | 2025-01-27 | 2025-02-04 | A4940, A4930 |
| 1 | **A3-RA-D-01** |  | 2025-03-31 | 2025-04-12 |  |
| A1710 | EXCAVACIÓN EN TERRENO NATURAL CON EQUIPO | 7d | 2025-03-31 | 2025-04-06 | A5280 |
| A1720 | CONFORMACIÓN DE CUERPO DE RAMPA CON MATERIAL PROPIO | 6d | 2025-04-07 | 2025-04-12 | A1710 |
| A1730 | CONFORMACIÓN DE CORONACIÓN DE RAMPA | 6d | 2025-04-07 | 2025-04-12 | A1720 SS |
| A5220 | SECADO DE CONCRETO f'c=280 kg/cm2 | 18d | 2024-12-20 | 2025-01-06 | A2800 |
| A5750 | SECADO DE CONCRETO f'c=280 kg/cm2 | 12d | 2024-12-20 | 2024-12-31 | A2800 |
| A5230 | SECADO DE CONCRETO f'c=280 kg/cm2 | 12d | 2024-12-14 | 2024-12-25 | A3180 |
| A5240 | SECADO DE CONCRETO f'c=280 kg/cm2 (Buzones) | 12d | 2024-12-25 | 2025-01-05 | A3340 |
| A3570 | EXCAVACIÓN EN TERRENO NATURAL CON EQUIPO | 36d | 2025-01-07 | 2025-02-11 | A3560 SS+6d, A3760 |
| A3590 | ENCOFRADO RECTO | 61d | 2025-02-04 | 2025-04-05 | A3600 SS, A3530, A3550 |
| A5730 | SECADO DE CONCRETO f'c=280 kg/cm2 | 14d | 2025-03-31 | 2025-04-13 | A3620 |
| A5740 | DESENCOFRADO RECTO | 10d | 2025-04-14 | 2025-04-23 | A5730 |
| A3660 | EXCAVACIÓN EN TERRENO NATURAL CON EQUIPO | 18d | 2024-12-01 | 2024-12-18 | A3650 |
| A3860 | MOVILIZACIÓN DE EQUIPOS Y HERRAMIENTAS (ARQUITECTURA Y PAISAJISMO) | 8d | 2025-01-23 | 2025-01-30 | A4420 FS+20d |
| A4020 | DEMOVILIZACIÓN DE EQUIPOS Y HERRAMIENTAS (ARQUITECTURA Y PAISAJISMO) | 8d | 2025-04-17 | 2025-04-24 | A4010, A3900 |
| 5 | **INSTALACIÓN DE ALCORQUES** |  | 2025-04-15 | 2025-04-16 |  |

Removed: 000002 INICIO; 000003 KOM; 000004 ENTREGA DE TERRENO; 000005 NOTIFICACION DE OS; 000006 Inicio OS; 000007 Inicio del Proyecto; 000008 Fin de la Construccion; DESCOLMATACIÓN DE CAUCE y OBRAS AUXILIARES; 000033 DESCOLMATACIÓN DE CAUCE NATURAL DEL RÍO LACRAMARCA; 000223 ENCOFRADO Y DESENCOFRADO RECTO; TRANSPORTE DE MATERIAL; 000229 TRANSPORTE DE ROCA PARA DISTANCIAS <1KM; 000228 TRANSPORTE DE MATERIAL GRANULAR PARA DISTANCIAS >1KM; 000227 TRANSPORTE DE MATERIAL GRANULAR PARA DISTANCIAS <1KM; 000230 TRANSPORTE DE ROCA PARA DISTANCIAS >1KM; 000231 TRANSPORTE DE MATERIAL EXCEDENTE PARA DISTANCIAS <1KM; 000232 TRANSPORTE DE MATERIAL EXCEDENTE PARA DISTANCIAS >1KM; 000235 MOVILIZACIÓN Y DEMOVILIZACIÓN DE EQUIPOS Y HERRAMIENTAS (ARQUITECTURA Y PAISAJISMO); INSTALACION DE ALCORQUES; SEGURIDAD Y SALUD OCUPACIONAL; 000259 SEGURIDAD Y SALUD OCUPACIONAL; LIMPIEZA Y ENTREGA; 000262 LIMPIEZA DEL SITIO; 000261 TERMINO DE LOS TRABAJOS; 000263 ENTREGA

Changed:

| ID | Task | Start | Finish | Duration | Total float | Predecessors |
| --- | --- | --- | --- | --- | --- | --- |
| 0 | **HITOS** | 2024-05-01 → 2024-10-16 (+168d) | 2024-11-08 → 2025-04-29 (+172d) |  |  |  |
| 1 | **DEFENSAS RIBEREÑAS** | 2024-05-04 → 2024-10-16 (+165d) | 2024-11-08 → 2025-04-29 (+172d) |  |  |  |
| 2 | **TRABAJOS PRELIMINARES** | 2024-05-04 → 2024-10-16 (+165d) | 2024-11-08 → 2025-04-29 (+172d) |  |  |  |
| A1060 | MOVILIZACION DE EQUIPOS | 2024-05-04 → 2024-10-16 (+165d) | 2024-05-23 → 2024-10-31 (+161d) | 20d → 16d |  | Inicio del Proyecto → A1000 SS |
| A1070 | TOPOGRAFÍA Y GEOREFERENCIACIÓN | 2024-05-14 → 2024-11-01 (+171d) | 2024-11-06 → 2025-04-24 (+169d) | 177d → 175d | 2d → 5d | A1060 FS-10d → A1060 SS+2d, A1010 SS |
| A1080 | DESMOVILIZACION DE EQUIPOS | 2024-10-30 → 2025-04-25 (+177d) | 2024-11-08 → 2025-04-29 (+172d) | 10d → 5d |  | A5340 FS-10d → A5340, A1730 |
| 1 | **OBRAS PRELIMINARES** | 2024-05-14 → 2024-11-01 (+171d) | 2024-11-06 → 2025-04-28 (+173d) |  |  |  |
| A1040 | INSTALACIONES PROVISIONALES PARA LA OBRA | 2024-05-14 → 2024-11-06 (+176d) | 2024-05-28 → 2025-04-23 (+330d) | 15d → 169d | 2d → 1d | A1060 SS+10d → A1015, A1030 |
| A1050 | MANTENIMIENTO DE TRÁNSITO Y SEGURIDAD VIAL | 2024-05-29 → 2024-11-26 (+181d) | 2024-11-06 → 2025-04-28 (+173d) | 162d → 154d | 2d → 1d | A1040 → A1100 |
| 3 | **MEJORAMIENTO DE VÍAS EXISTENTES** | 2024-05-19 → 2024-11-06 (+171d) | 2024-06-02 → 2025-01-06 (+218d) |  |  |  |
| 1 | **MOVIMIENTO DE TIERRAS** | 2024-05-19 → 2024-11-06 (+171d) | 2024-06-02 → 2024-11-25 (+176d) |  |  |  |
| A1090 | ROCE Y LIMPIEZA DE MALEZA | 2024-05-19 → 2024-11-06 (+171d) | 2024-06-02 → 2024-11-25 (+176d) | 15d → 20d | 0d → 1d | A1060 FS-5d → A1015 SS, A1040 SS |
| A1100 | MEJORAMIENTO DE VIAS EXISTENTES | 2024-05-19 → 2024-11-06 (+171d) | 2024-06-02 → 2024-11-25 (+176d) | 15d → 20d | 0d → 1d | A1090 FS-15d → A1090 SS |
| 2 | **REPOSICIÓN DE ESTRUCTURAS** | 2024-05-19 → 2024-11-26 (+191d) | 2024-06-02 → 2024-12-31 (+212d) |  |  |  |
| A1150 | DEMOLICIÓN DE ESTRUCTURAS EXISTENTES | 2024-05-19 → 2024-11-26 (+191d) | 2024-06-02 → 2024-11-27 (+178d) | 15d → 2d | 2d → 35d | A1090 FS-15d → A1070 SS, A1100 |
| A1160 | REPOSICIÓN DE PASE DE AGUA TUBO HDPE Ø=18" | 2024-05-19 → 2024-11-28 (+193d) | 2024-06-02 → 2024-11-29 (+180d) | 15d → 2d | 40d → 35d | A1150 FS-15d → A1150 |
| A1170 | REPOSICIÓN DE PASE DE AGUA TUBO HDPE Ø=36" | 2024-05-19 → 2024-11-30 (+195d) | 2024-06-02 → 2024-12-01 (+182d) | 15d → 2d | 40d → 35d | A1160 FS-15d → A1160 |
| A1180 | SUMINISTRO Y MONTAJE DE PANELES DE C°A° 1.6mx1.0mx0.20m EN PASE DE AGUA | 2024-05-19 → 2024-12-02 (+197d) | 2024-06-02 → 2024-12-31 (+212d) | 15d → 30d | 40d → 35d | A1170 FS-15d → A1170 |
| A1190 | SUMINISTRO Y MONTAJE DE PANELES DE C°A° 2.20mx1.0mx0.20m EN PASE DE AGUA | 2024-05-19 → 2024-12-02 (+197d) | 2024-06-02 → 2024-12-31 (+212d) | 15d → 30d | 40d → 35d | A1180 FS-15d → A1180 SS |
| 4 | **CABEZAL DE ENTRADA Y SALIDA** | 2024-05-19 → 2025-01-01 (+227d) | 2024-06-02 → 2025-01-06 (+218d) |  |  |  |
| A1210 | ENCOFRADO Y DESENCOFRADO RECTO | 2024-05-19 → 2025-01-01 (+227d) | 2024-06-02 → 2025-01-03 (+215d) | 15d → 3d | 122d → 35d | A1200 FS-15d → A1190 |
| A1200 | CONCRETOS | 2024-05-19 → 2025-01-04 (+230d) | 2024-06-02 → 2025-01-06 (+218d) | 15d → 3d | 40d → 35d | A1190 FS-15d → A1210 |
| A1220 | DESBROCE Y LIMPIEZA EN ZONA NO BOSCOSA | 2024-05-22 → 2024-11-06 (+168d) | 2024-09-11 → 2025-01-20 (+131d) | 113d → 76d | 0d → 2d | A1100 FS-12d → A1015, A1010, A5250 |
| A5200 | CONFORMACIÓN DE DESVIO EN CAUCE DE RÍO | 2024-05-22 → 2024-11-08 (+170d) | 2024-09-11 → 2025-01-14 (+125d) | 113d → 68d | 58d → 6d | DESCOLMATACIÓN DE CAUCE NATURAL DEL RÍO LACRAMARCA FS-113d → A1015 FS+2d, A5260 |
| A5210 | RELLENO NO ESTRUCTURAL CON MATERIAL PROPIO | 2024-05-22 → 2025-01-15 (+238d) | 2024-09-11 → 2025-04-13 (+214d) | 113d → 89d | 58d → 16d | A5200 FS-113d → A5200 |
| 5 | **DIQUES DE TIERRA COMPACTADA CON ENROCADO** | 2024-05-27 → 2024-11-08 (+165d) | 2024-11-08 → 2025-04-24 (+167d) |  |  |  |
| 1 | **DIQUE DE TIERRA COMPACTADA A3-D-01** | 2024-05-27 → 2024-11-08 (+165d) | 2024-07-02 → 2024-12-07 (+158d) |  |  |  |
| A4210 | EXCAVACIÓN EN TERRENO NATURAL CON EQUIPO | 2024-05-27 → 2024-11-08 (+165d) | 2024-06-05 → 2024-11-16 (+164d) | 10d → 9d | 36d → 0d | A1220 SS+5d → A5250, A5260 |
| A4230 | PERFILADO Y COMPACTACIÓN EN ZONA DE CORTE | 2024-06-02 → 2024-11-09 (+160d) | 2024-06-11 → 2024-11-18 (+160d) |  | 59d → 3d | A4220 FS-7d → A4210 SS+1d |
| A4240 | PREPARACIÓN DE FUNDACIÓN DE CUERPO DE DIQUE | 2024-06-03 → 2024-11-09 (+159d) | 2024-06-12 → 2024-11-13 (+154d) | 10d → 5d | 59d → 3d | A4230 FS-9d → A4230 SS |
| A4220 | EXCAVACIÓN DE UÑA CON EQUIPO | 2024-05-30 → 2024-11-12 (+166d) | 2024-06-08 → 2024-11-17 (+162d) | 10d → 6d | 36d → 2d | A4210 FS-7d → A1230 SS+4d, A5200 SS |
| A4250 | CONFORMACIÓN DE CUERPO DE DIQUE CON MATERIAL PROPIO | 2024-06-05 → 2024-11-17 (+165d) | 2024-06-14 → 2024-11-21 (+160d) | 10d → 5d | 64d → 0d | A4230 FS-7d → A4210, A4240 |
| A4260 | GEOTEXTIL NO TEJIDO 400 G/M2, INC. COLOCACIÓN | 2024-06-13 → 2024-11-19 (+159d) | 2024-06-25 → 2024-11-24 (+152d) | 13d → 6d | 59d → 0d | A4250 FS-7d, A4240 → A4250 SS+2d |
| A4270 | COLOCACION Y ACOMODO DE ROCA EN UÑA DE DIQUE | 2024-06-18 → 2024-11-20 (+155d) | 2024-06-30 → 2024-11-25 (+148d) | 13d → 6d | 59d → 0d | A4260 FS-8d → A4260 SS+1d, A4220 |
| A4280 | COLOCACION Y ACOMODO DE ROCA EN TALUD DE DIQUE | 2024-06-20 → 2024-11-22 (+155d) | 2024-07-02 → 2024-12-05 (+156d) | 13d → 14d | 59d → 0d | A4270 FS-11d → A4270 SS+2d, A4210 |
| A4290 | CONFORMACIÓN DE CORONA DE DIQUE CON MATERIAL PROPIO | 2024-06-07 → 2024-12-06 (+182d) | 2024-06-16 → 2024-12-07 (+174d) | 10d → 2d | 66d → 0d | A4250 FS-8d → A4280 |
| 2 | **DIQUE DE TIERRA COMPACTADA A3-D-02** | 2024-06-09 → 2024-11-26 (+170d) | 2024-10-03 → 2025-04-24 (+203d) |  |  |  |
| A4660 | EXCAVACIÓN EN TERRENO NATURAL CON EQUIPO | 2024-06-09 → 2024-11-26 (+170d) | 2024-08-16 → 2024-12-06 (+112d) | 69d → 11d | 36d → 4d | A5460, A4220 → A5200 SS, A1870 SS, A1060, A4270 |
| A4680 | PERFILADO Y COMPACTACIÓN EN ZONA DE CORTE | 2024-07-04 → 2024-11-27 (+146d) | 2024-08-27 → 2024-12-10 (+105d) | 55d → 14d | 36d → 15d | A4670 FS-53d, A4690 → A4660 SS+1d |
| A4690 | PREPARACIÓN DE FUNDACIÓN DE CUERPO DE DIQUE | 2024-06-09 → 2024-12-03 (+177d) | 2024-06-18 → 2024-12-07 (+172d) | 10d → 5d | 51d → 15d | A4660 SS → A4680 SS+6d |
| A4700 | CONFORMACIÓN DE CUERPO DE DIQUE CON MATERIAL PROPIO | 2024-07-17 → 2024-12-07 (+143d) | 2024-08-30 → 2024-12-13 (+105d) | 45d → 7d | 36d → 8d | A4680 FS-42d, A4290 → A4660 |
| A4670 | EXCAVACIÓN DE UÑA CON EQUIPO | 2024-06-18 → 2024-12-08 (+173d) | 2024-08-25 → 2024-12-17 (+114d) | 69d → 10d | 36d → 0d | A4660 FS-60d → A1060, A1015 SS, A5260, A4280, A4290 |
| A4710 | GEOTEXTIL NO TEJIDO 400 G/M2, INC. COLOCACIÓN | 2024-07-19 → 2024-12-09 (+143d) | 2024-09-13 → 2024-12-14 (+92d) | 57d → 6d | 36d → 8d | A4700 FS-43d → A4700 SS+2d |
| A4720 | COLOCACION Y ACOMODO DE ROCA EN UÑA DE DIQUE | 2024-07-26 → 2024-12-18 (+145d) | 2024-09-23 → 2025-01-08 (+107d) | 60d → 22d | 36d → 0d | A4710 FS-50d, A4280 → A4670 |
| A4730 | COLOCACION Y ACOMODO DE ROCA EN TALUD DE DIQUE | 2024-08-05 → 2024-12-23 (+140d) | 2024-10-03 → 2025-01-10 (+99d) | 60d → 19d | 36d → 0d | A4720 FS-50d → A4720 SS+5d, A4690, A4710 |
| A4740 | CONFORMACIÓN DE CORONA DE DIQUE CON MATERIAL PROPIO | 2024-07-20 → 2025-01-09 (+173d) | 2024-09-02 → 2025-01-10 (+130d) | 45d → 2d | 67d → 109d | A4700 FS-42d → A4730 FF |
| A5450 | EXCAVACIÓN EN TERRENO NATURAL CON EQUIPO | 2024-05-27 → 2025-01-09 (+227d) | 2024-06-05 → 2025-01-19 (+228d) | 10d → 11d | 36d → 9d | A1220 SS+5d → A4720 |
| A5470 | PERFILADO Y COMPACTACIÓN EN ZONA DE CORTE | 2024-06-02 → 2025-01-09 (+221d) | 2024-06-11 → 2025-01-22 (+225d) | 10d → 14d | 134d → 9d | A5460 FS-7d → A5450 SS |
| A5460 | EXCAVACIÓN DE UÑA CON EQUIPO | 2024-05-30 → 2025-01-11 (+226d) | 2024-06-08 → 2025-01-20 (+226d) |  | 36d → 0d | A5450 FS-7d → A4730 |
| A5530 | PREPARACIÓN DE FUNDACIÓN DE CUERPO DE DIQUE | 2024-06-03 → 2025-01-15 (+226d) | 2024-06-12 → 2025-01-16 (+218d) | 10d → 2d | 149d → 9d | A5470 FS-9d → A5470 SS+6d |
| A5480 | CONFORMACIÓN DE CUERPO DE DIQUE CON MATERIAL PROPIO | 2024-06-05 → 2025-01-19 (+228d) | 2024-06-14 → 2025-01-23 (+223d) | 10d → 5d | 134d → 0d | A5470 FS-7d → A5460 SS+8d |
| A5500 | GEOTEXTIL NO TEJIDO 400 G/M2, INC. COLOCACIÓN | 2024-06-08 → 2025-01-21 (+227d) | 2024-06-20 → 2025-01-26 (+220d) | 13d → 6d | 134d → 0d | A5480 FS-7d → A5480 SS+2d |
| A5510 | COLOCACION Y ACOMODO DE ROCA EN UÑA DE DIQUE | 2024-06-13 → 2025-01-21 (+222d) | 2024-06-25 → 2025-02-11 (+231d) | 13d → 22d | 134d → 0d | A5500 FS-8d → A5500 SS, A5460 |
| A5520 | COLOCACION Y ACOMODO DE ROCA EN TALUD DE DIQUE | 2024-06-15 → 2025-01-26 (+225d) | 2024-06-27 → 2025-02-13 (+231d) | 13d → 19d | 134d → 0d | A5510 FS-11d → A5510 SS+5d, A5530 |
| A5360 | EXCAVACIÓN EN TERRENO NATURAL CON EQUIPO | 2024-05-27 → 2025-02-12 (+261d) | 2024-06-18 → 2025-02-22 (+249d) | 23d → 11d | 0d → 9d | A1220 SS+5d → A5510 |
| A5380 | PERFILADO Y COMPACTACIÓN EN ZONA DE CORTE | 2024-06-12 → 2025-02-13 (+246d) | 2024-06-24 → 2025-02-26 (+247d) | 13d → 14d | 127d → 9d | A5370 FS-10d → A5360 SS+1d |
| A5370 | EXCAVACIÓN DE UÑA CON EQUIPO | 2024-05-30 → 2025-02-14 (+260d) | 2024-06-21 → 2025-02-23 (+247d) | 23d → 10d |  | A5360 FS-20d → A5520 |
| A5440 | PREPARACIÓN DE FUNDACIÓN DE CUERPO DE DIQUE | 2024-06-20 → 2025-02-19 (+244d) | 2024-07-04 → 2025-02-20 (+231d) | 15d → 2d | 127d → 9d | A5410 FS-10d → A5380 SS+6d |
| A5390 | CONFORMACIÓN DE CUERPO DE DIQUE CON MATERIAL PROPIO | 2024-06-17 → 2025-02-22 (+250d) | 2024-06-26 → 2025-02-26 (+245d) | 10d → 5d | 127d → 0d | A5380 FS-8d → A5370 SS+8d |
| A5410 | GEOTEXTIL NO TEJIDO 400 G/M2, INC. COLOCACIÓN | 2024-06-18 → 2025-02-24 (+251d) | 2024-06-29 → 2025-03-01 (+245d) | 12d → 6d | 127d → 0d | A5390 FS-9d → A5390 SS+2d |
| A5420 | COLOCACION Y ACOMODO DE ROCA EN UÑA DE DIQUE | 2024-06-08 → 2025-02-25 (+262d) | 2024-06-30 → 2025-03-18 (+261d) | 23d → 22d | 128d → 0d | A5390 FS-19d → A5410 SS+1d, A5370 |
| A5430 | COLOCACION Y ACOMODO DE ROCA EN TALUD DE DIQUE | 2024-06-11 → 2025-03-02 (+264d) | 2024-07-03 → 2025-03-20 (+260d) | 23d → 19d | 128d → 0d | A5420 FS-20d → A5420 SS+5d, A5440 |
| A5270 | EXCAVACIÓN EN TERRENO NATURAL CON EQUIPO | 2024-06-22 → 2025-03-19 (+270d) | 2024-08-08 → 2025-03-29 (+233d) | 48d → 11d | 0d → 9d | A5370 → A5420 |
| A5290 | PERFILADO Y COMPACTACIÓN EN ZONA DE CORTE | 2024-07-04 → 2025-03-20 (+259d) | 2024-08-16 → 2025-04-02 (+229d) | 44d → 14d | 0d → 9d | A5280 FS-40d → A5270 SS+1d |
| A5280 | EXCAVACIÓN DE UÑA CON EQUIPO | 2024-06-26 → 2025-03-21 (+268d) | 2024-08-12 → 2025-03-30 (+230d) | 48d → 10d |  | A5270 FS-44d → A5430 |
| A5350 | PREPARACIÓN DE FUNDACIÓN DE CUERPO DE DIQUE | 2024-07-28 → 2025-03-26 (+241d) | 2024-08-21 → 2025-03-27 (+218d) | 25d → 2d | 79d → 9d | A5290 FS-20d → A5290 SS+6d |
| A5300 | CONFORMACIÓN DE CUERPO DE DIQUE CON MATERIAL PROPIO | 2024-07-10 → 2025-03-29 (+262d) | 2024-08-18 → 2025-04-02 (+227d) | 40d → 5d |  | A5290 FS-38d → A5280 SS+8d |
| A5320 | GEOTEXTIL NO TEJIDO 400 G/M2, INC. COLOCACIÓN | 2024-07-26 → 2025-03-31 (+248d) | 2024-09-10 → 2025-04-05 (+207d) | 47d → 6d |  | A5010 FS-26d → A5300 SS+2d |
| A5330 | COLOCACION Y ACOMODO DE ROCA EN UÑA DE DIQUE | 2024-07-31 → 2025-04-01 (+244d) | 2024-11-05 → 2025-04-22 (+168d) | 98d → 22d |  | A5320 FS-42d → A5320 SS+1d, A5280 |
| A5340 | COLOCACION Y ACOMODO DE ROCA EN TALUD DE DIQUE | 2024-08-03 → 2025-04-06 (+246d) | 2024-11-08 → 2025-04-24 (+167d) | 98d → 19d |  | A5330 FS-95d → A5330 SS+5d, A5350 |

| ID | Task | Start | Finish | Duration | Total float | Predecessors |
| --- | --- | --- | --- | --- | --- | --- |
| 3 | **DIQUE DE TIERRA COMPACTADA A3-I-01** | 2024-05-27 → 2024-11-08 (+165d) | 2024-06-27 → 2024-12-16 (+172d) |  |  |  |
| A1440 | EXCAVACIÓN EN TERRENO NATURAL CON EQUIPO | 2024-06-22 → 2024-11-08 (+139d) | 2024-06-24 → 2024-11-18 (+147d) | 3d → 11d | 137d → 7d | A5270 SS → A1230 SS, A1015 SS |
| A1480 | CONFORMACIÓN DE CORONA DE DIQUE CON MATERIAL PROPIO | 2024-06-07 → 2024-12-12 (+188d) | 2024-06-16 → 2024-12-16 (+183d) | 10d → 5d | 145d → 5d | A5480 FS-8d → A1510 FF+2d |
| 4 | **DIQUE DE TIERRA COMPACTADA A3-I-02** | 2024-05-27 → 2024-12-17 (+204d) | 2024-07-04 → 2025-01-16 (+196d) |  |  |  |
| A4390 | EXCAVACIÓN EN TERRENO NATURAL CON EQUIPO | 2024-08-21 → 2024-12-17 (+118d) | 2024-09-10 → 2024-12-31 (+112d) | 21d → 15d | 40d → 5d | A3560 FS-21d → A1520, A1510, A1480 |
| A4430 | CONFORMACIÓN DE CORONA DE DIQUE CON MATERIAL PROPIO | 2024-06-19 → 2025-01-10 (+205d) | 2024-06-28 → 2025-01-15 (+201d) | 10d → 6d | 133d → 26d | A5390 FS-8d → A4460 FF+1d |
| 5 | **DIQUE DE TIERRA COMPACTADA A3-I-03** | 2024-06-22 → 2025-01-15 (+207d) | 2024-11-08 → 2025-04-20 (+163d) |  |  |  |
| A4930 | EXCAVACIÓN EN TERRENO NATURAL CON EQUIPO | 2024-09-11 → 2025-01-15 (+126d) | 2024-09-29 → 2025-01-23 (+116d) | 19d → 9d | 40d → 9d | A3650 FS-19d → A4460 |
| A5010 | CONFORMACIÓN DE CORONA DE DIQUE CON MATERIAL PROPIO | 2024-07-12 → 2025-02-15 (+218d) | 2024-08-20 → 2025-02-16 (+180d) | 40d → 2d | 0d → 72d | A5300 FS-38d → A5000 FF |
| 6 | **RAMPAS** | 2024-06-22 → 2025-01-27 (+219d) | 2024-06-24 → 2025-04-12 (+292d) |  |  |  |
| A1750 | CONFORMACIÓN DE CUERPO DE RAMPA CON MATERIAL PROPIO | 2024-06-22 → 2025-02-05 (+228d) | 2024-06-24 → 2025-02-13 (+234d) | 3d → 9d | 137d → 55d | A1440 FS-3d → A1740 |
| A1760 | CONFORMACIÓN DE CORONACIÓN DE RAMPA | 2024-06-22 → 2025-02-05 (+228d) | 2024-06-24 → 2025-02-13 (+234d) | 3d → 9d | 137d → 55d | A1750 FS-3d → A1750 SS |
| 2 | **OBRAS DE ARTE** | 2024-06-03 → 2024-11-08 (+158d) | 2024-09-29 → 2025-04-25 (+208d) |  |  |  |
| 1 | **CAPTACIÓN A3-CP-23-95** | 2024-06-03 → 2024-11-26 (+176d) | 2024-07-15 → 2025-04-12 (+271d) |  |  |  |
| 1 | **MOVIMIENTO DE TIERRAS** | 2024-06-03 → 2024-11-26 (+176d) | 2024-07-09 → 2025-01-12 (+187d) |  |  |  |
| A2770 | EXCAVACIÓN ESTRUCTURAL PARA OBRAS DE ARTE | 2024-06-03 → 2024-11-26 (+176d) | 2024-07-09 → 2024-12-01 (+145d) | 37d → 6d | 116d → 4d | A1200 → A4660 SS |
| A2780 | RELLENO ESTRUCTURAL PARA OBRAS DE ARTE, CON MATERIAL PROPIO | 2024-06-03 → 2025-01-07 (+218d) | 2024-07-09 → 2025-01-12 (+187d) | 37d → 6d | 116d → 29d | A2770 FS-37d → A2800, A5220 |
| 2 | **OBRAS DE CONCRETO** | 2024-06-05 → 2024-12-02 (+180d) | 2024-07-15 → 2025-01-06 (+175d) |  |  |  |
| A2790 | CONCRETO f'c=100 kg/cm2 | 2024-06-05 → 2024-12-02 (+180d) | 2024-07-11 → 2024-12-04 (+146d) | 37d → 3d | 116d → 14d | A2780 FS-35d → A2770 |
| A2810 | CONCRETO CICLÓPEO f'c=280 kg/cm2 + 30% P.G. | 2024-06-09 → 2024-12-05 (+179d) | 2024-07-15 → 2024-12-07 (+145d) | 37d → 3d | 116d → 14d | A2800 FS-35d → A2790 |
| A2800 | CONCRETO f'c=280 kg/cm2 | 2024-06-07 → 2024-12-08 (+184d) | 2024-07-13 → 2024-12-19 (+159d) | 37d → 12d | 116d → 19d | A2790 FS-35d → A2820 SS |
| A2820 | ENCOFRADO Y DESENCOFRADO RECTO | 2024-06-09 → 2024-12-08 (+182d) | 2024-07-15 → 2024-12-20 (+158d) | 37d → 13d | 116d → 18d | A2810 FS-37d, A1210 → A2830 FF |
| A2830 | ACERO DE REFUERZO fy=4200 kg/cm2 | 2024-06-09 → 2024-12-08 (+182d) | 2024-07-15 → 2024-12-20 (+158d) | 37d → 13d | 116d → 14d | A2820 FS-37d → A2810 |
| 3 | **ESTRUCTURAS METALICAS** | 2024-06-03 → 2025-01-01 (+212d) | 2024-07-09 → 2025-01-15 (+190d) |  |  |  |
| A2840 | COMPUERTA METALICA PLANA DESLIZANTE DE 1.0x1.0m | 2024-06-03 → 2025-01-01 (+212d) | 2024-07-09 → 2025-01-03 (+178d) | 37d → 3d | 122d → 19d | A1200 → A5750 |
| A2850 | REJILLA DE 1.00x1.00m CON VARILLA DE 1/2" CADA 6,25cm | 2024-06-03 → 2025-01-04 (+215d) | 2024-07-09 → 2025-01-06 (+181d) | 37d → 3d | 122d → 19d | A2840 FS-37d → A2840 |
| A2860 | BARANDA DE FIERRO GALVANIZADO 1 1/2" | 2024-06-03 → 2025-01-07 (+218d) | 2024-07-09 → 2025-01-09 (+184d) | 37d → 3d | 122d → 19d | A2850 FS-37d → A2850 |
| A2870 | ESCALERA TIPO GATO | 2024-06-03 → 2025-01-10 (+221d) | 2024-07-09 → 2025-01-12 (+187d) | 37d → 3d | 122d → 19d | A2860 FS-37d → A2860 |
| A2880 | TAPA METALICA CIRCULAR DN600 MM | 2024-06-03 → 2025-01-13 (+224d) | 2024-07-09 → 2025-01-15 (+190d) | 37d → 3d | 122d → 19d | A2870 FS-37d → A2870 |
| 4 | **TUBERIAS** | 2024-06-03 → 2024-12-02 (+182d) | 2024-07-09 → 2025-01-24 (+199d) |  |  |  |
| A2890 | EXCAVACIÓN ESTRUCTURAL PARA OBRAS DE ARTE (Buzones) | 2024-06-03 → 2024-12-02 (+182d) | 2024-07-09 → 2024-12-04 (+148d) | 37d → 3d | 122d → 4d | A1200 → A2770 |
| A2900 | EXCAVACIÓN DE ZANJA | 2024-06-03 → 2024-12-05 (+185d) | 2024-07-09 → 2024-12-29 (+173d) | 37d → 25d | 122d → 4d | A2890 FS-37d → A2890 |
| A2920 | CAMA DE ARENA | 2024-06-03 → 2024-12-05 (+185d) | 2024-07-09 → 2024-12-29 (+173d) | 37d → 25d | 122d → 25d | A2910 FS-37d → A2900 SS |
| A2940 | CONCRETO f'c=100 kg/cm2 (Buzones) | 2024-06-03 → 2024-12-05 (+185d) | 2024-07-09 → 2024-12-07 (+151d) | 37d → 3d | 122d → 27d | A2930 FS-37d → A2900 SS, A2790 |
| A2990 | SUMINISTRO E INSTALACIÓN DE TUBERÍA GRP DN600 mm SN2500 | 2024-06-03 → 2024-12-05 (+185d) | 2024-07-09 → 2024-12-29 (+173d) | 37d → 25d | 122d → 25d | A2980 FS-37d → A2920 SS |
| A2980 | ACERO DE REFUERZO fy=4200 kg/cm2 (Buzones) | 2024-06-03 → 2024-12-21 (+201d) | 2024-07-09 → 2024-12-24 (+168d) | 37d → 4d | 122d → 14d | A2970 FS-37d → A2940, A2830 |
| A2960 | ENCOFRADO Y DESENCOFRADO RECTO | 2024-06-03 → 2024-12-25 (+205d) | 2024-07-09 → 2024-12-29 (+173d) | 37d → 5d | 122d → 14d | A2950 FS-37d → A2820, A2980 |
| A2970 | ENCOFRADO Y DESENCOFRADO CURVO | 2024-06-03 → 2024-12-25 (+205d) | 2024-07-09 → 2024-12-29 (+173d) | 37d → 5d | 122d → 14d | A2960 FS-37d → A2960 SS |
| A2930 | RELLENO COMÚN PARA ZANJAS | 2024-06-03 → 2024-12-30 (+210d) | 2024-07-09 → 2025-01-24 (+199d) | 37d → 26d | 122d → 25d | A2920 FS-37d → A2990 |
| A2950 | CONCRETO f'c=280 kg/cm2 (Buzones) | 2024-06-03 → 2024-12-30 (+210d) | 2024-07-09 → 2025-01-01 (+176d) | 37d → 3d | 122d → 23d | A2940 FS-37d → A2970, A2800 |
| A2910 | RELLENO ESTRUCTURAL PARA OBRAS DE ARTE CON MATERIAL PROPIO (Buzones) | 2024-06-03 → 2025-01-14 (+225d) | 2024-07-09 → 2025-01-21 (+196d) | 37d → 8d | 122d → 28d | A2900 FS-37d → A2950 FS+12d, A2780, A1200, A3160 |
| 5 | **CANAL** | 2024-06-03 → 2024-12-30 (+210d) | 2024-07-09 → 2025-03-18 (+252d) |  |  |  |
| A3000 | EXCAVACIÓN ESTRUCTURAL PARA OBRAS DE ARTE | 2024-06-03 → 2024-12-30 (+210d) | 2024-07-09 → 2025-01-04 (+179d) | 37d → 6d | 122d → 4d | A2890 FS-37d → A2900 |
| A3020 | COLOCACIÓN DE CONCRETO f'c=100 kg/cm2 | 2024-06-03 → 2025-01-05 (+216d) | 2024-07-09 → 2025-01-08 (+183d) | 37d → 4d | 122d → 4d | A3010 FS-37d → A2940, A3000 |
| A3040 | ENCOFRADO Y DESENCOFRADO RECTO | 2024-06-03 → 2025-01-09 (+220d) | 2024-07-09 → 2025-03-01 (+235d) | 37d → 52d | 122d → 4d | A3030 FS-37d → A2970, A3050 SS |
| A3050 | ACERO DE REFUERZO fy=4200 kg/cm2 | 2024-06-03 → 2025-01-09 (+220d) | 2024-07-09 → 2025-02-05 (+211d) | 37d → 28d | 122d → 4d | A3040 FS-37d → A2980, A3020 |
| A3030 | COLOCACIÓN DE CONCRETO f'c=280 kg/cm2 | 2024-06-03 → 2025-01-11 (+222d) | 2024-07-09 → 2025-03-04 (+238d) | 37d → 53d | 122d → 11d | A3020 FS-37d → A2950 SS, A3040 SS+2d |
| A3060 | JUNTA WATER STOP SIN BULBO 150 mm | 2024-06-03 → 2025-01-11 (+222d) | 2024-07-09 → 2025-03-18 (+252d) | 37d → 67d | 122d → 20d | A3050 FS-37d → A3030 SS |
| A3010 | RELLENO ESTRUCTURAL PARA CANALES, CON MATERIAL PROPIO | 2024-06-03 → 2025-01-25 (+236d) | 2024-07-09 → 2025-03-08 (+242d) | 37d → 43d | 122d → 25d | A3000 FS-37d → A2910, A2930 |
| 6 | **OBRAS DE DESCARGA** | 2024-06-03 → 2025-01-05 (+216d) | 2024-07-09 → 2025-04-12 (+277d) |  |  |  |
| A3070 | EXCAVACIÓN ESTRUCTURAL PARA OBRAS DE ARTE | 2024-06-03 → 2025-01-05 (+216d) | 2024-07-09 → 2025-01-14 (+189d) | 37d → 10d | 40d → 30d | A1200 → A3000 |
| A3090 | CONCRETO f'c=100 kg/cm2 | 2024-06-03 → 2025-01-15 (+226d) | 2024-07-09 → 2025-01-24 (+199d) | 37d → 10d | 122d → 30d | A3080 FS-37d → A3070, A3020 |
| A3120 | ACERO DE REFUERZO fy=4200 kg/cm2 | 2024-06-03 → 2025-02-06 (+248d) | 2024-07-09 → 2025-02-15 (+221d) | 37d → 10d | 122d → 18d | A3110 FS-37d → A3090, A3050 |
| A3110 | ENCOFRADO Y DESENCOFRADO RECTO | 2024-06-03 → 2025-03-02 (+272d) | 2024-07-09 → 2025-03-11 (+245d) | 37d → 10d | 122d → 4d | A3100 FS-37d → A3120, A3040 |
| A3100 | CONCRETO f'c=280 kg/cm2 | 2024-06-03 → 2025-03-12 (+282d) | 2024-07-09 → 2025-03-21 (+255d) | 37d → 10d | 122d → 4d | A3090 FS-37d → A3110, A3030 |
| A3130 | JUNTA WATER STOP SIN BULBO 150 mm | 2024-06-03 → 2025-03-22 (+292d) | 2024-07-09 → 2025-04-02 (+267d) | 37d → 12d | 122d → 17d | A3120 FS-37d → A3100, A3060 |
| A3080 | RELLENO ESTRUCTURAL PARA OBRAS DE ARTE CON MATERIAL PROPIO | 2024-06-03 → 2025-03-30 (+300d) | 2024-07-09 → 2025-04-08 (+273d) | 37d → 10d | 40d → 4d | A3070 FS-37d → A3100 FS+8d, A3010 |
| A3140 | COMPUERTA METALICA PLANA DESLIZANTE | 2024-06-03 → 2025-04-03 (+304d) | 2024-07-09 → 2025-04-12 (+277d) | 37d → 10d | 122d → 17d | A3130 FS-37d → A3100 FS+12d, A3130 |
| 2 | **CAPTACIÓN A3-CP-21-05** | 2024-07-10 → 2024-11-08 (+121d) | 2024-08-01 → 2025-03-15 (+226d) |  |  |  |
| 1 | **MOVIMIENTO DE TIERRAS** | 2024-07-10 → 2024-11-08 (+121d) | 2024-08-01 → 2025-01-05 (+157d) |  |  |  |
| A3150 | EXCAVACIÓN ESTRUCTURAL PARA OBRAS DE ARTE | 2024-07-10 → 2024-11-08 (+121d) | 2024-08-01 → 2024-11-11 (+102d) | 23d → 4d | 40d → 10d | A3080 → A1070 SS+7d, A1015 SS, A1440 SS |
| A3160 | RELLENO ESTRUCTURAL PARA OBRAS DE ARTE, CON MATERIAL PROPIO | 2024-07-10 → 2024-12-14 (+157d) | 2024-08-01 → 2025-01-05 (+157d) |  | 99d → 36d | A3150 FS-23d → A3180 |
| 2 | **OBRAS DE CONCRETO** | 2024-07-10 → 2024-11-12 (+125d) | 2024-08-01 → 2024-12-25 (+146d) |  |  |  |
| A3170 | CONCRETO f'c=100 kg/cm2 | 2024-07-10 → 2024-11-12 (+125d) | 2024-08-01 → 2024-11-14 (+105d) | 23d → 3d | 40d → 10d | A3150 FS-23d → A3150 |
| A3190 | CONCRETO CICLÓPEO f'c=280 kg/cm2 + 30% P.G. | 2024-07-10 → 2024-11-15 (+128d) | 2024-08-01 → 2024-11-17 (+108d) | 23d → 3d | 40d → 10d | A3180 FS-23d → A3170 |
| A3180 | CONCRETO f'c=280 kg/cm2 | 2024-07-10 → 2024-11-18 (+131d) | 2024-08-01 → 2024-12-13 (+134d) | 23d → 26d | 40d → 10d | A3170 FS-23d → A3200 SS |
| A3200 | ENCOFRADO Y DESENCOFRADO RECTO | 2024-07-10 → 2024-11-18 (+131d) | 2024-08-01 → 2024-12-09 (+130d) | 23d → 22d | 99d → 10d | A3190 FS-23d → A3210 SS |
| A3210 | ACERO DE REFUERZO fy=4200 kg/cm2 | 2024-07-10 → 2024-11-18 (+131d) | 2024-08-01 → 2024-12-08 (+129d) | 23d → 21d | 99d → 10d | A3200 FS-23d → A3190 |
| 3 | **ESTRUCTURAS METALICAS** | 2024-07-10 → 2024-12-26 (+169d) | 2024-08-01 → 2025-02-13 (+196d) |  |  |  |
| A3220 | COMPUERTA METALICA PLANA DESLIZANTE DE 1.0x1.0m | 2024-07-10 → 2024-12-26 (+169d) | 2024-08-01 → 2025-01-04 (+156d) | 23d → 10d | 40d → 10d | A3190 FS-23d → A3180, A5230 |

| ID | Task | Start | Finish | Duration | Total float | Predecessors |
| --- | --- | --- | --- | --- | --- | --- |
| A3230 | REJILLA DE 1.00x1.00m CON VARILLA DE 1/2 CADA 6,25cm | 2024-07-10 → 2025-01-05 (+179d) | 2024-08-01 → 2025-01-14 (+166d) | 23d → 10d | 40d → 10d | A3220 FS-23d → A3220 |
| A3240 | BARANDA DE FIERRO GALVANIZADO 1 1/2" | 2024-07-10 → 2025-01-15 (+189d) | 2024-08-01 → 2025-01-24 (+176d) | 23d → 10d | 40d → 10d | A3230 FS-23d → A3230 |
| A3250 | ESCALERA TIPO GATO | 2024-07-10 → 2025-01-25 (+199d) | 2024-08-01 → 2025-02-03 (+186d) | 23d → 10d | 40d → 10d | A3240 FS-23d → A3240 |
| A3260 | TAPA METALICA CIRCULAR DN600 MM | 2024-07-10 → 2025-02-04 (+209d) | 2024-08-01 → 2025-02-13 (+196d) | 23d → 10d | 40d → 10d | A3250 FS-23d → A3250 |
| 4 | **TUBERIA** | 2024-07-10 → 2024-11-12 (+125d) | 2024-08-01 → 2025-01-12 (+164d) |  |  |  |
| A3270 | EXCAVACIÓN ESTRUCTURAL PARA OBRAS DE ARTE (Buzones) | 2024-07-10 → 2024-11-12 (+125d) | 2024-08-01 → 2024-11-17 (+108d) | 23d → 6d | 40d → 33d | A3260 FS-23d → A3150 |
| A3280 | EXCAVACIÓN DE ZANJA | 2024-07-10 → 2024-11-18 (+131d) | 2024-08-01 → 2024-11-23 (+114d) | 23d → 6d | 99d → 113d | A3270 FS-23d → A3270 |
| A3330 | CONCRETO f'c=100 kg/cm2 (Buzones) | 2024-07-10 → 2024-11-18 (+131d) | 2024-08-01 → 2024-11-23 (+114d) | 23d → 6d | 99d → 33d | A3320 FS-23d → A3270, A3170 |
| A3300 | CAMA DE ARENA | 2024-07-10 → 2024-11-24 (+137d) | 2024-08-01 → 2024-11-29 (+120d) | 23d → 6d | 99d → 113d | A3290 FS-23d → A3280 |
| A3380 | SUMINISTRO E INSTALACIÓN DE TUBERÍA GRP DN600 mm SN2500 | 2024-07-10 → 2024-11-30 (+143d) | 2024-08-01 → 2024-12-04 (+125d) | 23d → 5d | 99d → 113d | A3370 FS-23d → A3300 |
| A3310 | RELLENO SELECCIONADO PARA ZANJAS CON MATERIAL PROPIO | 2024-07-10 → 2024-12-05 (+148d) | 2024-08-01 → 2024-12-10 (+131d) | 23d → 6d | 99d → 113d | A3300 FS-23d → A3320 SS |
| A3320 | RELLENO COMÚN PARA ZANJAS | 2024-07-10 → 2024-12-05 (+148d) | 2024-08-01 → 2024-12-10 (+131d) | 23d → 6d | 99d → 113d | A3310 FS-23d → A3380 |
| A3370 | ACERO DE REFUERZO fy=4200 kg/cm2 | 2024-07-10 → 2024-12-09 (+152d) | 2024-08-01 → 2024-12-13 (+134d) | 23d → 5d | 99d → 32d | A3360 FS-23d → A3330, A3210 |
| A3350 | ENCOFRADO Y DESENCOFRADO RECTO | 2024-07-10 → 2024-12-14 (+157d) | 2024-08-01 → 2024-12-18 (+139d) | 23d → 5d | 99d → 32d | A3340 FS-23d → A3370, A3200 |
| A3360 | ENCOFRADO Y DESENCOFRADO CURVO | 2024-07-10 → 2024-12-14 (+157d) | 2024-08-01 → 2024-12-18 (+139d) | 23d → 5d | 99d → 32d | A3350 FS-23d → A3350 SS |
| A3340 | CONCRETO f'c=280 kg/cm2 (Buzones) | 2024-07-10 → 2024-12-19 (+162d) | 2024-08-01 → 2024-12-24 (+145d) | 23d → 6d | 99d → 63d | A3330 FS-23d → A3360, A3180 |
| A3290 | RELLENO ESTRUCTURAL PARA OBRAS DE ARTE CON MATERIAL PROPIO | 2024-07-10 → 2025-01-06 (+180d) | 2024-08-01 → 2025-01-12 (+164d) | 23d → 7d | 99d → 80d | A3280 FS-23d → A3340, A5240 |
| 5 | **CANALES** | 2024-07-10 → 2024-11-18 (+131d) | 2024-08-01 → 2025-03-15 (+226d) |  |  |  |
| A3390 | EXCAVACIÓN ESTRUCTURAL PARA OBRAS DE ARTE | 2024-07-10 → 2024-11-18 (+131d) | 2024-08-01 → 2024-11-22 (+113d) | 23d → 5d | 40d → 34d | A3270 FS-23d → A3270 |
| A3410 | COLOCACIÓN DE CONCRETO f'c=100 kg/cm2 | 2024-07-10 → 2024-11-24 (+137d) | 2024-08-01 → 2024-12-17 (+138d) | 23d → 24d | 40d → 33d | A3400 FS-23d → A3390, A3330 |
| A3440 | ACERO DE REFUERZO fy=4200 kg/cm2 | 2024-07-10 → 2024-12-18 (+161d) | 2024-08-01 → 2024-12-29 (+150d) | 23d → 12d | 40d → 33d | A3430 FS-23d → A3410, A3370 |
| A3430 | ENCOFRADO Y DESENCOFRADO | 2024-07-10 → 2024-12-19 (+162d) | 2024-08-01 → 2025-01-24 (+176d) | 23d → 37d | 40d → 32d | A3420 FS-23d → A3440 SS, A3360 |
| A3420 | COLOCACIÓN DE CONCRETO f'c=280 kg/cm2 | 2024-07-10 → 2025-01-25 (+199d) | 2024-08-01 → 2025-02-17 (+200d) | 23d → 24d | 40d → 32d | A3410 FS-23d → A3430, A3340 |
| A3450 | JUNTA WATER STOP SIN BULBO 150 mm | 2024-07-10 → 2025-01-25 (+199d) | 2024-08-01 → 2025-01-29 (+181d) | 23d → 5d | 40d → 90d | A3440 FS-23d → A3420 SS |
| A3400 | RELLENO ESTRUCTURAL PARA CANALES, CON MATERIAL PROPIO | 2024-07-10 → 2025-03-02 (+235d) | 2024-08-01 → 2025-03-15 (+226d) | 23d → 14d | 40d → 32d | A3390 FS-23d → A3420 FS+12d, A3290, A3310 |
| 3 | **RETORNO A3-OA-RE-D-21-55** | 2024-08-02 → 2024-11-17 (+107d) | 2024-08-20 → 2025-02-03 (+167d) |  |  |  |
| 1 | **MOVIMIENTO DE TIERRAS** | 2024-08-02 → 2024-11-17 (+107d) | 2024-08-20 → 2025-01-30 (+163d) |  |  |  |
| A3460 | EXCAVACIÓN ESTRUCTURAL PARA OBRAS DE ARTE | 2024-08-02 → 2024-11-17 (+107d) | 2024-08-20 → 2024-11-19 (+91d) | 19d → 3d | 40d → 7d | A3420, A3450 → A1070 SS+4d, A1015 SS, A4210 |
| A3470 | RELLENO ESTRUCTURAL PARA OBRAS DE ARTE, CON MATERIAL PROPIO | 2024-08-02 → 2025-01-28 (+179d) | 2024-08-20 → 2025-01-30 (+163d) | 19d → 3d | 40d → 11d | A3460 FS-19d → A3490 FS+12d |
| 2 | **OBRAS DE CONCRETO** | 2024-08-02 → 2024-11-20 (+110d) | 2024-08-20 → 2025-01-15 (+148d) |  |  |  |
| A3480 | CONCRETO f'c=100 kg/cm2 | 2024-08-02 → 2024-11-20 (+110d) | 2024-08-20 → 2024-12-06 (+108d) | 19d → 17d | 40d → 7d | A3460 FS-19d → A3460 |
| A3500 | CONCRETO CICLÓPEO f'c=280 kg/cm2 + 30% P.G. | 2024-08-02 → 2024-12-07 (+127d) | 2024-08-20 → 2024-12-21 (+123d) | 19d → 15d | 40d → 7d | A3490 FS-19d → A3480 |
| A3510 | ENCOFRADO Y DESENCOFRADO | 2024-08-02 → 2024-12-07 (+127d) | 2024-08-20 → 2024-12-31 (+133d) | 19d → 25d | 40d → 7d | A3500 FS-19d → A3520 SS |
| A3520 | ACERO DE REFUERZO fy=4200 kg/cm2 | 2024-08-02 → 2024-12-07 (+127d) | 2024-08-20 → 2024-12-30 (+132d) | 19d → 24d | 40d → 7d | A3510 FS-19d → A3500 SS |
| A3490 | CONCRETO f'c=280 kg/cm2 | 2024-08-02 → 2025-01-01 (+152d) | 2024-08-20 → 2025-01-15 (+148d) | 19d → 15d | 40d → 7d | A3480 FS-19d → A3510 |
| A3530 | JUNTA WATER STOP SIN BULBO 150 mm | 2024-08-02 → 2025-01-01 (+152d) | 2024-08-20 → 2025-01-15 (+148d) | 19d → 15d | 40d → 26d | A3520 FS-19d → A3490 SS |
| 3 | **ESTRUCTURAS METALICAS** | 2024-08-02 → 2025-01-28 (+179d) | 2024-08-20 → 2025-02-03 (+167d) |  |  |  |
| A3540 | COMPUERTA METALICA PLANA DESLIZANTE DE 1.0x1.6 m | 2024-08-02 → 2025-01-28 (+179d) | 2024-08-20 → 2025-01-31 (+164d) | 19d → 4d | 40d → 7d | A3490 FS-19d → A3490 FS+12d, A2880 |
| A3550 | BARANDA DE FIERRO GALVANIZADO 1 1/2" | 2024-08-02 → 2025-02-01 (+183d) | 2024-08-20 → 2025-02-03 (+167d) | 19d → 3d | 40d → 7d | A3540 FS-19d → A3540 |
| 4 | **REPOSICIÓN DE CANALES** | 2024-08-21 → 2024-11-19 (+90d) | 2024-09-29 → 2025-04-25 (+208d) |  |  |  |
| 1 | **REPOSICIÓN DE CANAL 1** | 2024-08-21 → 2025-01-01 (+133d) | 2024-09-10 → 2025-04-23 (+225d) |  |  |  |
| 1 | **MOVIMIENTO DE TIERRAS** | 2024-08-21 → 2025-01-01 (+133d) | 2024-09-10 → 2025-02-11 (+154d) |  |  |  |
| A3560 | DEMOLICIÓN DE ESTRUCTURAS EXISTENTES | 2024-08-21 → 2025-01-01 (+133d) | 2024-09-10 → 2025-01-17 (+129d) | 21d → 17d | 40d → 35d | A3490, A3550, A3530, A3470 → A4390 |
| A3580 | RELLENO ESTRUCTURAL PARA OBRAS DE ARTE CON MATERIAL PROPIO | 2024-08-21 → 2025-01-10 (+142d) | 2024-09-10 → 2025-02-04 (+147d) | 21d → 26d | 40d → 6d | A4390 FS-21d → A4660 SS+45d |
| 2 | **OBRAS DE CONCRETO** | 2024-08-21 → 2025-01-31 (+163d) | 2024-09-10 → 2025-04-23 (+225d) |  |  |  |
| A3600 | ACERO DE REFUERZO fy=4200 kg/cm2 | 2024-08-21 → 2025-01-31 (+163d) | 2024-09-10 → 2025-03-22 (+193d) | 21d → 51d | 40d → 11d | A3690 FS-21d → A3610 SS |
| A3610 | CONCRETO f'c=100 kg/cm2 | 2024-08-21 → 2025-01-31 (+163d) | 2024-09-10 → 2025-03-07 (+178d) | 21d → 36d | 40d → 11d | A3600 FS-21d → A3570 SS, A3470 |
| A3620 | CONCRETO f'c=280 kg/cm2 | 2024-08-21 → 2025-02-05 (+168d) | 2024-09-10 → 2025-03-30 (+201d) | 21d → 54d | 40d → 6d | A3610 FS-21d → A3590 SS, A3580 |
| A3630 | JUNTA WATER STOP 6" | 2024-08-21 → 2025-02-14 (+177d) | 2024-09-10 → 2025-03-30 (+201d) | 21d → 45d | 40d → 10d | A3620 FS-21d → A3620 SS, A3260 |
| A3640 | MAMPOSTERIA DE PIEDRA, e=20cm, ACABADO CARA VISTA | 2024-08-21 → 2025-04-03 (+225d) | 2024-09-10 → 2025-04-08 (+210d) | 21d → 6d | 40d → 18d | A3630 FS-21d → A3620, A3130 |
| 2 | **REPOSICIÓN DE CANAL 3** | 2024-09-11 → 2024-11-19 (+69d) | 2024-09-29 → 2025-04-25 (+208d) |  |  |  |
| 1 | **MOVIMIENTO DE TIERRAS** | 2024-09-11 → 2024-11-19 (+69d) | 2024-09-29 → 2025-04-01 (+184d) |  |  |  |
| A3650 | DEMOLICIÓN DE ESTRUCTURAS EXISTENTES | 2024-09-11 → 2024-11-19 (+69d) | 2024-09-29 → 2024-11-30 (+62d) | 19d → 12d | 40d → 105d | A3610, A3580, A3640 → A1440 |
| A3670 | RELLENO ESTRUCTURAL PARA OBRAS DE ARTE CON MATERIAL PROPIO | 2024-09-11 → 2025-03-30 (+200d) | 2024-09-29 → 2025-04-01 (+184d) | 19d → 3d | 40d → 4d | A4930 FS-19d → A3660, A3080 SS, A3400 SS |
| 2 | **OBRAS DE CONCRETO** | 2024-09-11 → 2025-04-02 (+203d) | 2024-09-29 → 2025-04-25 (+208d) |  |  |  |
| A3710 | CONCRETO f'c=100 kg/cm2 | 2024-09-11 → 2025-04-02 (+203d) | 2024-09-29 → 2025-04-05 (+188d) | 19d → 4d | 40d → 4d | A3700 FS-19d → A3670, A3580 |
| A3680 | ENCOFRADO Y DESENCOFRADO PARA REVESTIMIENTO DE CANALES (CERCHAS) | 2024-09-11 → 2025-04-06 (+207d) | 2024-09-29 → 2025-04-17 (+200d) | 19d → 12d | 40d → 4d | A4930 FS-19d → A3700 SS, A3630, A1760 |
| A3690 | ENCOFRADO Y DESENCOFRADO RECTO | 2024-08-21 → 2025-04-06 (+228d) | 2024-09-10 → 2025-04-17 (+219d) | 21d → 12d | 40d → 4d | A4390 FS-21d → A3680 SS |
| A3700 | MALLA ELECTROSOLDADA DE DN6mm EN CUADRICULA 15x15 cm | 2024-09-11 → 2025-04-06 (+207d) | 2024-09-29 → 2025-04-18 (+201d) | 19d → 13d | 40d → 4d | A3830 FS-19d → A3710 |
| A3730 | SELLO DE JUNTA CONSTRUCCIÓN CON MATERIAL ELASTOMÉRICO | 2024-09-11 → 2025-04-06 (+207d) | 2024-09-29 → 2025-04-13 (+196d) | 19d → 8d | 40d → 16d | A3720 FS-19d → A3680 SS |
| A3720 | CONCRETO f'c=280 kg/cm2 | 2024-09-11 → 2025-04-18 (+219d) | 2024-09-29 → 2025-04-22 (+205d) | 19d → 5d | 40d → 4d | A3710 FS-19d → A3690 |
| A3740 | MAMPOSTERIA DE PIEDRA, e=20cm, ACABADO CARA VISTA | 2024-09-11 → 2025-04-23 (+224d) | 2024-09-29 → 2025-04-25 (+208d) | 19d → 3d | 40d → 4d | A3730 FS-19d → A3720, A3640 |
| 5 | **REPOSICIÓN SIFON INOPERATIVO** | 2024-07-11 → 2024-12-10 (+152d) | 2024-08-08 → 2025-02-25 (+201d) |  |  |  |
| A3750 | DEMOLICIÓN DE ESTRUCTURAS EXISTENTES | 2024-07-27 → 2024-12-10 (+136d) | 2024-08-08 → 2024-12-13 (+127d) | 13d → 4d | 92d → 48d | A4700 SS+10d → A1230, A1880 FF |
| A3760 | EXCAVACIÓN ESTRUCTURAL PARA OBRAS DE ARTE | 2024-07-27 → 2024-12-14 (+140d) | 2024-08-08 → 2024-12-24 (+138d) | 13d → 11d | 92d → 48d | A3750 FS-13d → A3750 |
| A3770 | COLOCACIÓN CAMA DE ARENA | 2024-07-27 → 2024-12-25 (+151d) | 2024-08-08 → 2024-12-29 (+143d) | 13d → 5d | 92d → 104d | A3760 FS-13d → A3760 |
| A3810 | CONCRETO f'c=100 kg/cm2 | 2024-07-19 → 2024-12-25 (+159d) | 2024-07-31 → 2025-01-09 (+162d) | 13d → 16d | 100d → 63d | A3800 FS-15d → A3760 |
| A3800 | TUBERÍAS DE 14" HDPE SDR21 DN 355mm | 2024-07-21 → 2024-12-30 (+162d) | 2024-08-02 → 2025-01-05 (+156d) | 13d → 7d | 98d → 104d | A3790 FS-15d → A3770 |
| A3850 | CODOS HDPE DE 14" DN 355mm | 2024-07-11 → 2024-12-30 (+172d) | 2024-07-23 → 2025-01-05 (+166d) | 13d → 7d | 108d → 114d | A3840 FS-15d → A3800 SS |
| A3790 | RELLENO COMÚN | 2024-07-23 → 2025-01-06 (+167d) | 2024-08-04 → 2025-01-15 (+164d) | 13d → 10d | 96d → 104d | A3780 FS-15d → A3800 |

| ID | Task | Start | Finish | Duration | Total float | Predecessors |
| --- | --- | --- | --- | --- | --- | --- |
| A3840 | ACERO DE REFUERZO fy=4200 kg/cm2 | 2024-07-13 → 2025-01-10 (+181d) | 2024-07-25 → 2025-01-22 (+181d) |  | 106d → 63d | ENCOFRADO Y DESENCOFRADO RECTO FS-15d → A3810 |
| A3830 | ENCOFRADO Y DESENCOFRADO RECTO | 2024-09-11 → 2025-01-23 (+134d) | 2024-09-29 → 2025-02-04 (+128d) | 19d → 13d | 40d → 63d | A3680 FS-19d → A3840 |
| A3820 | CONCRETO f'c=280 kg/cm2 | 2024-07-17 → 2025-02-05 (+203d) | 2024-07-29 → 2025-02-20 (+206d) | 13d → 16d | 102d → 63d | A3810 FS-15d → A3830 |
| A3780 | RELLENO ESTRUCTURAL PARA OBRAS DE ARTE CON MATERIAL PROPIO | 2024-07-25 → 2025-02-21 (+211d) | 2024-08-06 → 2025-02-25 (+203d) | 13d → 5d | 94d → 63d | A3770 FS-15d → A3820 |
| 3 | **ARQUITECTURA Y PAISAJISMO** | 2024-05-19 → 2025-01-23 (+249d) | 2024-06-05 → 2025-04-24 (+323d) |  |  |  |
| 1 | **OBRAS PRELIMINARES** | 2024-05-19 → 2025-01-23 (+249d) | 2024-06-05 → 2025-04-24 (+323d) |  |  |  |
| A3870 | TRAZO Y REPLANTEO PRELIMINAR | 2024-05-19 → 2025-01-31 (+257d) | 2024-06-05 → 2025-02-07 (+247d) | 18d → 8d | 156d → 5d | MOVILIZACIÓN Y DEMOVILIZACIÓN DE EQUIPOS Y HERRAMIENTAS (ARQUITECTURA Y PAISAJISMO) FS-18d → A3860 |
| 2 | **MOVIMIENTO DE TIERRAS** | 2024-05-19 → 2025-02-08 (+265d) | 2024-06-05 → 2025-02-27 (+267d) |  |  |  |
| A3880 | EXCAVACIÓN MANUAL PARA INSTALACIÓN DE BORDILLOS Y CIMENTACIONES | 2024-05-19 → 2025-02-08 (+265d) | 2024-06-05 → 2025-02-09 (+249d) | 18d → 2d | 156d → 5d | MOVILIZACIÓN Y DEMOVILIZACIÓN DE EQUIPOS Y HERRAMIENTAS (ARQUITECTURA Y PAISAJISMO) FS-18d → A3870 |
| A3900 | ELIMINACION DE MATERIAL EXCEDENTE (DME´S) | 2024-05-19 → 2025-02-08 (+265d) | 2024-06-05 → 2025-02-27 (+267d) | 18d → 20d | 156d → 53d | A3890 FS-18d → A3880 SS |
| A3890 | EXCAVACIÓN PARA MEJORAMIENTO DE SUELO CON TIERRA VEGETAL | 2024-05-19 → 2025-02-10 (+267d) | 2024-06-05 → 2025-02-24 (+264d) | 18d → 15d | 156d → 5d | A3880 FS-18d → A3880 |
| 3 | **PAVIMENTOS, RECUBRIMIENTOS Y BORDILLOS** | 2024-05-19 → 2025-02-25 (+282d) | 2024-06-05 → 2025-03-07 (+275d) |  |  |  |
| A3910 | PISO DE GRAVILLA | 2024-05-19 → 2025-02-25 (+282d) | 2024-06-05 → 2025-02-26 (+266d) | 18d → 2d | 156d → 5d | A3890 FS-18d → A3890 |
| A3920 | RECUBRIMIENTO DE PIEDRA DEL LUGAR e=0.05cm | 2024-05-19 → 2025-02-27 (+284d) | 2024-06-05 → 2025-03-02 (+270d) | 18d → 4d | 156d → 5d | A3910 FS-18d → A3910 |
| A3930 | BORDILLOS DE PIEDRA DEL LUGAR | 2024-05-19 → 2025-03-03 (+288d) | 2024-06-05 → 2025-03-07 (+275d) | 18d → 5d | 156d → 5d | A3920 FS-18d → A3920 |
| 4 | **MOBILIARIOS, BARANDAS Y ESCALERAS** | 2024-05-19 → 2025-03-08 (+293d) | 2024-06-05 → 2025-04-14 (+313d) |  |  |  |
| A3940 | ESCALERA DE CONCRETO SOBRE ENROCADO, CIMENTACION Y ANCLAJE | 2024-05-19 → 2025-03-08 (+293d) | 2024-06-05 → 2025-03-17 (+285d) | 18d → 10d | 156d → 5d | A3920 FS-18d → A3930 |
| A3950 | BARANDA DE MADERA EUCALIPTO CON SOGA, INCLUYE CIMENTACIÓN | 2024-05-19 → 2025-03-18 (+303d) | 2024-06-05 → 2025-03-21 (+289d) | 18d → 4d | 156d → 5d | A3940 FS-18d → A3940 |
| A3960 | TACHOS DE BASURA, INCLUYE CIMENTACIÓN | 2024-05-19 → 2025-03-22 (+307d) | 2024-06-05 → 2025-03-24 (+292d) | 18d → 3d | 156d → 5d | A3950 FS-18d → A3950 |
| A3970 | BANCAS DE CONCRETO, INCLUYE CIMENTACIÓN | 2024-05-19 → 2025-03-25 (+310d) | 2024-06-05 → 2025-04-03 (+302d) | 18d → 10d | 156d → 5d | A3960 FS-18d → A3960 |
| A3980 | POSTES DE ILUMINACIÓN, INCLUYE LUMINARIA Y CIMENTACIÓN | 2024-05-19 → 2025-04-04 (+320d) | 2024-06-05 → 2025-04-08 (+307d) | 18d → 5d | 156d → 5d | A3970 FS-18d → A3970 |
| A3990 | SEÑALETICA INFORMATIVA | 2024-05-19 → 2025-04-09 (+325d) | 2024-06-05 → 2025-04-11 (+310d) | 18d → 3d | 156d → 5d | A3980 FS-18d → A3980 |
| A4000 | BOLARDOS DE PIEDRA | 2024-05-19 → 2025-04-12 (+328d) | 2024-06-05 → 2025-04-14 (+313d) | 18d → 3d | 156d → 5d | A3990 FS-18d → A3990 |
| A4010 | ALCORQUES DE PIEDRA DE CANTO RODADO PARA ARBOLES | 2024-05-19 → 2025-04-15 (+331d) | 2024-05-20 → 2025-04-16 (+331d) |  | 172d → 5d | MOVILIZACIÓN Y DEMOVILIZACIÓN DE EQUIPOS Y HERRAMIENTAS (ARQUITECTURA Y PAISAJISMO) SS → A4000 |
| 4 | **PROGRAMA DE CIERRE DE OBRA** | 2024-05-19 → 2024-11-06 (+171d) | 2024-11-06 → 2025-04-22 (+167d) |  |  |  |
| A1770 | ACONDICIONAMIENTO DE DEPOSITOS DE MATERIALES EXCEDENTES (DME) | 2024-05-19 → 2024-11-06 (+171d) | 2024-11-06 → 2025-04-14 (+159d) | 172d → 160d | 2d → 7d | A1150 SS → A1220 SS |
| A1780 | RESTAURACIÓN DE ÁREAS DE INSTALACIONES PROVISIONALES | 2024-05-19 → 2025-04-15 (+331d) | 2024-11-06 → 2025-04-22 (+167d) | 172d → 8d | 2d → 7d | A1770 SS → A1770 |

## Version 7 (data date 2024-11-01, saved 2024-10-09, file A3-1.xer)

Last finish 2025-04-29 → 2025-05-03 (+4d).

Added:

| ID | Task | Duration | Start | Finish | Predecessors | Constraint | Resources |
| --- | --- | --- | --- | --- | --- | --- | --- |
| H1 | INICIO DE PLAZO CONTRACTUAL - ACCESO AL SITIO (16 días calendario despues del KOM) | 0d | 2024-11-01 | 2024-11-01 |  | start on or after 2023-11-01 |  |
| H2 | INICIO DE EXCAVACION | 0d | 2024-11-06 | 2024-11-06 | H1 FS+5d |  |  |
| H4 | FIN DE PLAZO DE CONTRACTUAL - CULMINACION DE OBRAS | 0d | 2025-05-03 | 2025-05-03 | 1.2.11 |  |  |
| 4 | **DESCOLMATACIÓN DE CAUCE y OBRAS AUXILIARES** |  | 2024-11-01 | 2025-04-23 |  |  |  |
| 1.4.2 | DESCOLMATACIÓN DE CAUCE NATURAL DEL RÍO LACRAMARCA | 43d | 2024-11-04 | 2024-12-16 | 1.4.1 SS+3d |  | Tractor D8 [1034 h]; Operador Tractor [1034 h] |
| 1 | **DIQUE DE TIERRA COMPACTADA A3-I-01- 1 ETAPA** |  | 2024-11-06 | 2024-12-24 |  |  |  |
| 2 | **DIQUE DE TIERRA COMPACTADA A3-I-01- 2 ETAPA** |  | 2025-01-27 | 2025-03-01 |  |  |  |
| 1.5.3.100 | LIBERACIÓN DE PREDIOS A3-I-01 | 0d | 2025-01-27 | 2025-01-27 | H1 FS+87d |  |  |
| 1 | **DIQUE DE TIERRA COMPACTADA A3-I-03- 1 ETAPA** |  | 2024-11-06 | 2025-03-07 |  |  |  |
| 1.5.5.59 | CONFORMACIÓN DE CORONA DE DIQUE CON MATERIAL PROPIO | 13d | 2025-02-23 | 2025-03-07 | 1.5.5.89 |  | Operador Excavadora [97 h]; Excavadora [97 h]; Operador Rodillo [95 h]; Rodillo [95 h]; Motoniveladora [95 h]; Operador Motoniveladora [95 h] |
| 2 | **DIQUE DE TIERRA COMPACTADA A3-I-03- 2 ETAPA** |  | 2025-03-25 | 2025-04-26 |  |  |  |
| 1.5.5.108 | LIBERACION DE PREDIOS A3-I-03 | 0d | 2025-03-26 | 2025-03-26 | H2 FS+140d |  |  |
| 1.5.5.149 | CONFORMACIÓN DE CORONA DE DIQUE CON MATERIAL PROPIO | 2d | 2025-04-25 | 2025-04-26 | 1.5.5.179 |  | Operador Excavadora [97 h]; Excavadora [97 h]; Operador Rodillo [95 h]; Rodillo [95 h]; Motoniveladora [95 h]; Operador Motoniveladora [95 h] |
| 4 | **TUBERIAS** |  | 2025-03-06 | 2025-04-08 |  |  |  |
| 2.5.9 | ENCOFRADO Y DESENCOFRADO RECTO | 3d | 2024-12-19 | 2024-12-21 | 2.5.10 |  |  |
| 3 | **TRANSPORTE DE MATERIAL** |  | 2024-11-06 | 2025-04-20 |  |  |  |
| 3.5 | TRANSPORTE DE MATERIAL EXCEDENTE PARA DISTANCIAS <1KM | 130d | 2024-11-06 | 2025-03-15 | H2 |  | Volquete [4742 h]; Operador Volquete [4742 h] |
| 3.6 | TRANSPORTE DE MATERIAL EXCEDENTE PARA DISTANCIAS >1KM | 130d | 2024-11-06 | 2025-03-15 | 3.5 SS |  | Volquete [16442 h]; Operador Volquete [16442 h] |
| 3.3 | TRANSPORTE DE ROCA PARA DISTANCIAS <1KM | 130d | 2024-12-04 | 2025-04-12 | 1.5.3.79 |  | Volquete [3037 h]; Operador Volquete [3037 h] |
| 3.4 | TRANSPORTE DE ROCA PARA DISTANCIAS >1KM | 130d | 2024-12-04 | 2025-04-12 | 3.3 SS |  | Volquete [12197 h]; Operador Volquete [12197 h] |
| 3.1 | TRANSPORTE DE MATERIAL GRANULAR PARA DISTANCIAS <1KM | 85d | 2025-01-26 | 2025-04-20 | 2.1.2.3 SS |  | Volquete [372 h]; Operador Volquete [372 h] |
| 3.2 | TRANSPORTE DE MATERIAL GRANULAR PARA DISTANCIAS >1KM | 85d | 2025-01-26 | 2025-04-20 | 2.1.2.3 SS |  | Volquete [76.08 h]; Operador Volquete [76.08 h] |
| 4.1.1 | MOVILIZACIÓN Y DEMOVILIZACIÓN DE EQUIPOS Y HERRAMIENTAS (ARQUITECTURA Y PAISAJISMO) | 6d | 2025-01-26 | 2025-01-31 | 2.5.4, 1.5.4.8 |  |  |
| 6 | **SEGURIDAD Y SALUD OCUPACIONAL** |  | 2024-11-01 | 2025-04-19 |  |  |  |
| 6.1 | SEGURIDAD Y SALUD OCUPACIONAL | 170d | 2024-11-01 | 2025-04-19 | H1 |  |  |
| 6.2 | IMPLEMENTACIÓN DEL PLAN PARA LA VIGILANCIA, PREVENCIÓN Y CONTROL DE COVID-19 EN EL TRABAJO | 160d | 2024-11-01 | 2025-04-09 | H1 |  |  |

Removed: A1000 KICK OFF MEETING; A1010 INICIO DE PLAZO CONTRACTUAL - ACCESO AL SITIO; A1015 INICIO DE EXCAVACIÓN; A1020 FIN DE PLAZO CONTRACTUAL - CULMINACION DE OBRAS; DESCOLMATACIÓN DE CAUCE Y OBRAS AUXILIARES; DESBROCE Y DESCOLMATACIÓN; A5250 DESBROCE Y LIMPIEZA INICIAL EN ZONA NO BOSCOSA; A5260 DESCOLMATACIÓN DE CAUCE NATURAL DEL RÍO LACRAMARCA - DIQUE A3-D-02 - INICIAL; A1230 DESCOLMATACIÓN DE CAUCE NATURAL DEL RÍO LACRAMARCA - DIQUE A3-D-01; A1880 DESCOLMATACIÓN DE CAUCE NATURAL DEL RÍO LACRAMARCA - DIQUE A3-I-01; A1870 DESCOLMATACIÓN DE CAUCE NATURAL DEL RÍO LACRAMARCA - DIQUE A3-D-02; A1890 DESCOLMATACIÓN DE CAUCE NATURAL DEL RÍO LACRAMARCA - DIQUE A3-I-02; A1900 DESCOLMATACIÓN DE CAUCE NATURAL DEL RÍO LACRAMARCA - DIQUE A3-I-03; DESVIO DEL CAUCE; CONSTRUCCION DIQUE A3-D-01; CONSTRUCCION DIQUE A3-D-02 TRAMO 1; CONSTRUCCION DIQUE A3-D-02 TRAMO 2; CONSTRUCCION DIQUE A3-D-02 TRAMO 3; CONSTRUCCION DIQUE A3-D-02 TRAMO 4; CONSTRUCCION DIQUE A3-I-01; CONSTRUCCION DIQUE A3-I-02; CONSTRUCCION DIQUE A3-I-03 TRAMO 1; A4950 PERFILADO Y COMPACTACIÓN EN ZONA DE CORTE; A4940 EXCAVACIÓN DE UÑA CON EQUIPO; A4970 CONFORMACIÓN DE CUERPO DE DIQUE CON MATERIAL PROPIO; A4980 GEOTEXTIL NO TEJIDO 400 G/M2, INC. COLOCACIÓN; A4990 COLOCACION Y ACOMODO DE ROCA EN UÑA DE DIQUE; A5000 COLOCACION Y ACOMODO DE ROCA EN TALUD DE DIQUE; A4960 PREPARACIÓN DE FUNDACIÓN DE CUERPO DE DIQUE; CONSTRUCCION DIQUE A3-I-03 TRAMO 2; A5650 PERFILADO Y COMPACTACIÓN EN ZONA DE CORTE; A5640 EXCAVACIÓN DE UÑA CON EQUIPO; A5660 CONFORMACIÓN DE CUERPO DE DIQUE CON MATERIAL PROPIO; A5680 GEOTEXTIL NO TEJIDO 400 G/M2, INC. COLOCACIÓN; A5710 PREPARACIÓN DE FUNDACIÓN DE CUERPO DE DIQUE; A5690 COLOCACION Y ACOMODO DE ROCA EN UÑA DE DIQUE; A5700 COLOCACION Y ACOMODO DE ROCA EN TALUD DE DIQUE; CONSTRUCCION DIQUE A3-I-03 TRAMO 3; A5550 EXCAVACIÓN DE UÑA CON EQUIPO; A5560 PERFILADO Y COMPACTACIÓN EN ZONA DE CORTE; A5570 CONFORMACIÓN DE CUERPO DE DIQUE CON MATERIAL PROPIO; A5590 GEOTEXTIL NO TEJIDO 400 G/M2, INC. COLOCACIÓN; A5600 COLOCACION Y ACOMODO DE ROCA EN UÑA DE DIQUE; A5610 COLOCACION Y ACOMODO DE ROCA EN TALUD DE DIQUE; A5620 PREPARACIÓN DE FUNDACIÓN DE CUERPO DE DIQUE; A3-RA-I-01; A1740 EXCAVACIÓN EN TERRENO NATURAL CON EQUIPO; A3-RA-D-01; A1710 EXCAVACIÓN EN TERRENO NATURAL CON EQUIPO; A1720 CONFORMACIÓN DE CUERPO DE RAMPA CON MATERIAL PROPIO; A1730 CONFORMACIÓN DE CORONACIÓN DE RAMPA; A5220 SECADO DE CONCRETO f'c=280 kg/cm2; A5750 SECADO DE CONCRETO f'c=280 kg/cm2; A5230 SECADO DE CONCRETO f'c=280 kg/cm2; TUBERIA; A5240 SECADO DE CONCRETO f'c=280 kg/cm2 (Buzones); A3570 EXCAVACIÓN EN TERRENO NATURAL CON EQUIPO; A3590 ENCOFRADO RECTO; A5730 SECADO DE CONCRETO f'c=280 kg/cm2; A5740 DESENCOFRADO RECTO; A3660 EXCAVACIÓN EN TERRENO NATURAL CON EQUIPO; A3860 MOVILIZACIÓN DE EQUIPOS Y HERRAMIENTAS (ARQUITECTURA Y PAISAJISMO); A4020 DEMOVILIZACIÓN DE EQUIPOS Y HERRAMIENTAS (ARQUITECTURA Y PAISAJISMO)

Changed:

| ID | Task | Start | Finish | Duration | Total float | Predecessors | Other |
| --- | --- | --- | --- | --- | --- | --- | --- |
| A | **HITOS** | 2024-10-16 → 2024-11-01 (+16d) | 2025-04-29 → 2025-05-03 (+4d) |  |  |  |  |
| H3 | INICIO DE RELLENO DE DIQUE | 2024-11-28 → 2024-11-22 (-6d) | 2024-11-28 → 2024-11-22 (-6d) |  | 5d → 162d | INICIO DE EXCAVACIÓN SS+22d → 1.5.3.99 FS+3d |  |
| 1 | **DEFENSAS RIBEREÑAS** | 2024-10-16 → 2024-11-01 (+16d) | 2025-04-29 → 2025-05-02 (+3d) |  |  |  |  |
| 1 | **OBRAS PRELIMINARES** |  | 2025-04-28 → 2025-04-20 (-8d) |  |  |  |  |
| 1.1.2 | INSTALACIONES PROVISIONALES PARA LA OBRA | 2024-11-06 → 2024-11-01 (-5d) | 2025-04-23 → 2024-11-13 (-161d) | 169d → 13d | 1d → 6d | INICIO DE EXCAVACIÓN, 1.1.1 → H1 |  |
| 1.1.3 | MANTENIMIENTO DE TRÁNSITO Y SEGURIDAD VIAL | 2024-11-26 → 2024-11-13 (-13d) | 2025-04-28 → 2025-04-20 (-8d) | 154d → 159d | 1d → 12d | 1.3.1.2 → 1.2.1 FS-1d |  |
| 1.1.1 | CARTEL DE IDENTIFICACIÓN OBRA 4.80 x 3.60 m. | 2024-11-01 → 2024-11-14 (+13d) | 2024-11-02 → 2024-11-18 (+16d) | 2d → 5d | 4d → 165d | 1.2.1 SS+2d, INICIO DE PLAZO CONTRACTUAL - ACCESO AL SITIO SS → 1.2.1, H1 |  |
| 2 | **TRABAJOS PRELIMINARES** | 2024-10-16 → 2024-11-01 (+16d) | 2025-04-29 → 2025-05-02 (+3d) |  |  |  |  |
| 1.2.1 | MOVILIZACION DE EQUIPOS | 2024-10-16 → 2024-11-01 (+16d) | 2024-10-31 → 2024-11-13 (+13d) | 16d → 13d | 0d → 6d | KICK OFF MEETING SS → H1 |  |
| 1.2.2 | TOPOGRAFÍA Y GEOREFERENCIACIÓN |  | 2025-04-24 → 2025-04-19 (-5d) | 175d → 170d | 5d → 6d | 1.2.1 SS+2d, INICIO DE PLAZO CONTRACTUAL - ACCESO AL SITIO SS → 1.1.2 SS |  |
| 1.2.11 | DESMOVILIZACION DE EQUIPOS | 2025-04-25 → 2025-04-18 (-7d) | 2025-04-29 → 2025-05-02 (+3d) | 5d → 15d |  | 1.5.4.8, CONFORMACIÓN DE CORONACIÓN DE RAMPA → 2.2.5.2 FF, 5.2 FF |  |
| 3 | **MEJORAMIENTO DE VÍAS EXISTENTES** | 2024-11-06 → 2024-11-08 (+2d) | 2025-01-06 → 2024-12-02 (-35d) |  |  |  |  |
| 1 | **MOVIMIENTO DE TIERRAS** | 2024-11-06 → 2024-11-08 (+2d) | 2024-11-25 → 2024-12-02 (+7d) |  |  |  |  |
| 1.3.1.1 | ROCE Y LIMPIEZA DE MALEZA | 2024-11-06 → 2024-11-08 (+2d) | 2024-11-25 → 2024-11-11 (-14d) | 20d → 4d | 1d → 151d | INICIO DE EXCAVACIÓN SS, 1.1.2 SS → 1.2.2 SS+7d |  |
| 1.3.1.2 | MEJORAMIENTO DE VIAS EXISTENTES | 2024-11-06 → 2024-11-11 (+5d) | 2024-11-25 → 2024-12-02 (+7d) | 20d → 22d | 1d → 151d | 1.3.1.1 SS → 1.3.1.1 SS+3d |  |
| 2 | **REPOSICIÓN DE ESTRUCTURAS** | 2024-11-26 → 2024-11-15 (-11d) | 2024-12-31 → 2024-11-23 (-38d) |  |  |  |  |
| 1.3.2.1 | DEMOLICIÓN DE ESTRUCTURAS EXISTENTES | 2024-11-26 → 2024-11-15 (-11d) | 2024-11-27 → 2024-11-17 (-10d) | 2d → 3d | 35d → 152d | 1.2.2 SS, 1.3.1.2 → 1.3.1.2 SS+4d |  |
| 1.3.2.2 | REPOSICIÓN DE PASE DE AGUA TUBO HDPE Ø=18" | 2024-11-28 → 2024-11-18 (-10d) | 2024-11-29 → 2024-11-20 (-9d) | 2d → 3d | 35d → 152d |  |  |
| 1.3.2.3 | REPOSICIÓN DE PASE DE AGUA TUBO HDPE Ø=36" | 2024-11-30 → 2024-11-18 (-12d) | 2024-12-01 → 2024-11-20 (-11d) | 2d → 3d | 35d → 152d | 1.3.2.2 → 1.3.2.2 SS |  |
| 1.3.2.4 | SUMINISTRO Y MONTAJE DE PANELES DE C°A° 1.6mx1.0mx0.20m EN PASE DE AGUA | 2024-12-02 → 2024-11-21 (-11d) | 2024-12-31 → 2024-11-23 (-38d) | 30d → 3d | 35d → 152d |  |  |
| 1.3.2.5 | SUMINISTRO Y MONTAJE DE PANELES DE C°A° 2.20mx1.0mx0.20m EN PASE DE AGUA | 2024-12-02 → 2024-11-21 (-11d) | 2024-12-31 → 2024-11-23 (-38d) | 30d → 3d | 35d → 152d |  |  |
| 3 | **CABEZAL DE ENTRADA Y SALIDA** | 2025-01-01 → 2024-11-24 (-38d) | 2025-01-06 → 2024-12-01 (-36d) |  |  |  |  |
| 1.3.3.2 | ENCOFRADO Y DESENCOFRADO RECTO | 2025-01-01 → 2024-11-24 (-38d) | 2025-01-03 → 2024-11-28 (-36d) | 3d → 5d | 35d → 152d |  |  |
| 1.3.3.1 | CONCRETOS | 2025-01-04 → 2024-11-29 (-36d) | 2025-01-06 → 2024-12-01 (-36d) |  | 35d → 152d |  |  |
| 1.4.1 | DESBROCE Y LIMPIEZA EN ZONA NO BOSCOSA | 2024-11-06 → 2024-11-01 (-5d) | 2025-01-20 → 2024-12-13 (-38d) | 76d → 43d | 2d → 6d | INICIO DE EXCAVACIÓN, INICIO DE PLAZO CONTRACTUAL - ACCESO AL SITIO, DESBROCE Y LIMPIEZA INICIAL EN ZONA NO BOSCOSA → 1.2.1 SS | resources none → Operador Excavadora [426 h]; Excavadora [426 h]; Tractor D8 [487 h]; Volquete [1157 h]; Operador Tractor [487.46 h]; Operador Volquete [1157 h] |
| 1.4.3 | CONFORMACIÓN DE DESVIO EN CAUCE DE RÍO | 2024-11-08 → 2024-11-06 (-2d) | 2025-01-14 → 2024-12-15 (-30d) | 68d → 40d | 6d → 135d | INICIO DE EXCAVACIÓN FS+2d, DESCOLMATACIÓN DE CAUCE NATURAL DEL RÍO LACRAMARCA - DIQUE A3-D-02 - INICIAL → 1.4.2 SS+2d | resources none → Operador Excavadora [572 h]; Excavadora [572 h] |
| 1.4.4 | RELLENO NO ESTRUCTURAL CON MATERIAL PROPIO | 2025-01-15 → 2025-03-22 (+66d) | 2025-04-13 → 2025-04-23 (+10d) | 89d → 33d | 16d → 9d | 1.4.3 → 1.4.3 SS+10d, 1.5.1.5, 1.5.2.5 | resources none → Tractor D6 [459 h]; Operador Tractor [459 h] |
| 5 | **DIQUES DE TIERRA COMPACTADA CON ENROCADO** | 2024-11-08 → 2024-11-06 (-2d) | 2025-04-24 → 2025-04-26 (+2d) |  |  |  |  |
| 1 | **DIQUE DE TIERRA COMPACTADA A3-D-01** | 2024-11-08 → 2024-12-15 (+37d) | 2024-12-07 → 2025-02-07 (+62d) |  |  |  |  |
| 1.5.1.1 | EXCAVACIÓN EN TERRENO NATURAL CON EQUIPO | 2024-11-08 → 2024-12-15 (+37d) | 2024-11-16 → 2024-12-21 (+35d) | 9d → 7d | 0d → 48d | DESBROCE Y LIMPIEZA INICIAL EN ZONA NO BOSCOSA, DESCOLMATACIÓN DE CAUCE NATURAL DEL RÍO LACRAMARCA - DIQUE A3-D-02 - INICIAL → H2, 1.5.2.1, 1.5.2.2, 1.5.3.89 | resources none → Operador Excavadora [56 h]; Excavadora [56 h]; Tractor D6 [28 h]; Operador Tractor [28 h] |
| 1.5.1.2 | EXCAVACIÓN DE UÑA CON EQUIPO | 2024-11-12 → 2024-12-22 (+40d) | 2024-11-17 → 2024-12-25 (+38d) | 6d → 4d | 2d → 48d | DESCOLMATACIÓN DE CAUCE NATURAL DEL RÍO LACRAMARCA - DIQUE A3-D-01 SS+4d, 1.4.3 SS → 1.5.1.1 | resources none → Operador Excavadora [29 h]; Excavadora [29 h] |
| 1.5.1.3 | PERFILADO Y COMPACTACIÓN EN ZONA DE CORTE | 2024-11-09 → 2024-12-26 (+47d) | 2024-11-18 → 2024-12-30 (+42d) | 10d → 5d | 3d → 48d | 1.5.1.1 SS+1d → 1.5.1.2 | resources none → Operador Rodillo [17 h]; Rodillo [17 h]; Motoniveladora [36 h]; Operador Motoniveladora [36 h] |
| 1.5.1.9 | PREPARACIÓN DE FUNDACIÓN DE CUERPO DE DIQUE | 2024-11-09 → 2024-12-31 (+52d) | 2024-11-13 → 2025-01-02 (+50d) | 5d → 3d | 3d → 48d | 1.5.1.3 SS → 1.5.1.3 | resources none → Operador Rodillo [7 h]; Rodillo [7 h]; Motoniveladora [7 h]; Operador Motoniveladora [7 h] |
| 1.5.1.4 | CONFORMACIÓN DE CUERPO DE DIQUE CON MATERIAL PROPIO | 2024-11-17 → 2025-01-03 (+47d) | 2024-11-21 → 2025-01-07 (+47d) |  | 0d → 48d | 1.5.1.1, 1.5.1.9 → 1.5.1.9 | resources none → Operador Excavadora [39 h]; Excavadora [39 h]; Operador Rodillo [38 h]; Rodillo [38 h]; Motoniveladora [38 h]; Operador Motoniveladora [38 h] |
| 1.5.1.6 | GEOTEXTIL NO TEJIDO 400 G/M2, INC. COLOCACIÓN | 2024-11-19 → 2025-01-08 (+50d) | 2024-11-24 → 2025-01-19 (+56d) | 6d → 12d | 0d → 48d | 1.5.1.4 SS+2d → 1.5.1.4 |  |
| 1.5.1.7 | COLOCACION Y ACOMODO DE ROCA EN UÑA DE DIQUE | 2024-11-20 → 2025-01-12 (+53d) | 2024-11-25 → 2025-01-21 (+57d) | 6d → 10d | 0d → 48d | 1.5.1.6 SS+1d, 1.5.1.2 → 1.5.1.6 SS+4d | resources none → Operador Excavadora [447 h]; Excavadora [447 h] |
| 1.5.1.8 | COLOCACION Y ACOMODO DE ROCA EN TALUD DE DIQUE | 2024-11-22 → 2025-01-19 (+58d) | 2024-12-05 → 2025-02-01 (+58d) |  | 0d → 48d | 1.5.1.7 SS+2d, 1.5.1.1 → 1.5.1.7 SS+7d | resources none → Operador Excavadora [682 h]; Excavadora [682 h] |
| 1.5.1.5 | CONFORMACIÓN DE CORONA DE DIQUE CON MATERIAL PROPIO | 2024-12-06 → 2025-02-02 (+58d) | 2024-12-07 → 2025-02-07 (+62d) | 2d → 6d | 0d → 51d |  | resources none → Operador Excavadora [24 h]; Excavadora [24 h]; Operador Rodillo [23 h]; Rodillo [23 h]; Motoniveladora [23 h]; Operador Motoniveladora [23 h] |
| 2 | **DIQUE DE TIERRA COMPACTADA A3-D-02** | 2024-11-26 → 2024-11-07 (-19d) | 2025-04-24 → 2025-03-21 (-34d) |  |  |  |  |
| 1.5.2.1 | EXCAVACIÓN EN TERRENO NATURAL CON EQUIPO | 2024-11-26 → 2024-11-07 (-19d) | 2024-12-06 → 2024-12-02 (-4d) | 11d → 26d | 4d → 0d | 1.4.3 SS, DESCOLMATACIÓN DE CAUCE NATURAL DEL RÍO LACRAMARCA - DIQUE A3-D-02 SS, 1.2.1, 1.5.1.7 → H2 FS+1d, 1.2.2 SS, 1.2.1 SS, 1.4.1 SS, H1 | resources none → Operador Excavadora [485 h]; Excavadora [485 h]; Tractor D6 [240 h]; Operador Tractor [240 h] |
| 1.5.2.2 | EXCAVACIÓN DE UÑA CON EQUIPO | 2024-12-08 → 2024-11-28 (-10d) | 2024-12-17 → 2024-12-09 (-8d) | 10d → 12d |  | 1.2.1, INICIO DE EXCAVACIÓN SS, DESCOLMATACIÓN DE CAUCE NATURAL DEL RÍO LACRAMARCA - DIQUE A3-D-02 - INICIAL, 1.5.1.8, 1.5.1.5 → 1.5.2.1 FS-5d | resources none → Operador Excavadora [206 h]; Excavadora [206 h] |
| 1.5.2.3 | PERFILADO Y COMPACTACIÓN EN ZONA DE CORTE | 2024-11-27 → 2024-12-10 (+13d) | 2024-12-10 → 2024-12-20 (+10d) | 14d → 11d | 15d → 0d | 1.5.2.1 SS+1d → 1.5.2.2 | resources none → Operador Rodillo [105 h]; Rodillo [105 h]; Motoniveladora [223 h]; Operador Motoniveladora [223 h] |
| 1.5.2.9 | PREPARACIÓN DE FUNDACIÓN DE CUERPO DE DIQUE | 2024-12-03 → 2024-12-21 (+18d) | 2024-12-07 → 2024-12-26 (+19d) | 5d → 6d | 15d → 0d | 1.5.2.3 SS+6d → 1.5.2.3 | resources none → Operador Rodillo [26 h]; Rodillo [26 h]; Motoniveladora [26 h]; Operador Motoniveladora [26 h] |
| 1.5.2.4 | CONFORMACIÓN DE CUERPO DE DIQUE CON MATERIAL PROPIO | 2024-12-07 → 2024-12-24 (+17d) | 2024-12-13 → 2025-01-01 (+19d) | 7d → 9d | 8d → 0d | 1.5.2.1 → 1.5.2.9 FS-3d | resources none → Operador Excavadora [164 h]; Excavadora [164 h]; Operador Rodillo [160 h]; Rodillo [160 h]; Motoniveladora [160 h]; Operador Motoniveladora [160 h] |
| 1.5.2.6 | GEOTEXTIL NO TEJIDO 400 G/M2, INC. COLOCACIÓN | 2024-12-09 → 2024-12-31 (+22d) | 2024-12-14 → 2025-02-13 (+61d) | 6d → 45d | 8d → 0d | 1.5.2.4 SS+2d → 1.5.2.4 FS-2d |  |
| 1.5.2.7 | COLOCACION Y ACOMODO DE ROCA EN UÑA DE DIQUE | 2024-12-18 → 2025-01-03 (+16d) | 2025-01-08 → 2025-02-28 (+51d) | 22d → 57d |  | 1.5.2.2 → 1.5.2.6 SS+3d | resources none → Operador Excavadora [3210 h]; Excavadora [3210 h] |
| 1.5.2.8 | COLOCACION Y ACOMODO DE ROCA EN TALUD DE DIQUE | 2024-12-23 → 2025-01-18 (+26d) | 2025-01-10 → 2025-03-06 (+55d) | 19d → 48d |  | 1.5.2.7 SS+5d, 1.5.2.9, 1.5.2.6 → 1.5.2.7 SS+15d | resources none → Operador Excavadora [3908 h]; Excavadora [3908 h] |
| 1.5.2.5 | CONFORMACIÓN DE CORONA DE DIQUE CON MATERIAL PROPIO | 2025-01-09 → 2025-03-07 (+57d) | 2025-01-10 → 2025-03-21 (+70d) | 2d → 15d | 109d → 9d | 1.5.2.8 FF → 1.5.2.8 | resources none → Operador Excavadora [119 h]; Excavadora [119 h]; Operador Rodillo [116 h]; Rodillo [116 h]; Motoniveladora [116 h]; Operador Motoniveladora [116 h] |
| 3 | **DIQUE DE TIERRA COMPACTADA A3-I-01** | 2024-11-08 → 2024-11-06 (-2d) | 2024-12-16 → 2025-03-01 (+75d) |  |  |  |  |
| 1.5.3.19 | EXCAVACIÓN EN TERRENO NATURAL CON EQUIPO | 2025-01-09 → 2024-11-06 (-64d) | 2025-01-19 → 2024-11-12 (-68d) | 11d → 7d | 9d → 20d | 1.5.2.7 → H2, H1 | resources none → Operador Excavadora [126 h]; Excavadora [126 h]; Tractor D6 [62 h]; Operador Tractor [62 h] |
| 1.5.3.29 | EXCAVACIÓN DE UÑA CON EQUIPO | 2025-01-11 → 2024-11-13 (-59d) | 2025-01-20 → 2024-11-14 (-67d) | 10d → 2d | 0d → 20d | 1.5.2.8 → 1.5.3.19 | resources none → Operador Excavadora [28 h]; Excavadora [28 h] |
| 1.5.3.39 | PERFILADO Y COMPACTACIÓN EN ZONA DE CORTE | 2025-01-09 → 2024-11-15 (-55d) | 2025-01-22 → 2024-11-16 (-67d) | 14d → 2d | 9d → 20d | 1.5.3.19 SS → 1.5.3.29 | resources none → Operador Rodillo [15 h]; Rodillo [15 h]; Motoniveladora [32 h]; Operador Motoniveladora [32 h] |
| 1.5.3.99 | PREPARACIÓN DE FUNDACIÓN DE CUERPO DE DIQUE | 2025-01-15 → 2024-11-17 (-59d) | 2025-01-16 → 2024-11-18 (-59d) |  | 9d → 20d | 1.5.3.39 SS+6d → 1.5.3.39 | resources none → Operador Rodillo [9 h]; Rodillo [9 h]; Motoniveladora [9 h]; Operador Motoniveladora [9 h] |
| 1.5.3.49 | CONFORMACIÓN DE CUERPO DE DIQUE CON MATERIAL PROPIO | 2025-01-19 → 2024-11-19 (-61d) | 2025-01-23 → 2024-11-22 (-62d) | 5d → 4d | 0d → 20d | 1.5.3.29 SS+8d → 1.5.3.99 | resources none → Operador Excavadora [66 h]; Excavadora [66 h]; Operador Rodillo [64 h]; Rodillo [64 h]; Motoniveladora [64 h]; Operador Motoniveladora [64 h] |
| 1.5.3.69 | GEOTEXTIL NO TEJIDO 400 G/M2, INC. COLOCACIÓN | 2025-01-21 → 2024-11-23 (-59d) | 2025-01-26 → 2024-11-25 (-62d) | 6d → 3d | 0d → 20d | 1.5.3.49 SS+2d → 1.5.3.49 |  |
| 1.5.3.79 | COLOCACION Y ACOMODO DE ROCA EN UÑA DE DIQUE | 2025-01-21 → 2024-11-26 (-56d) | 2025-02-11 → 2024-12-03 (-70d) | 22d → 8d | 0d → 20d | 1.5.3.69 SS, 1.5.3.29 → 1.5.3.69 | resources none → Operador Excavadora [437 h]; Excavadora [437 h] |
| 1.5.3.89 | COLOCACION Y ACOMODO DE ROCA EN TALUD DE DIQUE | 2025-01-26 → 2024-12-04 (-53d) | 2025-02-13 → 2024-12-14 (-61d) | 19d → 11d | 0d → 48d | 1.5.3.79 SS+5d, 1.5.3.99 → 1.5.3.79, 1.5.3.79 FF | resources none → Operador Excavadora [669 h]; Excavadora [669 h] |
| 1.5.3.59 | CONFORMACIÓN DE CORONA DE DIQUE CON MATERIAL PROPIO | 2024-12-12 → 2024-12-15 (+3d) | 2024-12-16 → 2024-12-24 (+8d) | 5d → 10d | 5d → 129d | 1.5.5.89 FF+2d → 1.5.3.89 | resources none → Operador Excavadora [23 h]; Excavadora [23 h]; Operador Rodillo [23 h]; Rodillo [23 h]; Motoniveladora [23 h]; Operador Motoniveladora [23 h] |
| 1.5.3.109 | EXCAVACIÓN EN TERRENO NATURAL CON EQUIPO | 2025-02-12 → 2025-01-27 (-16d) | 2025-02-22 → 2025-01-31 (-22d) | 11d → 5d | 9d → 0d | 1.5.3.79 → 1.5.3.100 | resources none → Operador Excavadora [126 h]; Excavadora [126 h]; Tractor D6 [62 h]; Operador Tractor [62 h] |
| 1.5.3.119 | EXCAVACIÓN DE UÑA CON EQUIPO | 2025-02-14 → 2025-02-01 (-13d) | 2025-02-23 → 2025-02-03 (-20d) | 10d → 3d |  | 1.5.3.89 → 1.5.3.109 | resources none → Operador Excavadora [28 h]; Excavadora [28 h] |
| 1.5.3.129 | PERFILADO Y COMPACTACIÓN EN ZONA DE CORTE | 2025-02-13 → 2025-02-04 (-9d) | 2025-02-26 → 2025-02-05 (-21d) | 14d → 2d | 9d → 0d | 1.5.3.109 SS+1d → 1.5.3.119 | resources none → Operador Rodillo [15 h]; Rodillo [15 h]; Motoniveladora [32 h]; Operador Motoniveladora [32 h] |
| 1.5.3.189 | PREPARACIÓN DE FUNDACIÓN DE CUERPO DE DIQUE | 2025-02-19 → 2025-02-06 (-13d) | 2025-02-20 → 2025-02-07 (-13d) |  | 9d → 0d | 1.5.3.129 SS+6d → 1.5.3.129 | resources none → Operador Rodillo [9 h]; Rodillo [9 h]; Motoniveladora [9 h]; Operador Motoniveladora [9 h] |
| 1.5.3.139 | CONFORMACIÓN DE CUERPO DE DIQUE CON MATERIAL PROPIO | 2025-02-22 → 2025-02-08 (-14d) | 2025-02-26 → 2025-02-10 (-16d) | 5d → 3d |  | 1.5.3.119 SS+8d → 1.5.3.189 | resources none → Operador Excavadora [66 h]; Excavadora [66 h]; Operador Rodillo [64 h]; Rodillo [64 h]; Motoniveladora [64 h]; Operador Motoniveladora [64 h] |
| 1.5.3.159 | GEOTEXTIL NO TEJIDO 400 G/M2, INC. COLOCACIÓN | 2025-02-24 → 2025-02-11 (-13d) | 2025-03-01 → 2025-02-15 (-14d) | 6d → 5d |  | 1.5.3.139 SS+2d → 1.5.3.139 |  |
| 1.5.3.169 | COLOCACION Y ACOMODO DE ROCA EN UÑA DE DIQUE | 2025-02-25 → 2025-02-16 (-9d) | 2025-03-18 → 2025-02-20 (-26d) | 22d → 5d |  | 1.5.3.159 SS+1d, 1.5.3.119 → 1.5.3.159 | resources none → Operador Excavadora [437 h]; Excavadora [437 h] |
| 1.5.3.179 | COLOCACION Y ACOMODO DE ROCA EN TALUD DE DIQUE | 2025-03-02 → 2025-02-21 (-9d) | 2025-03-20 → 2025-02-27 (-21d) | 19d → 7d |  | 1.5.3.169 SS+5d, 1.5.3.189 → 1.5.3.169, 1.5.3.169 FF | resources none → Operador Excavadora [669 h]; Excavadora [669 h] |
| 1.5.3.149 | CONFORMACIÓN DE CORONA DE DIQUE CON MATERIAL PROPIO | 2025-01-10 → 2025-02-28 (+49d) | 2025-01-15 → 2025-03-01 (+45d) | 6d → 2d | 26d → 62d | 1.5.5.179 FF+1d → 1.5.3.179 | resources none → Operador Excavadora [23 h]; Excavadora [23 h]; Operador Rodillo [23 h]; Rodillo [23 h]; Motoniveladora [23 h]; Operador Motoniveladora [23 h] |
| 4 | **DIQUE DE TIERRA COMPACTADA A3-I-02** | 2024-12-17 → 2024-11-06 (-41d) | 2025-01-16 → 2025-01-31 (+15d) |  |  |  |  |
| 1.5.4.1 | EXCAVACIÓN EN TERRENO NATURAL CON EQUIPO | 2025-03-19 → 2024-11-06 (-133d) | 2025-03-29 → 2024-11-30 (-119d) | 11d → 25d | 9d → 0d | 1.5.3.169 → H2, H1 | resources none → Operador Excavadora [171 h]; Excavadora [171 h]; Tractor D6 [85 h]; Operador Tractor [85 h] |
| 1.5.4.2 | EXCAVACIÓN DE UÑA CON EQUIPO | 2025-03-21 → 2024-12-01 (-110d) | 2025-03-30 → 2024-12-08 (-112d) | 10d → 8d |  | 1.5.3.179 → 1.5.4.1 | resources none → Operador Excavadora [38 h]; Excavadora [38 h] |

| ID | Task | Start | Finish | Duration | Total float | Predecessors | Other |
| --- | --- | --- | --- | --- | --- | --- | --- |
| 1.5.4.3 | PERFILADO Y COMPACTACIÓN EN ZONA DE CORTE | 2025-03-20 → 2024-12-09 (-101d) | 2025-04-02 → 2024-12-15 (-108d) | 14d → 7d | 9d → 0d | 1.5.4.1 SS+1d → 1.5.4.2 | resources none → Operador Rodillo [19 h]; Rodillo [19 h]; Motoniveladora [40 h]; Operador Motoniveladora [40 h] |
| 1.5.4.9 | PREPARACIÓN DE FUNDACIÓN DE CUERPO DE DIQUE | 2025-03-26 → 2024-12-16 (-100d) | 2025-03-27 → 2024-12-18 (-99d) | 2d → 3d | 9d → 0d | 1.5.4.3 SS+6d → 1.5.4.3 | resources none → Operador Rodillo [4 h]; Rodillo [4 h]; Motoniveladora [4 h]; Operador Motoniveladora [4 h] |
| 1.5.4.4 | CONFORMACIÓN DE CUERPO DE DIQUE CON MATERIAL PROPIO | 2025-03-29 → 2024-12-19 (-100d) | 2025-04-02 → 2024-12-22 (-101d) | 5d → 4d |  | 1.5.4.2 SS+8d → 1.5.4.9 | resources none → Operador Excavadora [14 h]; Excavadora [14 h]; Operador Rodillo [14 h]; Rodillo [14 h]; Motoniveladora [14 h]; Operador Motoniveladora [14 h] |
| 1.5.4.6 | GEOTEXTIL NO TEJIDO 400 G/M2, INC. COLOCACIÓN | 2025-03-31 → 2024-12-23 (-98d) | 2025-04-05 → 2025-01-02 (-93d) | 6d → 11d |  | 1.5.4.4 SS+2d → 1.5.4.4 |  |
| 1.5.4.7 | COLOCACION Y ACOMODO DE ROCA EN UÑA DE DIQUE | 2025-04-01 → 2024-12-26 (-96d) | 2025-04-22 → 2025-01-17 (-95d) | 22d → 23d |  | 1.5.4.6 SS+1d, 1.5.4.2 → 1.5.4.6 SS+3d | resources none → Operador Excavadora [596 h]; Excavadora [596 h] |
| 1.5.4.8 | COLOCACION Y ACOMODO DE ROCA EN TALUD DE DIQUE | 2025-04-06 → 2025-01-10 (-86d) | 2025-04-24 → 2025-01-25 (-89d) | 19d → 16d |  | 1.5.4.7 SS+5d, 1.5.4.9 → 1.5.4.7 SS+15d | resources none → Operador Excavadora [750 h]; Excavadora [750 h] |
| 1.5.4.5 | CONFORMACIÓN DE CORONA DE DIQUE CON MATERIAL PROPIO | 2025-02-15 → 2025-01-26 (-20d) | 2025-02-16 → 2025-01-31 (-16d) | 2d → 6d | 72d → 91d | COLOCACION Y ACOMODO DE ROCA EN TALUD DE DIQUE FF → 1.5.4.8 | resources none → Operador Excavadora [28 h]; Excavadora [28 h]; Operador Rodillo [27 h]; Rodillo [27 h]; Motoniveladora [27 h]; Operador Motoniveladora [27 h] |
| 5 | **DIQUE DE TIERRA COMPACTADA A3-I-03** | 2025-01-15 → 2024-11-06 (-70d) | 2025-04-20 → 2025-04-26 (+6d) |  |  |  |  |
| 1.5.5.19 | EXCAVACIÓN EN TERRENO NATURAL CON EQUIPO | 2024-11-08 → 2024-11-06 (-2d) | 2024-11-18 → 2024-11-25 (+7d) | 11d → 20d | 7d → 56d | DESCOLMATACIÓN DE CAUCE NATURAL DEL RÍO LACRAMARCA - DIQUE A3-D-01 SS, INICIO DE EXCAVACIÓN SS → H2, H1 | resources none → Operador Excavadora [315 h]; Excavadora [315 h]; Tractor D6 [155 h]; Operador Tractor [155 h] |
| 1.5.5.29 | EXCAVACIÓN DE UÑA CON EQUIPO | 2024-11-22 → 2024-11-26 (+4d) | 2024-11-26 → 2024-12-07 (+11d) | 5d → 12d | 7d → 56d | 1.5.5.19 FS+3d → 1.5.5.19 | resources none → Operador Excavadora [170 h]; Excavadora [170 h] |
| 1.5.5.39 | PERFILADO Y COMPACTACIÓN EN ZONA DE CORTE | 2024-11-22 → 2024-12-08 (+16d) | 2024-11-29 → 2024-12-18 (+19d) | 8d → 11d | 7d → 56d | 1.5.5.19 SS+1d, 1.5.5.29 SS → 1.5.5.29 | resources none → Operador Rodillo [85 h]; Rodillo [85 h]; Motoniveladora [181 h]; Operador Motoniveladora [181 h] |
| 1.5.5.99 | PREPARACIÓN DE FUNDACIÓN DE CUERPO DE DIQUE | 2024-11-25 → 2024-12-19 (+24d) | 2024-11-26 → 2024-12-23 (+27d) | 2d → 5d | 7d → 56d | 1.5.5.39 SS+3d → 1.5.5.39 | resources none → Operador Rodillo [25 h]; Rodillo [25 h]; Motoniveladora [25 h]; Operador Motoniveladora [25 h] |
| 1.5.5.49 | CONFORMACIÓN DE CUERPO DE DIQUE CON MATERIAL PROPIO | 2024-11-28 → 2024-12-22 (+24d) | 2024-12-05 → 2024-12-30 (+25d) | 8d → 9d | 5d → 56d | 1.5.5.99 SS+1d, H3 SS → 1.5.5.99 FS-2d | resources none → Operador Excavadora [133 h]; Excavadora [133 h]; Operador Rodillo [130 h]; Rodillo [130 h]; Motoniveladora [130 h]; Operador Motoniveladora [130 h] |
| 1.5.5.69 | GEOTEXTIL NO TEJIDO 400 G/M2, INC. COLOCACIÓN | 2024-11-30 → 2024-12-31 (+31d) | 2024-12-04 → 2025-02-01 (+59d) | 5d → 33d | 5d → 56d | 1.5.5.49 SS+2d → 1.5.5.49 |  |
| 1.5.5.79 | COLOCACION Y ACOMODO DE ROCA EN UÑA DE DIQUE | 2024-12-01 → 2025-01-03 (+33d) | 2024-12-06 → 2025-01-31 (+56d) | 6d → 29d | 5d → 56d | 1.5.5.69 SS+1d, 1.5.5.29 → 1.5.5.69 SS+3d | resources none → Operador Excavadora [2646 h]; Excavadora [2646 h] |
| 1.5.5.89 | COLOCACION Y ACOMODO DE ROCA EN TALUD DE DIQUE | 2024-12-03 → 2025-01-18 (+46d) | 2024-12-14 → 2025-02-22 (+70d) | 12d → 36d | 5d → 56d | 1.5.5.79 SS+2d, 1.5.5.19 → 1.5.5.79 SS+15d | resources none → Operador Excavadora [3250 h]; Excavadora [3250 h] |
| 1.5.5.109 | EXCAVACIÓN EN TERRENO NATURAL CON EQUIPO | 2024-12-17 → 2025-03-25 (+98d) | 2024-12-31 → 2025-03-27 (+86d) | 15d → 3d | 5d → 6d | 1.5.5.99, 1.5.5.89, 1.5.3.59 → 1.5.5.108 FS-1d | resources none → Operador Excavadora [315 h]; Excavadora [315 h]; Tractor D6 [155 h]; Operador Tractor [155 h] |
| 1.5.5.119 | EXCAVACIÓN DE UÑA CON EQUIPO | 2024-12-18 → 2025-03-28 (+100d) | 2024-12-24 → 2025-03-30 (+96d) | 7d → 3d | 12d → 6d | 1.5.5.109 SS+1d → 1.5.5.109 | resources none → Operador Excavadora [170 h]; Excavadora [170 h] |
| 1.5.5.129 | PERFILADO Y COMPACTACIÓN EN ZONA DE CORTE | 2024-12-20 → 2025-03-31 (+101d) | 2024-12-30 → 2025-04-01 (+92d) | 11d → 2d | 5d → 6d | 1.5.5.109 SS+3d → 1.5.5.119 | resources none → Operador Rodillo [85 h]; Rodillo [85 h]; Motoniveladora [181 h]; Operador Motoniveladora [181 h] |
| 1.5.5.139 | CONFORMACIÓN DE CUERPO DE DIQUE CON MATERIAL PROPIO | 2025-01-01 → 2025-04-02 (+91d) | 2025-01-02 → 2025-04-03 (+91d) |  | 5d → 6d | 1.5.5.189 SS+1d, 1.5.5.119 → 1.5.5.189 FS-2d | resources none → Operador Excavadora [133 h]; Excavadora [133 h]; Operador Rodillo [130 h]; Rodillo [130 h]; Motoniveladora [130 h]; Operador Motoniveladora [130 h] |
| 1.5.5.189 | PREPARACIÓN DE FUNDACIÓN DE CUERPO DE DIQUE | 2024-12-31 → 2025-04-02 (+92d) | 2024-12-31 → 2025-04-03 (+93d) | 1d → 2d | 5d → 6d | 1.5.5.129 FF+1d → 1.5.5.129 | resources none → Operador Rodillo [25 h]; Rodillo [25 h]; Motoniveladora [25 h]; Operador Motoniveladora [25 h] |
| 1.5.5.159 | GEOTEXTIL NO TEJIDO 400 G/M2, INC. COLOCACIÓN | 2025-01-01 → 2025-04-04 (+93d) | 2025-01-05 → 2025-04-08 (+93d) |  | 9d → 6d | 1.5.5.139 SS, 1.5.5.129 → 1.5.5.139 |  |
| 1.5.5.169 | COLOCACION Y ACOMODO DE ROCA EN UÑA DE DIQUE | 2025-01-01 → 2025-04-07 (+96d) | 2025-01-16 → 2025-04-10 (+84d) | 16d → 4d | 9d → 6d | 1.5.5.159 SS → 1.5.5.159 SS+3d | resources none → Operador Excavadora [2646 h]; Excavadora [2646 h] |
| 1.5.5.179 | COLOCACION Y ACOMODO DE ROCA EN TALUD DE DIQUE | 2025-01-01 → 2025-04-22 (+111d) | 2025-01-14 → 2025-04-24 (+100d) | 14d → 3d | 9d → 6d | 1.5.5.169 SS → 1.5.5.169 SS+15d | resources none → Operador Excavadora [3250 h]; Excavadora [3250 h] |
| 6 | **RAMPAS** | 2025-01-27 → 2025-02-23 (+27d) | 2025-04-12 → 2025-03-03 (-40d) |  |  |  |  |
| 1.6.1 | EXCAVACIÓN EN TERRENO NATURAL CON EQUIPO | 2025-01-15 → 2025-02-23 (+39d) | 2025-01-23 → 2025-02-25 (+33d) | 9d → 3d | 9d → 60d | 1.5.5.179 → 1.5.5.89 | resources none → Operador Excavadora [5 h]; Excavadora [5 h]; Tractor D6 [3 h]; Operador Tractor [3 h] |
| 1.6.2 | CONFORMACIÓN DE CUERPO DE RAMPA CON MATERIAL PROPIO | 2025-02-05 → 2025-02-26 (+21d) | 2025-02-13 → 2025-02-28 (+15d) | 9d → 3d | 55d → 60d | EXCAVACIÓN EN TERRENO NATURAL CON EQUIPO → 1.6.1 | resources none → Operador Excavadora [7 h]; Excavadora [7 h]; Operador Rodillo [7 h]; Rodillo [7 h]; Motoniveladora [7 h]; Operador Motoniveladora [7 h] |
| 1.6.3 | CONFORMACIÓN DE CORONACIÓN DE RAMPA | 2025-02-05 → 2025-03-01 (+24d) | 2025-02-13 → 2025-03-03 (+18d) | 9d → 3d | 55d → 60d | 1.6.2 SS → 1.6.2 | resources none → Operador Excavadora [5 h]; Excavadora [5 h]; Operador Rodillo [5 h]; Rodillo [5 h]; Motoniveladora [5 h]; Operador Motoniveladora [5 h] |
| 2 | **OBRAS DE ARTE** | 2024-11-08 → 2024-11-01 (-7d) | 2025-04-25 → 2025-05-02 (+7d) |  |  |  |  |
| 1 | **CAPTACIÓN A3-CP-23-95** | 2024-11-26 → 2025-01-18 (+53d) | 2025-04-12 → 2025-05-02 (+20d) |  |  |  |  |
| 1 | **MOVIMIENTO DE TIERRAS** | 2024-11-26 → 2025-01-18 (+53d) | 2025-01-12 → 2025-02-26 (+45d) |  |  |  |  |
| 2.1.1.1 | EXCAVACIÓN ESTRUCTURAL PARA OBRAS DE ARTE | 2024-11-26 → 2025-01-18 (+53d) | 2024-12-01 → 2025-01-25 (+55d) | 6d → 8d | 4d → 0d | 1.5.2.1 SS → 1.5.2.8 SS |  |
| 2.1.1.2 | RELLENO ESTRUCTURAL PARA OBRAS DE ARTE, CON MATERIAL PROPIO | 2025-01-07 → 2025-02-22 (+46d) | 2025-01-12 → 2025-02-26 (+45d) | 6d → 5d | 29d → 65d | 2.1.2.2, SECADO DE CONCRETO f'c=280 kg/cm2 → 2.1.2.2 |  |
| 2 | **OBRAS DE CONCRETO** | 2024-12-02 → 2025-01-26 (+55d) | 2025-01-06 → 2025-02-21 (+46d) |  |  |  |  |
| 2.1.2.3 | CONCRETO CICLÓPEO f'c=280 kg/cm2 + 30% P.G. | 2024-12-05 → 2025-01-26 (+52d) | 2024-12-07 → 2025-01-28 (+52d) |  | 14d → 0d | 2.1.2.1 → 2.1.1.1 |  |
| 2.1.2.1 | CONCRETO f'c=100 kg/cm2 | 2024-12-02 → 2025-01-29 (+58d) | 2024-12-04 → 2025-01-31 (+58d) |  | 14d → 0d | 2.1.1.1 → 2.1.2.3 |  |
| 2.1.2.5 | ACERO DE REFUERZO fy=4200 kg/cm2 | 2024-12-08 → 2025-02-01 (+55d) | 2024-12-20 → 2025-02-11 (+53d) | 13d → 11d | 14d → 0d | 2.1.2.3 → 2.1.2.1 |  |
| 2.1.2.4 | ENCOFRADO Y DESENCOFRADO RECTO | 2024-12-08 → 2025-02-10 (+64d) | 2024-12-20 → 2025-02-16 (+58d) | 13d → 7d | 18d → 0d | 2.1.2.5 FF → 2.1.2.5 FS-2d |  |
| 2.1.2.2 | CONCRETO f'c=280 kg/cm2 | 2024-12-08 → 2025-02-17 (+71d) | 2024-12-19 → 2025-02-21 (+64d) | 12d → 5d | 19d → 0d | 2.1.2.4 SS → 2.1.2.4 |  |
| 3 | **ESTRUCTURAS METALICAS** | 2025-01-01 → 2025-02-22 (+52d) | 2025-01-15 → 2025-03-08 (+52d) |  |  |  |  |
| 2.1.3.1 | COMPUERTA METALICA PLANA DESLIZANTE DE 1.0x1.0m | 2025-01-01 → 2025-02-22 (+52d) | 2025-01-03 → 2025-02-24 (+52d) |  | 19d → 55d | SECADO DE CONCRETO f'c=280 kg/cm2 → 2.1.2.2 |  |
| 2.1.3.2 | REJILLA DE 1.00x1.00m CON VARILLA DE 1/2" CADA 6,25cm | 2025-01-04 → 2025-02-25 (+52d) | 2025-01-06 → 2025-02-27 (+52d) |  | 19d → 55d |  |  |
| 2.1.3.3 | BARANDA DE FIERRO GALVANIZADO 1 1/2" | 2025-01-07 → 2025-02-28 (+52d) | 2025-01-09 → 2025-03-02 (+52d) |  | 19d → 55d |  |  |
| 2.1.3.4 | ESCALERA TIPO GATO | 2025-01-10 → 2025-03-03 (+52d) | 2025-01-12 → 2025-03-05 (+52d) |  | 19d → 55d |  |  |
| 2.1.3.5 | TAPA METALICA CIRCULAR DN600 MM | 2025-01-13 → 2025-03-06 (+52d) | 2025-01-15 → 2025-03-08 (+52d) |  | 19d → 55d |  |  |
| 4 | **TUBERIAS** | 2024-12-02 → 2025-02-22 (+82d) | 2025-01-24 → 2025-04-19 (+85d) |  |  |  |  |
| 2.1.4.1 | EXCAVACIÓN ESTRUCTURAL PARA OBRAS DE ARTE (Buzones) | 2024-12-02 → 2025-02-22 (+82d) | 2024-12-04 → 2025-02-26 (+84d) | 3d → 5d | 4d → 0d | 2.1.1.1 → 2.1.2.2 |  |
| 2.1.4.6 | CONCRETO f'c=100 kg/cm2 (Buzones) | 2024-12-05 → 2025-02-27 (+84d) | 2024-12-07 → 2025-03-01 (+84d) |  | 27d → 13d | 2.1.4.2 SS, 2.1.2.1 → 2.1.4.1 |  |
| 2.1.4.10 | ACERO DE REFUERZO fy=4200 kg/cm2 (Buzones) | 2024-12-21 → 2025-03-02 (+71d) | 2024-12-24 → 2025-03-06 (+72d) | 4d → 5d | 14d → 13d | 2.1.4.6, 2.1.2.5 → 2.1.4.6 |  |
| 2.1.4.9 | ENCOFRADO Y DESENCOFRADO CURVO | 2024-12-25 → 2025-03-05 (+70d) | 2024-12-29 → 2025-03-09 (+70d) |  | 14d → 13d | 2.1.4.8 SS → 2.1.4.10 FS-2d |  |
| 2.1.4.8 | ENCOFRADO Y DESENCOFRADO RECTO | 2024-12-25 → 2025-03-10 (+75d) | 2024-12-29 → 2025-03-13 (+74d) | 5d → 4d | 14d → 13d | 2.1.2.4, 2.1.4.10 → 2.1.4.9 |  |
| 2.1.4.7 | CONCRETO f'c=280 kg/cm2 (Buzones) | 2024-12-30 → 2025-03-14 (+74d) | 2025-01-01 → 2025-03-16 (+74d) |  | 23d → 13d | 2.1.4.9, 2.1.2.2 → 2.1.4.8 |  |
| 2.1.4.2 | EXCAVACIÓN DE ZANJA | 2024-12-05 → 2025-03-17 (+102d) | 2024-12-29 → 2025-03-29 (+90d) | 25d → 13d | 4d → 13d | 2.1.4.1 → 2.1.4.7, 2.1.2.2 |  |
| 2.1.4.3 | RELLENO ESTRUCTURAL PARA OBRAS DE ARTE CON MATERIAL PROPIO (Buzones) | 2025-01-14 → 2025-03-17 (+62d) | 2025-01-21 → 2025-03-19 (+57d) | 8d → 3d | 28d → 44d | 2.1.4.7 FS+12d, 2.1.1.2, 1.3.3.1, 2.2.1.2 → 2.1.4.7 |  |
| 2.1.4.4 | CAMA DE ARENA | 2024-12-05 → 2025-03-30 (+115d) | 2024-12-29 → 2025-04-04 (+96d) | 25d → 6d | 25d → 13d | 2.1.4.2 SS → 2.1.4.2 |  |
| 2.1.4.11 | SUMINISTRO E INSTALACIÓN DE TUBERÍA GRP DN600 mm SN2500 | 2024-12-05 → 2025-04-05 (+121d) | 2024-12-29 → 2025-04-11 (+103d) | 25d → 7d | 25d → 13d | 2.1.4.4 SS → 2.1.4.4 |  |
| 2.1.4.5 | RELLENO COMÚN PARA ZANJAS | 2024-12-30 → 2025-04-12 (+103d) | 2025-01-24 → 2025-04-19 (+85d) | 26d → 8d | 25d → 13d |  |  |
| 5 | **CANAL** | 2024-12-30 → 2025-02-27 (+59d) | 2025-03-18 → 2025-04-14 (+27d) |  |  |  |  |
| 2.1.5.1 | EXCAVACIÓN ESTRUCTURAL PARA OBRAS DE ARTE | 2024-12-30 → 2025-02-27 (+59d) | 2025-01-04 → 2025-03-06 (+61d) | 6d → 8d | 4d → 0d | 2.1.4.2 → 2.1.1.1 FS+5d, 2.1.4.1 |  |
| 2.1.5.3 | COLOCACIÓN DE CONCRETO f'c=100 kg/cm2 | 2025-01-05 → 2025-03-07 (+61d) | 2025-01-08 → 2025-03-10 (+61d) |  | 4d → 0d | 2.1.4.6, 2.1.5.1 → 2.1.5.1 |  |
| 2.1.5.6 | ACERO DE REFUERZO fy=4200 kg/cm2 | 2025-01-09 → 2025-03-11 (+61d) | 2025-02-05 → 2025-03-23 (+46d) | 28d → 13d | 4d → 0d | 2.1.4.10, 2.1.5.3 → 2.1.5.3 |  |
| 2.1.5.5 | ENCOFRADO Y DESENCOFRADO RECTO | 2025-01-09 → 2025-03-16 (+66d) | 2025-03-01 → 2025-03-27 (+26d) | 52d → 12d | 4d → 0d | 2.1.4.9, 2.1.5.6 SS → 2.1.5.6 SS+5d |  |
| 2.1.5.7 | JUNTA WATER STOP SIN BULBO 150 mm | 2025-01-11 → 2025-03-28 (+76d) | 2025-03-18 → 2025-03-31 (+13d) | 67d → 4d | 20d → 0d | 2.1.5.4 SS → 2.1.5.5 |  |
| 2.1.5.4 | COLOCACIÓN DE CONCRETO f'c=280 kg/cm2 | 2025-01-11 → 2025-04-01 (+80d) | 2025-03-04 → 2025-04-05 (+32d) | 53d → 5d | 11d → 0d | 2.1.4.7 SS, 2.1.5.5 SS+2d → 2.1.5.7 |  |
| 2.1.5.2 | RELLENO ESTRUCTURAL PARA CANALES, CON MATERIAL PROPIO | 2025-01-25 → 2025-04-06 (+71d) | 2025-03-08 → 2025-04-14 (+37d) | 43d → 9d | 25d → 18d | 2.1.4.3, 2.1.4.5 → 2.1.5.4 |  |
| 6 | **OBRAS DE DESCARGA** | 2025-01-05 → 2025-04-05 (+90d) | 2025-04-12 → 2025-05-02 (+20d) |  |  |  |  |
| 2.1.6.1 | EXCAVACIÓN ESTRUCTURAL PARA OBRAS DE ARTE | 2025-01-05 → 2025-04-05 (+90d) | 2025-01-14 → 2025-04-10 (+86d) | 10d → 6d | 30d → 0d | 2.1.5.1 → 2.1.5.4 FS-1d |  |
| 2.1.6.3 | CONCRETO f'c=100 kg/cm2 | 2025-01-15 → 2025-04-11 (+86d) | 2025-01-24 → 2025-04-13 (+79d) | 10d → 3d | 30d → 0d | 2.1.6.1, 2.1.5.3 → 2.1.6.1 |  |
| 2.1.6.6 | ACERO DE REFUERZO fy=4200 kg/cm2 | 2025-02-06 → 2025-04-14 (+67d) | 2025-02-15 → 2025-04-16 (+60d) | 10d → 3d | 18d → 0d | 2.1.6.3, 2.1.5.6 → 2.1.6.3 |  |
| 2.1.6.5 | ENCOFRADO Y DESENCOFRADO RECTO | 2025-03-02 → 2025-04-17 (+46d) | 2025-03-11 → 2025-04-21 (+41d) | 10d → 5d | 4d → 0d | 2.1.6.6, 2.1.5.5 → 2.1.6.6 |  |

| ID | Task | Start | Finish | Duration | Total float | Predecessors |
| --- | --- | --- | --- | --- | --- | --- |
| 2.1.6.7 | JUNTA WATER STOP SIN BULBO 150 mm | 2025-03-22 → 2025-04-19 (+28d) | 2025-04-02 → 2025-04-22 (+20d) | 12d → 4d | 17d → 0d | 2.1.6.4, 2.1.5.7 → 2.1.6.5 SS+2d |
| 2.1.6.4 | CONCRETO f'c=280 kg/cm2 | 2025-03-12 → 2025-04-23 (+42d) | 2025-03-21 → 2025-04-25 (+35d) | 10d → 3d | 4d → 0d | 2.1.6.5, 2.1.5.4 → 2.1.6.7 |
| 2.1.6.2 | RELLENO ESTRUCTURAL PARA OBRAS DE ARTE CON MATERIAL PROPIO | 2025-03-30 → 2025-04-26 (+27d) | 2025-04-08 → 2025-04-28 (+20d) | 10d → 3d | 4d → 0d | 2.1.6.4 FS+8d, 2.1.5.2 → 2.1.6.4 |
| 2.1.6.8 | COMPUERTA METALICA PLANA DESLIZANTE | 2025-04-03 → 2025-04-29 (+26d) | 2025-04-12 → 2025-05-02 (+20d) | 10d → 4d | 17d → 0d | 2.1.6.4 FS+12d, 2.1.6.7 → 2.1.6.2 |
| 2 | **CAPTACIÓN A3-CP-21-05** | 2024-11-08 → 2025-02-28 (+112d) | 2025-03-15 → 2025-05-02 (+48d) |  |  |  |
| 1 | **MOVIMIENTO DE TIERRAS** | 2024-11-08 → 2025-02-28 (+112d) | 2025-01-05 → 2025-04-03 (+88d) |  |  |  |
| 2.2.1.1 | EXCAVACIÓN ESTRUCTURAL PARA OBRAS DE ARTE | 2024-11-08 → 2025-02-28 (+112d) | 2024-11-11 → 2025-03-05 (+114d) | 4d → 6d | 10d → 0d | 1.2.2 SS+7d, INICIO DE EXCAVACIÓN SS, 1.5.5.19 SS → 1.5.3.179 |
| 2.2.1.2 | RELLENO ESTRUCTURAL PARA OBRAS DE ARTE, CON MATERIAL PROPIO | 2024-12-14 → 2025-03-30 (+106d) | 2025-01-05 → 2025-04-03 (+88d) | 23d → 5d | 36d → 29d |  |
| 2 | **OBRAS DE CONCRETO** | 2024-11-12 → 2025-03-06 (+114d) | 2024-12-25 → 2025-03-29 (+94d) |  |  |  |
| 2.2.2.3 | CONCRETO CICLÓPEO f'c=280 kg/cm2 + 30% P.G. | 2024-11-15 → 2025-03-06 (+111d) | 2024-11-17 → 2025-03-08 (+111d) |  | 10d → 16d | 2.2.2.1 → 2.2.1.1 |
| 2.2.2.1 | CONCRETO f'c=100 kg/cm2 | 2024-11-12 → 2025-03-09 (+117d) | 2024-11-14 → 2025-03-11 (+117d) |  | 10d → 16d | 2.2.1.1 → 2.2.2.3 |
| 2.2.2.5 | ACERO DE REFUERZO fy=4200 kg/cm2 | 2024-11-18 → 2025-03-12 (+114d) | 2024-12-08 → 2025-03-19 (+101d) | 21d → 8d | 10d → 16d | 2.2.2.3 → 2.2.2.1 |
| 2.2.2.4 | ENCOFRADO Y DESENCOFRADO RECTO | 2024-11-18 → 2025-03-16 (+118d) | 2024-12-09 → 2025-03-22 (+103d) | 22d → 7d | 10d → 16d | 2.2.2.5 SS → 2.2.2.5 SS+4d |
| 2.2.2.2 | CONCRETO f'c=280 kg/cm2 | 2024-11-18 → 2025-03-23 (+125d) | 2024-12-13 → 2025-03-29 (+106d) | 26d → 7d | 10d → 16d | 2.2.2.4 SS → 2.2.2.4 |
| 3 | **ESTRUCTURAS METALICAS** | 2024-12-26 → 2025-03-30 (+94d) | 2025-02-13 → 2025-04-16 (+62d) |  |  |  |
| 2.2.3.1 | COMPUERTA METALICA PLANA DESLIZANTE DE 1.0x1.0m | 2024-12-26 → 2025-03-30 (+94d) | 2025-01-04 → 2025-04-01 (+87d) | 10d → 3d | 10d → 16d | 2.2.2.2, SECADO DE CONCRETO f'c=280 kg/cm2 → 2.2.2.2 |
| 2.2.3.2 | REJILLA DE 1.00x1.00m CON VARILLA DE 1/2 CADA 6,25cm | 2025-01-05 → 2025-04-02 (+87d) | 2025-01-14 → 2025-04-04 (+80d) | 10d → 3d | 10d → 16d |  |
| 2.2.3.3 | BARANDA DE FIERRO GALVANIZADO 1 1/2" | 2025-01-15 → 2025-04-05 (+80d) | 2025-01-24 → 2025-04-10 (+76d) | 10d → 6d | 10d → 16d |  |
| 2.2.3.4 | ESCALERA TIPO GATO | 2025-01-25 → 2025-04-11 (+76d) | 2025-02-03 → 2025-04-13 (+69d) | 10d → 3d | 10d → 16d |  |
| 2.2.3.5 | TAPA METALICA CIRCULAR DN600 MM | 2025-02-04 → 2025-04-14 (+69d) | 2025-02-13 → 2025-04-16 (+62d) | 10d → 3d | 10d → 16d |  |
| 2.2.4.1 | EXCAVACIÓN ESTRUCTURAL PARA OBRAS DE ARTE (Buzones) | 2024-11-12 → 2025-03-06 (+114d) | 2024-11-17 → 2025-03-08 (+111d) | 6d → 3d | 33d → 0d |  |
| 2.2.4.7 | CONCRETO f'c=100 kg/cm2 (Buzones) | 2024-11-18 → 2025-03-09 (+111d) | 2024-11-23 → 2025-03-11 (+108d) | 6d → 3d | 33d → 0d | 2.2.4.1, 2.2.2.1 → 2.2.4.1 |
| 2.2.4.11 | ACERO DE REFUERZO fy=4200 kg/cm2 | 2024-12-09 → 2025-03-12 (+93d) | 2024-12-13 → 2025-03-14 (+91d) | 5d → 3d | 32d → 0d | 2.2.4.7, 2.2.2.5 → 2.2.4.7 |
| 2.2.4.10 | ENCOFRADO Y DESENCOFRADO CURVO | 2024-12-14 → 2025-03-15 (+91d) | 2024-12-18 → 2025-03-18 (+90d) | 5d → 4d | 32d → 0d | 2.2.4.9 SS → 2.2.4.11 |
| 2.2.4.9 | ENCOFRADO Y DESENCOFRADO RECTO | 2024-12-14 → 2025-03-19 (+95d) | 2024-12-18 → 2025-03-21 (+93d) | 5d → 3d | 32d → 0d | 2.2.4.11, 2.2.2.4 → 2.2.4.10 |
| 2.2.4.8 | CONCRETO f'c=280 kg/cm2 (Buzones) | 2024-12-19 → 2025-03-22 (+93d) | 2024-12-24 → 2025-03-24 (+90d) | 6d → 3d | 63d → 0d | 2.2.4.10, 2.2.2.2 → 2.2.4.9 |
| 2.2.4.2 | EXCAVACIÓN DE ZANJA | 2024-11-18 → 2025-03-25 (+127d) | 2024-11-23 → 2025-03-27 (+124d) | 6d → 3d | 113d → 0d | 2.2.4.1 → 2.2.4.8, 2.2.1.1 |
| 2.2.4.3 | RELLENO ESTRUCTURAL PARA OBRAS DE ARTE CON MATERIAL PROPIO | 2025-01-06 → 2025-03-25 (+78d) | 2025-01-12 → 2025-03-27 (+74d) | 7d → 3d | 80d → 36d | 2.2.4.8, SECADO DE CONCRETO f'c=280 kg/cm2 (Buzones) → 2.2.4.8 |
| 2.2.4.4 | CAMA DE ARENA | 2024-11-24 → 2025-03-28 (+124d) | 2024-11-29 → 2025-03-30 (+121d) | 6d → 3d | 113d → 0d |  |
| 2.2.4.12 | SUMINISTRO E INSTALACIÓN DE TUBERÍA GRP DN600 mm SN2500 | 2024-11-30 → 2025-03-31 (+121d) | 2024-12-04 → 2025-04-02 (+119d) | 5d → 3d | 113d → 0d |  |
| 2.2.4.6 | RELLENO COMÚN PARA ZANJAS | 2024-12-05 → 2025-04-03 (+119d) | 2024-12-10 → 2025-04-05 (+116d) | 6d → 3d | 113d → 24d |  |
| 2.2.4.5 | RELLENO SELECCIONADO PARA ZANJAS CON MATERIAL PROPIO | 2024-12-05 → 2025-04-06 (+122d) | 2024-12-10 → 2025-04-08 (+119d) | 6d → 3d | 113d → 24d | 2.2.4.6 SS → 2.2.4.6 |
| 5 | **CANALES** | 2024-11-18 → 2025-04-03 (+136d) | 2025-03-15 → 2025-05-02 (+48d) |  |  |  |
| 2.2.5.1 | EXCAVACIÓN ESTRUCTURAL PARA OBRAS DE ARTE | 2024-11-18 → 2025-04-03 (+136d) | 2024-11-22 → 2025-04-08 (+137d) | 5d → 6d | 34d → 0d | 2.2.4.1 → 2.2.4.12 |
| 2.2.5.3 | COLOCACIÓN DE CONCRETO f'c=100 kg/cm2 | 2024-11-24 → 2025-04-09 (+136d) | 2024-12-17 → 2025-04-11 (+115d) | 24d → 3d | 33d → 0d | 2.2.5.1, 2.2.4.7 → 2.2.5.1 |
| 2.2.5.6 | ACERO DE REFUERZO fy=4200 kg/cm2 | 2024-12-18 → 2025-04-12 (+115d) | 2024-12-29 → 2025-04-17 (+109d) | 12d → 6d | 33d → 0d | 2.2.5.3, 2.2.4.11 → 2.2.5.3 |
| 2.2.5.5 | ENCOFRADO Y DESENCOFRADO | 2024-12-19 → 2025-04-16 (+118d) | 2025-01-24 → 2025-04-20 (+86d) | 37d → 5d | 32d → 0d | 2.2.5.6 SS, 2.2.4.10 → 2.2.5.6 SS+4d |
| 2.2.5.7 | JUNTA WATER STOP SIN BULBO 150 mm | 2025-01-25 → 2025-04-21 (+86d) | 2025-01-29 → 2025-04-23 (+84d) | 5d → 3d | 90d → 0d | 2.2.5.4 SS → 2.2.5.5 |
| 2.2.5.4 | COLOCACIÓN DE CONCRETO f'c=280 kg/cm2 | 2025-01-25 → 2025-04-24 (+89d) | 2025-02-17 → 2025-04-27 (+69d) | 24d → 4d | 32d → 0d | 2.2.5.5, 2.2.4.8 → 2.2.5.7 |
| 2.2.5.2 | RELLENO ESTRUCTURAL PARA CANALES, CON MATERIAL PROPIO | 2025-03-02 → 2025-04-28 (+57d) | 2025-03-15 → 2025-05-02 (+48d) | 14d → 5d | 32d → 0d | 2.2.5.4 FS+12d, 2.2.4.3, 2.2.4.5 → 2.2.5.4 |
| 3 | **RETORNO A3-OA-RE-D-21-55** | 2024-11-17 → 2025-02-02 (+77d) | 2025-02-03 → 2025-03-15 (+40d) |  |  |  |
| 1 | **MOVIMIENTO DE TIERRAS** | 2024-11-17 → 2025-02-02 (+77d) | 2025-01-30 → 2025-03-10 (+39d) |  |  |  |
| 2.3.1.1 | EXCAVACIÓN ESTRUCTURAL PARA OBRAS DE ARTE | 2024-11-17 → 2025-02-02 (+77d) | 2024-11-19 → 2025-02-04 (+77d) |  | 7d → 48d | 1.2.2 SS+4d, INICIO DE EXCAVACIÓN SS, 1.5.1.1 → 1.5.1.8 |
| 2.3.1.2 | RELLENO ESTRUCTURAL PARA OBRAS DE ARTE, CON MATERIAL PROPIO | 2025-01-28 → 2025-03-08 (+39d) | 2025-01-30 → 2025-03-10 (+39d) |  | 11d → 48d | 2.3.2.2 FS+12d → 2.3.2.2 |
| 2 | **OBRAS DE CONCRETO** | 2024-11-20 → 2025-02-05 (+77d) | 2025-01-15 → 2025-03-07 (+51d) |  |  |  |
| 2.3.2.3 | CONCRETO CICLÓPEO f'c=280 kg/cm2 + 30% P.G. | 2024-12-07 → 2025-02-05 (+60d) | 2024-12-21 → 2025-02-08 (+49d) | 15d → 4d | 7d → 48d | 2.3.2.1 → 2.3.1.1 |
| 2.3.2.1 | CONCRETO f'c=100 kg/cm2 | 2024-11-20 → 2025-02-09 (+81d) | 2024-12-06 → 2025-02-11 (+67d) | 17d → 3d | 7d → 48d | 2.3.1.1 → 2.3.2.3 |
| 2.3.2.5 | ACERO DE REFUERZO fy=4200 kg/cm2 | 2024-12-07 → 2025-02-12 (+67d) | 2024-12-30 → 2025-02-24 (+56d) | 24d → 13d | 7d → 48d | 2.3.2.3 SS → 2.3.2.1 |
| 2.3.2.4 | ENCOFRADO Y DESENCOFRADO | 2024-12-07 → 2025-02-22 (+77d) | 2024-12-31 → 2025-02-27 (+58d) | 25d → 6d | 7d → 48d | 2.3.2.5 SS → 2.3.2.5 FS-3d |
| 2.3.2.6 | JUNTA WATER STOP SIN BULBO 150 mm | 2025-01-01 → 2025-02-28 (+58d) | 2025-01-15 → 2025-03-03 (+47d) | 15d → 4d | 26d → 48d | 2.3.2.2 SS → 2.3.2.4 |
| 2.3.2.2 | CONCRETO f'c=280 kg/cm2 | 2025-01-01 → 2025-03-04 (+62d) | 2025-01-15 → 2025-03-07 (+51d) | 15d → 4d | 7d → 48d | 2.3.2.4 → 2.3.2.6 |
| 3 | **ESTRUCTURAS METALICAS** | 2025-01-28 → 2025-03-11 (+42d) | 2025-02-03 → 2025-03-15 (+40d) |  |  |  |
| 2.3.3.1 | COMPUERTA METALICA PLANA DESLIZANTE DE 1.0x1.6 m | 2025-01-28 → 2025-03-11 (+42d) | 2025-01-31 → 2025-03-13 (+41d) | 4d → 3d | 7d → 48d | 2.3.2.2 FS+12d, 2.1.3.5 → 2.3.1.2 |
| 2.3.3.2 | BARANDA DE FIERRO GALVANIZADO 1 1/2" | 2025-02-01 → 2025-03-14 (+41d) | 2025-02-03 → 2025-03-15 (+40d) | 3d → 2d | 7d → 48d |  |
| 4 | **REPOSICIÓN DE CANALES** | 2024-11-19 → 2024-11-01 (-18d) | 2025-04-25 → 2025-04-16 (-9d) |  |  |  |
| 1 | **REPOSICIÓN DE CANAL 1** | 2025-01-01 → 2025-01-26 (+25d) | 2025-04-23 → 2025-04-16 (-7d) |  |  |  |
| 1 | **MOVIMIENTO DE TIERRAS** | 2025-01-01 → 2025-01-26 (+25d) | 2025-02-11 → 2025-04-16 (+64d) |  |  |  |
| 2.4.1.1.1 | DEMOLICIÓN DE ESTRUCTURAS EXISTENTES | 2025-01-01 → 2025-01-26 (+25d) | 2025-01-17 → 2025-01-28 (+11d) | 17d → 3d | 35d → 16d | 1.5.5.109 → 1.5.4.8 |
| 2.4.1.1.2 | EXCAVACIÓN EN TERRENO NATURAL CON EQUIPO | 2025-02-16 → 2025-01-29 (-18d) | 2025-02-24 → 2025-02-04 (-20d) | 9d → 7d | 9d → 16d | COLOCACION Y ACOMODO DE ROCA EN UÑA DE DIQUE → 2.4.1.1.1 |
| 2.4.1.1.3 | RELLENO ESTRUCTURAL PARA OBRAS DE ARTE CON MATERIAL PROPIO | 2025-01-10 → 2025-04-08 (+88d) | 2025-02-04 → 2025-04-16 (+71d) | 26d → 9d | 6d → 16d | 1.5.2.1 SS+45d → 2.4.1.2.4 FS-3d |
| 2 | **OBRAS DE CONCRETO** | 2025-01-31 → 2025-02-05 (+5d) | 2025-04-23 → 2025-04-13 (-10d) |  |  |  |
| 2.4.1.2.3 | CONCRETO f'c=100 kg/cm2 | 2025-01-31 → 2025-02-05 (+5d) | 2025-03-07 → 2025-02-11 (-24d) | 36d → 7d | 11d → 16d | EXCAVACIÓN EN TERRENO NATURAL CON EQUIPO SS, 2.3.1.2 → 2.4.1.1.2 |
| 2.4.1.2.2 | ACERO DE REFUERZO fy=4200 kg/cm2 | 2025-01-31 → 2025-02-12 (+12d) | 2025-03-22 → 2025-03-11 (-11d) | 51d → 28d | 11d → 16d | 2.4.1.2.3 SS → 2.4.1.2.3 |
| 2.4.1.2.1 | ENCOFRADO Y DESENCOFRADO RECTO | 2025-04-06 → 2025-02-20 (-45d) | 2025-04-17 → 2025-03-23 (-25d) | 12d → 32d | 4d → 16d | 2.4.2.2.1 SS → 2.4.1.2.2 SS+8d |
| 2.4.1.2.5 | JUNTA WATER STOP 6" | 2025-02-14 → 2025-03-24 (+38d) | 2025-03-30 → 2025-03-31 (+1d) | 45d → 8d | 10d → 16d | 2.4.1.2.4 SS, 2.2.3.5 → 2.4.1.2.1 |
| 2.4.1.2.4 | CONCRETO f'c=280 kg/cm2 | 2025-02-05 → 2025-04-01 (+55d) | 2025-03-30 → 2025-04-10 (+11d) | 54d → 10d | 6d → 16d | ENCOFRADO RECTO SS, 2.4.1.1.3 → 2.4.1.2.5 |
| 2.4.1.2.6 | MAMPOSTERIA DE PIEDRA, e=20cm, ACABADO CARA VISTA | 2025-04-03 → 2025-04-11 (+8d) | 2025-04-08 → 2025-04-13 (+5d) | 6d → 3d | 18d → 19d | 2.4.1.2.4, 2.1.6.7 → 2.4.1.2.4 |
| 2 | **REPOSICIÓN DE CANAL 3** | 2024-11-19 → 2024-11-01 (-18d) | 2025-04-25 → 2024-12-27 (-119d) |  |  |  |
| 1 | **MOVIMIENTO DE TIERRAS** | 2024-11-19 → 2024-11-01 (-18d) | 2025-04-01 → 2024-12-17 (-105d) |  |  |  |
| 2.4.2.1.1 | DEMOLICIÓN DE ESTRUCTURAS EXISTENTES | 2024-11-19 → 2024-11-01 (-18d) | 2024-11-30 → 2024-11-07 (-23d) | 12d → 7d | 105d → 126d | 1.5.5.19 → H1 |

| ID | Task | Start | Finish | Duration | Total float | Predecessors | Other |
| --- | --- | --- | --- | --- | --- | --- | --- |
| 2.4.2.1.2 | EXCAVACIÓN EN TERRENO NATURAL CON EQUIPO | 2025-03-20 → 2024-11-08 (-132d) | 2025-03-28 → 2024-11-10 (-138d) | 9d → 3d | 9d → 126d | COLOCACION Y ACOMODO DE ROCA EN UÑA DE DIQUE → 2.4.2.1.1 |  |
| 2.4.2.1.3 | RELLENO ESTRUCTURAL PARA OBRAS DE ARTE CON MATERIAL PROPIO | 2025-03-30 → 2024-12-15 (-105d) | 2025-04-01 → 2024-12-17 (-105d) |  | 4d → 136d | EXCAVACIÓN EN TERRENO NATURAL CON EQUIPO, 2.1.6.2 SS, 2.2.5.2 SS → 2.4.2.2.5 |  |
| 2 | **OBRAS DE CONCRETO** | 2025-04-02 → 2024-11-11 (-142d) | 2025-04-25 → 2024-12-27 (-119d) |  |  |  |  |
| 2.4.2.2.4 | CONCRETO f'c=100 kg/cm2 | 2025-04-02 → 2024-11-11 (-142d) | 2025-04-05 → 2024-11-14 (-142d) |  | 4d → 126d | 2.4.2.1.3, 2.4.1.1.3 → 2.4.2.1.2 |  |
| 2.4.2.2.3 | MALLA ELECTROSOLDADA DE DN6mm EN CUADRICULA 15x15 cm | 2025-04-06 → 2024-11-15 (-142d) | 2025-04-18 → 2024-11-23 (-146d) | 13d → 9d | 4d → 126d |  |  |
| 2.4.2.2.1 | ENCOFRADO Y DESENCOFRADO PARA REVESTIMIENTO DE CANALES (CERCHAS) | 2025-04-06 → 2024-11-23 (-134d) | 2025-04-17 → 2024-11-26 (-142d) | 12d → 4d | 4d → 126d | 2.4.2.2.3 SS, 2.4.1.2.5, 1.6.3 → 2.4.2.2.3 FS-1d |  |
| 2.4.2.2.2 | ENCOFRADO Y DESENCOFRADO RECTO | 2025-01-23 → 2024-11-27 (-57d) | 2025-02-04 → 2024-12-09 (-57d) |  | 63d → 126d | 2.5.10 → 2.4.2.2.1 |  |
| 2.4.2.2.5 | CONCRETO f'c=280 kg/cm2 | 2025-04-18 → 2024-12-10 (-129d) | 2025-04-22 → 2024-12-14 (-129d) |  | 4d → 126d | 2.4.1.2.1 → 2.4.2.2.2 |  |
| 2.4.2.2.6 | SELLO DE JUNTA CONSTRUCCIÓN CON MATERIAL ELASTOMÉRICO | 2025-04-06 → 2024-12-15 (-112d) | 2025-04-13 → 2024-12-27 (-107d) | 8d → 13d | 16d → 126d | 2.4.2.2.1 SS → 2.4.2.2.5 |  |
| 2.4.2.2.7 | MAMPOSTERIA DE PIEDRA, e=20cm, ACABADO CARA VISTA | 2025-04-23 → 2024-12-15 (-129d) | 2025-04-25 → 2024-12-17 (-129d) |  | 4d → 136d | 2.4.2.2.5, 2.4.1.2.6 → 2.4.2.2.5 |  |
| 5 | **REPOSICIÓN SIFON INOPERATIVO** | 2024-12-10 → 2024-11-12 (-28d) | 2025-02-25 → 2024-12-24 (-63d) |  |  |  |  |
| 2.5.1 | DEMOLICIÓN DE ESTRUCTURAS EXISTENTES | 2024-12-10 → 2024-11-12 (-28d) | 2024-12-13 → 2024-11-14 (-29d) | 4d → 3d | 48d → 44d | DESCOLMATACIÓN DE CAUCE NATURAL DEL RÍO LACRAMARCA - DIQUE A3-D-01, DESCOLMATACIÓN DE CAUCE NATURAL DEL RÍO LACRAMARCA - DIQUE A3-I-01 FF → H2 SS+6d |  |
| 2.5.2 | EXCAVACIÓN ESTRUCTURAL PARA OBRAS DE ARTE | 2024-12-14 → 2024-11-15 (-29d) | 2024-12-24 → 2024-11-21 (-33d) | 11d → 7d | 48d → 44d |  |  |
| 2.5.3 | COLOCACIÓN CAMA DE ARENA | 2024-12-25 → 2024-11-22 (-33d) | 2024-12-29 → 2024-11-25 (-34d) | 5d → 4d | 104d → 44d |  |  |
| 2.5.11 | CODOS HDPE DE 14" DN 355mm | 2024-12-30 → 2024-11-26 (-34d) | 2025-01-05 → 2024-12-02 (-34d) |  | 114d → 44d |  |  |
| 2.5.6 | TUBERÍAS DE 14" HDPE SDR21 DN 355mm | 2024-12-30 → 2024-11-26 (-34d) | 2025-01-05 → 2024-12-02 (-34d) |  | 104d → 44d |  |  |
| 2.5.5 | RELLENO COMÚN | 2025-01-06 → 2024-12-03 (-34d) | 2025-01-15 → 2024-12-09 (-37d) | 10d → 7d | 104d → 44d | 2.5.6 → 2.5.6, 2.5.11 |  |
| 2.5.4 | RELLENO ESTRUCTURAL PARA OBRAS DE ARTE CON MATERIAL PROPIO | 2025-02-21 → 2024-12-10 (-73d) | 2025-02-25 → 2024-12-12 (-75d) | 5d → 3d | 63d → 44d | 2.5.8 → 2.5.5 |  |
| 2.5.7 | CONCRETO f'c=100 kg/cm2 | 2024-12-25 → 2024-12-13 (-12d) | 2025-01-09 → 2024-12-15 (-25d) | 16d → 3d | 63d → 129d | 2.5.2 → 2.5.4 |  |
| 2.5.10 | ACERO DE REFUERZO fy=4200 kg/cm2 | 2025-01-10 → 2024-12-16 (-25d) | 2025-01-22 → 2024-12-18 (-35d) | 13d → 3d | 63d → 129d |  |  |
| 2.5.8 | CONCRETO f'c=280 kg/cm2 | 2025-02-05 → 2024-12-22 (-45d) | 2025-02-20 → 2024-12-24 (-58d) | 16d → 3d | 63d → 129d | 2.4.2.2.2 → 2.5.9 |  |
| 4 | **ARQUITECTURA Y PAISAJISMO** | 2025-01-23 → 2025-01-26 (+3d) | 2025-04-24 → 2025-03-26 (-29d) |  |  |  |  |
| 1 | **OBRAS PRELIMINARES** | 2025-01-23 → 2025-01-26 (+3d) | 2025-04-24 → 2025-02-05 (-78d) |  |  |  |  |
| 4.1.2 | TRAZO Y REPLANTEO PRELIMINAR | 2025-01-31 → 2025-02-01 (+1d) | 2025-02-07 → 2025-02-05 (-2d) | 8d → 5d | 5d → 0d | MOVILIZACIÓN DE EQUIPOS Y HERRAMIENTAS (ARQUITECTURA Y PAISAJISMO) → 4.1.1 |  |
| 2 | **MOVIMIENTO DE TIERRAS** | 2025-02-08 → 2025-02-06 (-2d) | 2025-02-27 → 2025-02-19 (-8d) |  |  |  |  |
| 4.2.1 | EXCAVACIÓN MANUAL PARA INSTALACIÓN DE BORDILLOS Y CIMENTACIONES | 2025-02-08 → 2025-02-06 (-2d) | 2025-02-09 → 2025-02-10 (+1d) | 2d → 5d | 5d → 0d |  |  |
| 4.2.2 | EXCAVACIÓN PARA MEJORAMIENTO DE SUELO CON TIERRA VEGETAL | 2025-02-10 → 2025-02-07 (-3d) | 2025-02-24 → 2025-02-14 (-10d) | 15d → 8d | 5d → 0d | 4.2.1 → 4.2.1 SS+1d |  |
| 4.2.3 | ELIMINACION DE MATERIAL EXCEDENTE (DME´S) | 2025-02-08 → 2025-02-15 (+7d) | 2025-02-27 → 2025-02-19 (-8d) | 20d → 5d | 53d → 72d | 4.2.1 SS → 4.2.2 |  |
| 3 | **PAVIMENTOS, RECUBRIMIENTOS Y BORDILLOS** | 2025-02-25 → 2025-02-15 (-10d) | 2025-03-07 → 2025-03-04 (-3d) |  |  |  |  |
| 4.3.1 | PISO DE GRAVILLA | 2025-02-25 → 2025-02-15 (-10d) | 2025-02-26 → 2025-02-17 (-9d) | 2d → 3d | 5d → 0d |  |  |
| 4.3.2 | RECUBRIMIENTO DE PIEDRA DEL LUGAR e=0.05cm | 2025-02-27 → 2025-02-18 (-9d) | 2025-03-02 → 2025-02-27 (-3d) | 4d → 10d | 5d → 0d |  |  |
| 4.3.3 | BORDILLOS DE PIEDRA DEL LUGAR | 2025-03-03 → 2025-02-28 (-3d) | 2025-03-07 → 2025-03-04 (-3d) |  | 5d → 0d |  |  |
| 4 | **MOBILIARIOS, BARANDAS Y ESCALERAS** | 2025-03-08 → 2025-03-05 (-3d) | 2025-04-14 → 2025-03-26 (-19d) |  |  |  |  |
| 4.4.1 | ESCALERA DE CONCRETO SOBRE ENROCADO, CIMENTACION Y ANCLAJE | 2025-03-08 → 2025-03-05 (-3d) | 2025-03-17 → 2025-03-08 (-9d) | 10d → 4d | 5d → 0d |  |  |
| 4.4.2 | BARANDA DE MADERA EUCALIPTO CON SOGA, INCLUYE CIMENTACIÓN | 2025-03-18 → 2025-03-09 (-9d) | 2025-03-21 → 2025-03-11 (-10d) | 4d → 3d | 5d → 0d |  |  |
| 4.4.7 | BOLARDOS DE PIEDRA | 2025-04-12 → 2025-03-12 (-31d) | 2025-04-14 → 2025-03-14 (-31d) |  | 5d → 37d | 4.4.6 → 4.4.2 |  |
| 4.4.5 | POSTES DE ILUMINACIÓN, INCLUYE LUMINARIA Y CIMENTACIÓN | 2025-04-04 → 2025-03-15 (-20d) | 2025-04-08 → 2025-03-17 (-22d) | 5d → 3d | 5d → 37d | 4.4.4 → 4.4.7 |  |
| 4.4.4 | BANCAS DE CONCRETO, INCLUYE CIMENTACIÓN | 2025-03-25 → 2025-03-18 (-7d) | 2025-04-03 → 2025-03-20 (-14d) | 10d → 3d | 5d → 37d | 4.4.3 → 4.4.5 |  |
| 4.4.3 | TACHOS DE BASURA, INCLUYE CIMENTACIÓN | 2025-03-22 → 2025-03-21 (-1d) | 2025-03-24 → 2025-03-23 (-1d) |  | 5d → 37d | 4.4.2 → 4.4.4 |  |
| 4.4.6 | SEÑALETICA INFORMATIVA | 2025-04-09 → 2025-03-24 (-16d) | 2025-04-11 → 2025-03-26 (-16d) |  | 5d → 37d | 4.4.5 → 4.4.3 |  |
| 5 | **INSTALACIÓN DE ALCORQUES** | 2025-04-15 → 2025-03-05 (-41d) | 2025-04-16 → 2025-03-07 (-40d) |  |  |  |  |
| 4.5.1 | ALCORQUES DE PIEDRA DE CANTO RODADO PARA ARBOLES | 2025-04-15 → 2025-03-05 (-41d) | 2025-04-16 → 2025-03-07 (-40d) | 2d → 3d | 5d → 56d | 4.4.7 → 4.3.3 |  |
| 5 | **PROGRAMA DE CIERRE DE OBRA** | 2024-11-06 → 2024-11-09 (+3d) | 2025-04-22 → 2025-05-02 (+10d) |  |  |  |  |
| 5.1 | ACONDICIONAMIENTO DE DEPOSITOS DE MATERIALES EXCEDENTES (DME) | 2024-11-06 → 2024-11-09 (+3d) | 2025-04-14 → 2025-04-22 (+8d) | 160d → 165d | 7d → 10d | 1.4.1 SS → 3.5 SS+3d, 3.6 SS+3d | resources none → Tractor D6 [1579 h]; Operador Tractor [1579 h] |
| 5.2 | RESTAURACIÓN DE ÁREAS DE INSTALACIONES PROVISIONALES | 2025-04-15 → 2025-03-19 (-27d) | 2025-04-22 → 2025-05-02 (+10d) | 8d → 45d | 7d → 0d | 5.1 → 4.4.2 FS+7d |  |
